# NCDOT PDN Schedule

Schedule from MS Project, 2024-11-01 to 2027-01-15.

## Calendars

- NCDOT Holiday Calendar: Mon-Fri 08:00-12:00, 13:00-17:00; Sat-Sun off. Exceptions (off unless hours are given): 2024-11-11 (Veterans Day), 2024-11-25 to 2024-11-29 (Thanksgiving [Week]), 2024-12-23 to 2024-12-27 (Christmas [Week]), 2025-01-01 (New Years), 2025-01-20 (MLK), 2025-04-18 (Good Friday), 2025-05-26 (Memorial Day), 2025-07-04 (Independence Day), 2025-09-01 (Labor Day), 2025-11-11 (Veterans Day), 2025-11-24 to 2025-11-28 (Thanksgiving [Week]), 2025-12-22 to 2025-12-26 (Christmas [Week]), 2026-01-01 (New Years), 2026-01-19 (MLK), 2026-04-03 (Good Friday), 2026-05-25 (Memorial Day), 2026-07-03 (Independence Day), 2026-09-07 (Labor Day), 2026-11-11 (Veterans Day), 2026-11-23 to 2026-11-27 (Thanksgiving [Week]), 2026-12-21 to 2026-12-25 (Christmas [Week]), 2027-01-01 (New Years).

## Resources

| Resource |
| --- |
| Transportation Planning |
| Division CDE's |
| Feasibility Studies |
| Funds Administration |
| STIP Unit |
| All Parties |
| NCDOT |
| HNTB |
| UTILITY PEF |
| NCDOT/HNTB |

## Schedule

| ID | WBS | Task | Type | Duration | Start | Finish | Predecessors | Total slack | Free slack | Task Code | Discipline Code | Responsible Party | SAP MLSN |
| --- | --- | --- | --- | --- | --- | --- | --- | --- | --- | --- | --- | --- | --- |
| 1 | 1 | **WBS# - BRIDGE PROJECT NAME/DESCRIPTION** |  | 530d | 2024-11-01 | 2027-01-15 |  | 0d |  |  |  |  |  |
| 2 | 1.1 | **Scoping, Fee Estimate, and Notice to Proceed (Stage 1 & 2)** |  | 40d | 2024-11-01 | 2025-01-13 |  | 0d |  | SCOPE | SCOPE |  |  |
| 3 | 1.1.1 | Project Scoping Meeting | milestone | 0d | 2024-11-01 | 2024-11-01 |  | 0d |  | SCOPE | SCOPE | All Parties |  |
| 4 | 1.1.2 | Scope Development |  | 10d | 2024-11-01 | 2024-11-15 | 3 | 0d |  | SCOPE | SCOPE | PEF |  |
| 5 | 1.1.3 | Review/Approve Scope |  | 10d | 2024-11-18 | 2024-12-06 | 4 | 0d |  | SCOPE | SCOPE | NCDOT |  |
| 6 | 1.1.4 | Fee Estimate Development |  | 10d | 2024-12-09 | 2024-12-20 | 5 | 0d |  | SCOPE | SCOPE | PEF |  |
| 7 | 1.1.5 | Review/Approve Fee Estimate |  | 10d | 2024-12-30 | 2025-01-13 | 6 | 0d |  | SCOPE | SCOPE | NCDOT |  |
| 8 | 1.1.6 | Notice To Proceed (Stage 1 & 2) | milestone | 0d | 2025-01-13 | 2025-01-13 | 7 | 0d |  | SCOPE | SCOPE | NCDOT | M0965 |
| 9 | 1.2 | **Project Initiation (Stage 1)** |  | 80d | 2025-01-14 | 2025-05-07 |  | 0d |  |  |  |  |  |
| 10 | 1.2.1 | Complete Final Surveys |  | 40d | 2025-01-14 | 2025-03-11 | 2 | 25d |  | 2LS1 | LS | NCDOT |  |
| 11 | 1.2.2 | **Requests for Human & Environment Studies** |  | 10d | 2025-01-14 | 2025-01-28 |  | 245d |  | 1EN1 | EN |  |  |
| 12 | 1.2.2.1 | Prepare & Submit ETRACS Request for Historic Architecture |  | 10d | 2025-01-14 | 2025-01-28 | 8 | 245d | 0d | 1EN1 | EN | PEF |  |
| 13 | 1.2.2.2 | Prepare & Submit ETRACS Request for Archaeology |  | 10d | 2025-01-14 | 2025-01-28 | 8 | 245d | 0d | 1EN1 | EN | PEF |  |
| 14 | 1.2.3 | **Land Owner Notification Letters** |  | 10d | 2025-01-14 | 2025-01-28 |  | 200d |  | 1EN1 | EN |  |  |
| 15 | 1.2.3.1 | Prepare & Submit Land Owner Notification Letters |  | 10d | 2025-01-14 | 2025-01-28 | 8 | 200d | 0d | 1EN1 | EN | PEF |  |
| 16 | 1.2.3.2 | Send Out Land Owner Notification Letters | milestone | 0d | 2025-01-28 | 2025-01-28 | 15 | 200d | 0d | 1EN1 | EN | PEF |  |
| 17 | 1.2.4 | **Initiate NEPA/SEPA Review** |  | 20d | 2025-01-14 | 2025-02-11 |  | 0d |  | 1EP1 | EP |  |  |
| 18 | 1.2.4.1 | **Project Initiation and Merger Process** |  | 20d | 2025-01-14 | 2025-02-11 |  | 0d |  | 1EP1 | EP |  |  |
| 19 | 1.2.4.1.1 | Prepare Project Initiation Form |  | 10d | 2025-01-14 | 2025-01-28 | 8 | 0d |  | 1EP1 | EP | PEF |  |
| 20 | 1.2.4.1.2 | Prepare Start of Study E-mail List |  | 10d | 2025-01-14 | 2025-01-28 | 8 | 0d |  | 1EP1 | EP | PEF |  |
| 21 | 1.2.4.1.3 | Prepare Merger Pre-Screening Form |  | 10d | 2025-01-14 | 2025-01-28 | 8 | 0d |  | 1EP1 | EP | PEF |  |
| 22 | 1.2.4.1.4 | Review of Project Initiation Items |  | 10d | 2025-01-29 | 2025-02-11 | 20, 19, 21 | 0d |  | 1EP1 | EP | NCDOT |  |
| 23 | 1.2.4.1.5 | Approve Start of Study/Project Initiation Items | milestone | 0d | 2025-02-11 | 2025-02-11 | 22 | 0d |  | 1EP1 | EP | NCDOT |  |
| 24 | 1.2.4.1.6 | Send out Start of Study E-mail Package | milestone | 0d | 2025-02-11 | 2025-02-11 | 23 | 0d |  | 1EP1 | EP | PEF |  |

Notes:
- 12: Tied to Stage 2 Screenings
- 13: Tied to Stage 2 Screenings
- 23: Tied to Start of CE
- 24: Tied to sending out complete streets request

| ID | WBS | Task | Type | Duration | Start | Finish | Predecessors | Total slack | Free slack | Task Code | Discipline Code | Responsible Party |
| --- | --- | --- | --- | --- | --- | --- | --- | --- | --- | --- | --- | --- |
| 25 | 1.2.5 | **Initiate Complete Streets Review** |  | 45d | 2025-02-12 | 2025-04-15 |  | 0d |  | 1IM1 | IM |  |
| 26 | 1.2.5.1 | Prepare & Submit Complete Streets Project Sheet |  | 5d | 2025-02-12 | 2025-02-18 | 24 | 0d |  | 1IM1 | IM | PEF |
| 27 | 1.2.5.2 | Review of Complete Streets Project Sheet |  | 40d | 2025-02-19 | 2025-04-15 | 26 | 0d |  | 1IM1 | IM | NCDOT |
| 28 | 1.2.5.3 | Complete Streets Recommendations | milestone | 0d | 2025-04-15 | 2025-04-15 | 27 | 0d |  | 1IM1 | IM | NCDOT |
| 29 | 1.2.6 | **Initiate Public Engagement Tasks** |  | 30d | 2025-03-26 | 2025-05-07 |  | 125d |  | 1PI1 | PI |  |
| 30 | 1.2.6.1 | Prepare & Submit Draft Public Involvement Plan (PIP) |  | 10d | 2025-03-26 | 2025-04-08 | 135 | 125d | 0d | 1PI1 | PI | PEF |
| 31 | 1.2.6.2 | Review of Draft PIP |  | 10d | 2025-04-09 | 2025-04-23 | 30 | 125d | 0d | 1PI1 | PI | NCDOT |
| 32 | 1.2.6.3 | Revise & Submit Final PIP |  | 5d | 2025-04-24 | 2025-04-30 | 31 | 125d | 0d | 1PI1 | PI | PEF |
| 33 | 1.2.6.4 | Review of Final PIP |  | 5d | 2025-05-01 | 2025-05-07 | 32 | 125d | 0d | 1PI1 | PI | NCDOT |
| 34 | 1.2.6.5 | Final PIP Approved | milestone | 0d | 2025-05-07 | 2025-05-07 | 33 | 125d | 15d | 1PI1 | PI | NCDOT |
| 35 | 1.2.7 | Develop Initial Utility Relocation and Utility Construction Estimates |  | 10d | 2025-02-12 | 2025-02-25 | 23 | 430d | 0d | 1UT1 | UT | UTILITY PEF |
| 36 | 1.2.8 | **Investigate Existing Utilities** |  | 30d | 2025-02-26 | 2025-04-08 |  | 430d |  | 1UT2 | UT |  |
| 37 | 1.2.8.1 | Prepare & Submit Draft Critical Utilities Strategy |  | 10d | 2025-02-26 | 2025-03-11 | 35 | 430d | 0d | 1UT2 | UT | UTILITY PEF |
| 38 | 1.2.8.2 | Review of Draft Critical Utilities Strategy |  | 10d | 2025-03-12 | 2025-03-25 | 37 | 430d | 0d | 1UT2 | UT | NCDOT |
| 39 | 1.2.8.3 | Revise & Submit Final Critical Utilities Strategy |  | 5d | 2025-03-26 | 2025-04-01 | 38 | 430d | 0d | 1UT2 | UT | UTILITY PEF |
| 40 | 1.2.8.4 | Review of Final Critical Utilities Strategy |  | 5d | 2025-04-02 | 2025-04-08 | 39 | 430d | 0d | 1UT2 | UT | NCDOT |
| 41 | 1.2.8.5 | Final Critical Utilities Strategy Approved | milestone | 0d | 2025-04-08 | 2025-04-08 | 40 | 430d |  | 1UT2 | UT | NCDOT |
| 42 | 1.3 | **Environmental and ROW Plans (Stage 2)** |  | 270d | 2025-01-29 | 2026-03-05 |  | 55d |  |  |  |  |
| 43 | 1.3.1 | **Complete Design Recommendation Plan Set** |  | 30d | 2025-04-16 | 2025-05-29 |  | 0d |  | 2RD2 | RD |  |
| 44 | 1.3.1.1 | Prepare & Submit Design Recommendation Plan Set |  | 10d | 2025-04-16 | 2025-04-30 | 28, 10 | 0d |  | 2RD2 | RD | PEF |
| 45 | 1.3.1.2 | Prepare Initial Design Estimates |  | 10d | 2025-04-16 | 2025-04-30 | 44FF, 28, 10 | 0d |  | 2CS1 | CS | PEF |
| 46 | 1.3.1.3 | Review of Design Recommendation Plan Set |  | 10d | 2025-05-01 | 2025-05-14 | 44, 45 | 0d |  | 2RD2 | RD | NCDOT |
| 47 | 1.3.1.4 | Revise & Resubmit Design Recommendation Plan Set |  | 5d | 2025-05-15 | 2025-05-21 | 46 | 0d |  | 2RD2 | RD | PEF |
| 48 | 1.3.1.5 | Review of Revised Design Recommendation Plan Set |  | 5d | 2025-05-22 | 2025-05-29 | 47 | 0d |  | 2RD2 | RD | NCDOT |
| 49 | 1.3.1.6 | Design Recommendation Plan Set Approved | milestone | 0d | 2025-05-29 | 2025-05-29 | 48 | 0d |  | 2RD2 | RD | NCDOT |

Notes:
- 34: Tied to Public Meeting Maps
- 45: Estimate needed 7 months prior to ROW Fund Request

| ID | WBS | Task | Type | Duration | Start | Finish | Predecessors | Total slack | Free slack | Task Code | Discipline Code | Responsible Party |
| --- | --- | --- | --- | --- | --- | --- | --- | --- | --- | --- | --- | --- |
| 50 | 1.3.2 | **Develop Preliminary Hydraulic Recommendations** |  | 5d | 2025-05-30 | 2025-06-05 |  | 0d |  | 2HY1 | HY |  |
| 51 | 1.3.2.1 | Prepare & Submit Hydraulic Planning Report (HPR) |  | 5d | 2025-05-30 | 2025-06-05 | 49 | 0d |  | 2HY1 | HY | PEF |
| 52 | 1.3.3 | **Complete Drainage Design** |  | 110d | 2025-06-06 | 2025-11-10 |  | 0d |  | 2HY2 | HY |  |
| 53 | 1.3.3.1 | Prepare & Submit Hydraulic Designs & BSR |  | 20d | 2025-06-06 | 2025-07-03 | 51 | 0d |  | 2HY2 | HY | PEF |
| 54 | 1.3.3.2 | Review of Hydraulic Designs & BSR |  | 10d | 2025-07-07 | 2025-07-18 | 53 | 35d | 0d | 2HY2 | HY | NCDOT |
| 55 | 1.3.3.3 | Revise & Resubmit Hydraulic Designs & BSR |  | 10d | 2025-07-21 | 2025-08-01 | 54 | 35d | 0d | 2HY2 | HY | PEF |
| 56 | 1.3.3.4 | Review of Revised Hydraulic Designs & BSR |  | 5d | 2025-08-04 | 2025-08-08 | 55 | 35d | 0d | 2HY2 | HY | NCDOT |
| 57 | 1.3.3.5 | Hydraulic Designs & BSR Approved | milestone | 0d | 2025-08-08 | 2025-08-08 | 56 | 35d | 0d | 2HY2 | HY | NCDOT |
| 58 | 1.3.3.6 | State Floodplain Compliance (SFC) Package |  | 5d | 2025-08-11 | 2025-08-15 | 57 | 210d | 0d | 2HY2 | HY | PEF |
| 59 | 1.3.3.7 | NC SFC Review & Approval |  | 60d | 2025-08-18 | 2025-11-10 | 58 | 210d | 200d | 2HY2 | HY | AGENCY |
| 60 | 1.3.4 | **Develop Preliminary General Drawings** |  | 20d | 2025-08-11 | 2025-09-08 |  | 45d |  | 2ST2 | ST |  |
| 61 | 1.3.4.1 | Prepare & Submit PGDs |  | 10d | 2025-08-11 | 2025-08-22 | 57 | 45d | 0d | 2ST2 | ST | PEF |
| 62 | 1.3.4.2 | Review of PGDs |  | 10d | 2025-08-25 | 2025-09-08 | 61 | 45d | 10d | 2ST2 | ST | NCDOT |
| 63 | 1.3.5 | **Complete Safety Analysis and Operational Review** |  | 20d | 2025-05-30 | 2025-06-26 |  | 90d |  | 2TS1 | TS |  |
| 64 | 1.3.5.1 | Traffic Signal Recommendations |  | 20d | 2025-05-30 | 2025-06-26 | 49 | 90d | 0d | 2TS1 | TS | NCDOT |
| 65 | 1.3.6 | Establish Signal & ITS Locations |  | 20d | 2025-06-27 | 2025-07-25 | 49, 64 | 90d | 35d | 2SG1 | SG | PEF |
| 66 | 1.3.7 | **Advance Utility Coordination and/or Design** |  | 115d | 2025-07-07 | 2025-12-30 |  | 0d |  | 2UT3 | UT |  |
| 67 | 1.3.7.1 | Provide Plans to Utility Owners |  | 5d | 2025-07-07 | 2025-07-11 | 53 | 0d |  | 2UT3 | UT | UTILITY PEF |
| 68 | 1.3.7.2 | Identify Major Utility Conflicts and Relocation Impacts |  | 5d | 2025-07-07 | 2025-07-11 | 53 | 0d |  | 2UT3 | UT | UTILITY PEF |
| 69 | 1.3.7.3 | Conduct Utility Coordination Meeting (All Utilities) | milestone | 0d | 2025-07-11 | 2025-07-11 | 68, 67 | 0d |  | 2UT3 | UT | UTILITY PEF |
| 70 | 1.3.7.4 | Initiate Cost Responsibility Analysis |  | 5d | 2025-07-14 | 2025-07-18 | 69 | 360d |  | 2UT3 | UT | UTILITY PEF |
| 71 | 1.3.7.5 | Utility Owners Develop Routing Plans |  | 40d | 2025-07-14 | 2025-09-08 | 69 | 55d | 0d | 2UT3 | UT | UTILITY OWNERS |
| 72 | 1.3.7.6 | Submit Routing Plan/Preliminary UBO Plans |  | 5d | 2025-09-09 | 2025-09-15 | 71, 65FF | 55d | 0d | 2UT3 | UT | UTILITY PEF |
| 73 | 1.3.7.7 | Create Relocation Schedule |  | 5d | 2025-09-16 | 2025-09-22 | 72 | 55d |  | 2UT3 | UT | UTILITY PEF |
| 74 | 1.3.7.8 | Submit Preliminary Utility Construction Routing Plans (30%) |  | 20d | 2025-07-14 | 2025-08-08 | 69 | 0d |  | 2UT3 | UT | UTILITY PEF |
| 75 | 1.3.7.9 | Review of 30% UC Plans |  | 10d | 2025-08-11 | 2025-08-22 | 74 | 0d |  | 2UT3 | UT | NCDOT |
| 76 | 1.3.7.10 | Request Subsurface Utility Engineering (SUE) Level A |  | 5d | 2025-08-25 | 2025-08-29 | 75 | 0d |  | 2UT3 | UT | UTILITY PEF |
| 77 | 1.3.7.11 | Complete SUE Level A |  | 40d | 2025-09-02 | 2025-10-27 | 76 | 0d |  | 2LS2 | LS | NCDOT |
| 78 | 1.3.7.12 | Submit Preliminary Utility Construction Plans (60%) |  | 20d | 2025-10-28 | 2025-12-02 | 75, 77 | 0d |  | 2UT3 | UT | UTILITY PEF |
| 79 | 1.3.7.13 | Review of 60% UC Plans |  | 10d | 2025-12-03 | 2025-12-16 | 78 | 0d |  | 2UT3 | UT | NCDOT |
| 80 | 1.3.7.14 | Request Geotechnical Investigation for Trenchless Construction |  | 5d | 2025-12-17 | 2025-12-30 | 79 | 15d |  | 2UT3 | UT | UTILITY PEF |
| 81 | 1.3.7.15 | Submit Required Utility Easements and Parcel List |  | 5d | 2025-12-17 | 2025-12-30 | 72, 79 | 15d |  | 2UT3 | UT | UTILITY PEF |
| 82 | 1.3.8 | Prepare Utility Relocation and Construction Estimates |  | 10d | 2025-12-17 | 2026-01-07 | 72, 79 | 0d |  | 2UT4 | UT | UTILITY PEF |

Notes:
- 65: Need initial signal location for UBO routing
- 73: Tied to FI Plans
- 80: Tied to ROW Plans
- 81: Tied to ROW Plans
- 82: Tied to Field Inspection

| ID | WBS | Task | Type | Duration | Start | Finish | Predecessors | Total slack | Free slack | Task Code | Discipline Code | Responsible Party |
| --- | --- | --- | --- | --- | --- | --- | --- | --- | --- | --- | --- | --- |
| 83 | 1.3.9 | **Initiate Erosion and Sediment Control Plans** |  | 30d | 2025-08-11 | 2025-09-22 |  | 35d |  | 2RE1 | RE |  |
| 84 | 1.3.9.1 | Prepare & Submit E&SC Field Inspection Plans |  | 10d | 2025-08-11 | 2025-08-22 | 57 | 35d | 0d | 2RE1 | RE | PEF |
| 85 | 1.3.9.2 | Review of E&SC Field Inspection Plans |  | 10d | 2025-08-25 | 2025-09-08 | 84 | 35d | 0d | 2RE1 | RE | NCDOT |
| 86 | 1.3.9.3 | Revise & Resubmit E&SC Field Inspection Plans |  | 5d | 2025-09-09 | 2025-09-15 | 85 | 35d | 0d | 2RE1 | RE | PEF |
| 87 | 1.3.9.4 | Review of Revised E&SC Field Inspection Plans |  | 5d | 2025-09-16 | 2025-09-22 | 86 | 35d | 0d | 2RE1 | RE | NCDOT |
| 88 | 1.3.9.5 | E&SC Field Inspection Plans Approved | milestone | 0d | 2025-09-22 | 2025-09-22 | 87 | 35d | 0d | 2RE1 | RE | NCDOT |
| 89 | 1.3.10 | **Public Engagement** |  | 70d | 2025-05-30 | 2025-09-08 |  | 110d |  | 2PI1 | PI |  |
| 90 | 1.3.10.1 | **Public Meeting Map** |  | 30d | 2025-05-30 | 2025-07-11 |  | 110d |  | 2PI1 | PI |  |
| 91 | 1.3.10.1.1 | Develop Public Meeting Maps |  | 10d | 2025-05-30 | 2025-06-12 | 49, 34 | 110d | 0d | 2PI1 | PI | PEF |
| 92 | 1.3.10.1.2 | Review of Public Meeting Maps |  | 10d | 2025-06-13 | 2025-06-26 | 91 | 110d | 0d | 2PI1 | PI | NCDOT |
| 93 | 1.3.10.1.3 | Revise & Resubmit Public Meeting Maps |  | 5d | 2025-06-27 | 2025-07-03 | 92 | 110d | 0d | 2PI1 | PI | PEF |
| 94 | 1.3.10.1.4 | Review of Revised Public Meeting Maps |  | 5d | 2025-07-07 | 2025-07-11 | 93 | 110d | 0d | 2PI1 | PI | NCDOT |
| 95 | 1.3.10.1.5 | Public Meeting Maps Approved | milestone | 0d | 2025-07-11 | 2025-07-11 | 94 | 110d | 0d | 2PI1 | PI | NCDOT |
| 96 | 1.3.10.2 | **Postcard** |  | 40d | 2025-05-30 | 2025-07-25 |  | 355d |  | 2PI1 | PI |  |
| 97 | 1.3.10.2.1 | Develop Postcard |  | 5d | 2025-05-30 | 2025-06-05 | 49 | 370d | 0d | 2PI1 | PI | PEF |
| 98 | 1.3.10.2.2 | Review of Postcard |  | 10d | 2025-06-06 | 2025-06-19 | 97 | 370d | 0d | 2PI1 | PI | NCDOT |
| 99 | 1.3.10.2.3 | Revise & Resubmit Postcard |  | 5d | 2025-06-20 | 2025-06-26 | 98 | 370d | 0d | 2PI1 | PI | PEF |
| 100 | 1.3.10.2.4 | Review of Revised Postcard |  | 5d | 2025-06-27 | 2025-07-03 | 99 | 370d | 0d | 2PI1 | PI | NCDOT |
| 101 | 1.3.10.2.5 | Postcards Approved | milestone | 0d | 2025-07-03 | 2025-07-03 | 100 | 370d | 15d | 2PI1 | PI | NCDOT |
| 102 | 1.3.10.2.6 | Send Out Postcard | milestone | 0d | 2025-07-25 | 2025-07-25 | 101, 110SF | 355d |  | 2PI1 | PI | PEF |
| 103 | 1.3.10.3 | **Website** |  | 40d | 2025-05-30 | 2025-07-25 |  | 110d |  | 2PI1 | PI |  |
| 104 | 1.3.10.3.1 | Develop Website Template |  | 10d | 2025-05-30 | 2025-06-12 | 49 | 110d | 0d | 2PI1 | PI | PEF |
| 105 | 1.3.10.3.2 | Review of Website Template |  | 10d | 2025-06-13 | 2025-06-26 | 104 | 110d | 0d | 2PI1 | PI | NCDOT |
| 106 | 1.3.10.3.3 | Revise & Resubmit Website Template |  | 5d | 2025-06-27 | 2025-07-03 | 105 | 110d | 0d | 2PI1 | PI | PEF |
| 107 | 1.3.10.3.4 | Review of Revised Website Template |  | 5d | 2025-07-07 | 2025-07-11 | 106 | 110d | 0d | 2PI1 | PI | NCDOT |
| 108 | 1.3.10.3.5 | Website Template Approved | milestone | 0d | 2025-07-11 | 2025-07-11 | 107 | 110d | 0d | 2PI1 | PI | NCDOT |
| 109 | 1.3.10.3.6 | Creation of Website |  | 10d | 2025-07-14 | 2025-07-25 | 108, 95 | 110d | 0d | 2PI1 | PI | NCDOT |
| 110 | 1.3.10.3.7 | Website Goes Live | milestone | 0d | 2025-07-25 | 2025-07-25 | 109 | 110d | 0d | 2PI1 | PI | NCDOT |

| ID | WBS | Task | Type | Duration | Start | Finish | Predecessors | Total slack | Free slack | Task Code | Discipline Code | Responsible Party |
| --- | --- | --- | --- | --- | --- | --- | --- | --- | --- | --- | --- | --- |
| 111 | 1.3.10.4 | **Public Involvement Comment and Responses** |  | 30d | 2025-07-28 | 2025-09-08 |  | 110d |  | 2PI1 | PI |  |
| 112 | 1.3.10.4.1 | Gathering Public Comments |  | 20d | 2025-07-28 | 2025-08-22 | 110 | 110d | 0d | 2PI1 | PI | NCDOT |
| 113 | 1.3.10.4.2 | Response to Public Comments |  | 10d | 2025-08-25 | 2025-09-08 | 112 | 110d | 0d | 2PI1 | PI | PEF |
| 114 | 1.3.11 | Roadway Geotechnical & Geopavement Investigations |  | 40d | 2025-05-30 | 2025-07-25 | 49 | 95d |  | 2GT2 | GT | NCDOT |
| 115 | 1.3.12 | Geotechnical Structure Investigations |  | 40d | 2025-08-11 | 2025-10-06 | 57 | 275d | 0d | 2GT3 | GT | NCDOT |
| 116 | 1.3.13 | **Complete Pavement Design** |  | 40d | 2025-05-30 | 2025-07-25 |  | 95d |  | 2PD1 | PD |  |
| 117 | 1.3.13.1 | Final Pavement Design Memo |  | 40d | 2025-05-30 | 2025-07-25 | 49 | 95d |  | 2PD1 | PD | NCDOT |
| 118 | 1.3.14 | **Initiate Natural Resources Analysis** |  | 65d | 2025-01-29 | 2025-04-30 |  | 200d |  | 2EN1 | EN |  |
| 119 | 1.3.14.1 | **Complete NRTR and WEX File** |  | 30d | 2025-01-29 | 2025-03-11 |  | 200d |  | 2EN1 | EN |  |
| 120 | 1.3.14.1.1 | Conduct Wetland Delineations and Field Surveys |  | 5d | 2025-01-29 | 2025-02-04 | 16 | 200d | 0d | 2LS1 | LS | ENVIRONMENTAL PEF |
| 121 | 1.3.14.1.2 | Prepare & Submit Draft NRTR and PJD Package |  | 10d | 2025-02-05 | 2025-02-18 | 120 | 200d | 0d | 2EN1 | EN | ENVIRONMENTAL PEF |
| 122 | 1.3.14.1.3 | Review of Draft NRTR and PJD Package |  | 10d | 2025-02-19 | 2025-03-04 | 121 | 200d | 0d | 2EN1 | EN | NCDOT |
| 123 | 1.3.14.1.4 | Revise & Resubmit Final NRTR and PJD Package |  | 5d | 2025-03-05 | 2025-03-11 | 122 | 200d | 0d | 2EN1 | EN | ENVIRONMENTAL PEF |
| 124 | 1.3.14.2 | **Signed PJD** |  | 35d | 2025-03-12 | 2025-04-30 |  | 200d |  | 2EN1 | EN |  |
| 125 | 1.3.14.2.1 | Review PJD Package |  | 25d | 2025-03-12 | 2025-04-15 | 123 | 200d | 0d | 2EN1 | EN | AGENCY |
| 126 | 1.3.14.2.2 | Conduct Agency Field Review |  | 5d | 2025-04-16 | 2025-04-23 | 125 | 200d | 0d | 2EN1 | EN | AGENCY |
| 127 | 1.3.14.2.3 | Create WET File and Revise PJD Package (If Necessary) |  | 5d | 2025-04-24 | 2025-04-30 | 126 | 200d | 0d | 2EN1 | EN | ENVIRONMENTAL PEF |
| 128 | 1.3.14.2.4 | Sign PJD | milestone | 0d | 2025-04-30 | 2025-04-30 | 127 | 200d | 90d | 2EN1 | EN | AGENCY |
| 129 | 1.3.15 | **Initiate Human Environment Analysis** |  | 40d | 2025-01-29 | 2025-03-25 |  | 135d |  | 2EN2 | EN |  |
| 130 | 1.3.15.1 | **Direct and Indirect Screening Tool (DIST)** |  | 30d | 2025-02-12 | 2025-03-25 |  | 125d |  | 2EN2 | EN |  |
| 131 | 1.3.15.1.1 | Prepare & Submit Draft DIST |  | 10d | 2025-02-12 | 2025-02-25 | 23 | 125d | 0d | 2EN2 | EN | PEF |
| 132 | 1.3.15.1.2 | Review of Draft DIST |  | 10d | 2025-02-26 | 2025-03-11 | 131 | 125d | 0d | 2EN2 | EN | NCDOT |
| 133 | 1.3.15.1.3 | Revise & Resubmit DIST |  | 5d | 2025-03-12 | 2025-03-18 | 132 | 125d | 0d | 2EN2 | EN | PEF |
| 134 | 1.3.15.1.4 | Review of Revised DIST |  | 5d | 2025-03-19 | 2025-03-25 | 133 | 125d | 0d | 2EN2 | EN | NCDOT |
| 135 | 1.3.15.1.5 | Direct and Indirect Screening Tool Approved | milestone | 0d | 2025-03-25 | 2025-03-25 | 134 | 125d | 0d | 2EN2 | EN | NCDOT |

Notes:
- 115: Includes Foundation Recs. Start after Hydro approval.
- 128: Tied to Start of CE
- 135: Complete CIA by draft DRPS Submission

| ID | WBS | Task | Type | Duration | Start | Finish | Predecessors | Total slack | Free slack | Task Code | Discipline Code | Responsible Party |
| --- | --- | --- | --- | --- | --- | --- | --- | --- | --- | --- | --- | --- |
| 136 | 1.3.15.2 | **Complete Cultural Resource Screenings** |  | 20d | 2025-01-29 | 2025-02-25 |  | 245d |  | 2EN2 | EN |  |
| 137 | 1.3.15.2.1 | Complete Historic Architecture and Landscapes No Survey Required Form |  | 20d | 2025-01-29 | 2025-02-25 | 12 | 245d | 135d | 2EN2 | EN | NCDOT |
| 138 | 1.3.15.2.2 | Complete No Archaeological Survey Required Form |  | 20d | 2025-01-29 | 2025-02-25 | 13 | 245d | 135d | 2EN2 | EN | NCDOT |
| 139 | 1.3.16 | **Advance NEPA/SEPA Documentation** |  | 30d | 2025-09-09 | 2025-10-20 |  | 110d |  | 2EP1 | EP |  |
| 140 | 1.3.16.1 | Prepare & Submit Draft Categorical Exclusion (CE) |  | 10d | 2025-09-09 | 2025-09-22 | 137, 138, 113, 49, 128, 23, 34 | 110d | 0d | 2EP1 | EP | PEF |
| 141 | 1.3.16.2 | Review of Draft CE |  | 10d | 2025-09-23 | 2025-10-06 | 140 | 110d | 0d | 2EP1 | EP | NCDOT |
| 142 | 1.3.16.3 | Revise & Submit Final CE |  | 5d | 2025-10-07 | 2025-10-13 | 141 | 110d | 0d | 2EP1 | EP | PEF |
| 143 | 1.3.16.4 | Review of Final CE |  | 5d | 2025-10-14 | 2025-10-20 | 142 | 110d | 0d | 2EP1 | EP | NCDOT |
| 144 | 1.3.16.5 | Environmental Document Approved | milestone | 0d | 2025-10-20 | 2025-10-20 | 143 | 110d | 85d | 2EP1 | EP | NCDOT |
| 145 | 1.3.17 | **Initiate Transportation Management Plan** |  | 10d | 2025-12-03 | 2025-12-17 |  | 210d |  | 2TM2 | TM |  |
| 146 | 1.3.17.1 | Complete Concept Temporary Traffic Control (TTC) Plans |  | 10d | 2025-12-03 | 2025-12-17 | 151SF, 152SF, 49 | 210d | 0d | 2TM2 | TM | PEF |
| 147 | 1.3.18 | **Initiate Signing and Delineation Design** |  | 10d | 2025-12-03 | 2025-12-17 |  | 260d |  | SD | SD |  |
| 148 | 1.3.18.1 | Prepare Preliminary Signing and Delineation Strip Map |  | 10d | 2025-12-03 | 2025-12-17 | 151SF, 152SF, 49 | 260d |  | 2SD1 | SD | PEF |
| 149 | 1.3.19 | Initiate Signal System Timing |  | 10d | 2025-12-17 | 2026-01-07 | 146 | 210d | 40d | 2SS1 | SS | PEF |
| 150 | 1.3.20 | **Prepare for Field Inspection** |  | 20d | 2025-12-17 | 2026-01-22 |  | 0d |  | 2RD3 | RD |  |
| 151 | 1.3.20.1 | Prepare Field Construction Estimate |  | 10d | 2025-12-17 | 2026-01-07 | 114, 117, 88, 73, 57, 62, 64, 82FF | 0d |  | 2CS2 | CS | PEF |
| 152 | 1.3.20.2 | Prepare Field Inspection Plans Set |  | 10d | 2025-12-17 | 2026-01-07 | 114, 117, 73, 88, 82FF, 57, 62, 64 | 0d |  | 2RD3 | RD | PEF |
| 153 | 1.3.20.3 | Review of Field Inspection Plan Set |  | 10d | 2026-01-08 | 2026-01-22 | 151, 152 | 0d |  | 2RD3 | RD | NCDOT |
| 154 | 1.3.20.4 | Field Inspection | milestone | 0d | 2026-01-22 | 2026-01-22 | 153 | 0d |  | 2RD3 | RD | NCDOT |
| 155 | 1.3.21 | **ROW Plans Completed** |  | 140d | 2025-08-04 | 2026-03-05 |  | 110d |  | 2RD4 | RD |  |
| 156 | 1.3.21.1 | Prepare ROW Cost Estimate |  | 10d | 2025-08-04 | 2025-08-15 | 49, 173SS-140d | 340d |  | 2RW2 | RW | ROW PEF |
| 157 | 1.3.21.2 | Complete & Submit ROW Plan Set |  | 10d | 2026-01-23 | 2026-02-05 | 169, 154, 80, 81 | 0d |  | 2RD4 | RD | PEF |
| 158 | 1.3.21.3 | Review of ROW Plan Set |  | 10d | 2026-02-06 | 2026-02-19 | 157 | 0d |  | 2RD4 | RD | NCDOT |
| 159 | 1.3.21.4 | Revise & Resubmit ROW Plan Set |  | 5d | 2026-02-20 | 2026-02-26 | 158 | 0d |  | 2RD4 | RD | PEF |
| 160 | 1.3.21.5 | Review of Revised ROW Plan Set |  | 5d | 2026-02-27 | 2026-03-05 | 159 | 0d |  | 2RD4 | RD | NCDOT |
| 161 | 1.3.21.6 | ROW Plans Complete (RPC) | milestone | 0d | 2026-03-05 | 2026-03-05 | 160 | 0d |  | 2RD4 | RD |  |
| 162 | 1.3.21.7 | Prepare ROW Cost Estimate |  | 10d | 2026-01-23 | 2026-02-05 | 154 | 25d | 0d | 2RW3 | RW | ROW PEF |
| 163 | 1.3.21.8 | Review of ROW Cost Estimate |  | 20d | 2026-02-06 | 2026-03-05 | 162 | 25d | 0d | 2RW3 | RW | NCDOT |

Notes:
- 137: Tied to Request in Stage 1
- 138: Tied to Request in Stage 1
- 142: Need Final TNR and 4(f) Signed de minimis Agreement for Final CE
- 156: Estimate needed 7 months prior to ROW Fund Request

| ID | WBS | Task | Type | Duration | Start | Finish | Predecessors | Total slack | Free slack | Task Code | Discipline Code | Responsible Party |
| --- | --- | --- | --- | --- | --- | --- | --- | --- | --- | --- | --- | --- |
| 164 | 1.4 | **Scoping, Fee Estimate, and Notice to Proceed (Stage 3 & 4)** |  | 40d | 2025-09-23 | 2025-11-18 |  | 35d |  | SCOPE | SCOPE |  |
| 165 | 1.4.1 | Scope Development |  | 10d | 2025-09-23 | 2025-10-06 | 88, 57, 62 | 35d | 0d | SCOPE | SCOPE | PEF |
| 166 | 1.4.2 | Review/Approve Scope |  | 10d | 2025-10-07 | 2025-10-20 | 165 | 35d | 0d | SCOPE | SCOPE | NCDOT |
| 167 | 1.4.3 | Fee Estimate Development |  | 10d | 2025-10-21 | 2025-11-03 | 166 | 35d | 0d | SCOPE | SCOPE | PEF |
| 168 | 1.4.4 | Review/Approve Fee Estimate |  | 10d | 2025-11-04 | 2025-11-18 | 167 | 35d | 0d | SCOPE | SCOPE | NCDOT |
| 169 | 1.4.5 | Notice To Proceed (Stage 3 & 4) | milestone | 0d | 2025-11-18 | 2025-11-18 | 168 | 35d |  | SCOPE | SCOPE |  |
| 170 | 1.5 | **Final Plans (Stage 3)** |  | 215d | 2025-10-07 | 2026-08-26 |  | 90d |  |  |  |  |
| 171 | 1.5.1 | **Right of Way Funding** |  | 90d | 2025-12-03 | 2026-04-17 |  | 85d |  | 3RW1 | RW |  |
| 172 | 1.5.1.1 | Complete NEPA/SEPA Documentation |  | 10d | 2025-12-03 | 2025-12-16 | 173SS-60d | 260d |  | 3EP1 | EP | PEF |
| 173 | 1.5.1.2 | Complete ROW Authorization Package |  | 30d | 2026-03-06 | 2026-04-17 | 163, 144 | 25d | 0d | 3RW1 | RW | NCDOT |
| 174 | 1.5.1.3 | ROW Funds Released | milestone | 0d | 2026-04-17 | 2026-04-17 | 173 | 25d | 0d | 3RW1 | RW | NCDOT |
| 175 | 1.5.2 | Complete Additional Surveys and ROW Acquisition Surveys |  | 20d | 2026-03-06 | 2026-04-02 | 161 | 95d | 70d | 3LS1 | LS | NCDOT |
| 176 | 1.5.3 | **Complete ROW Acquisitions and Relocations** |  | 60d | 2026-04-20 | 2026-07-14 |  | 25d |  | 3RW2 | RW | ROW PEF |
| 177 | 1.5.3.1 | ROW Acquisition |  | 60d | 2026-04-20 | 2026-07-14 | 174, 175FF, 161 | 25d | 0d | 3RW2 | RW | ROW PEF |
| 178 | 1.5.3.2 | ROW Certification | milestone | 0d | 2026-07-14 | 2026-07-14 | 177 | 25d | 0d | 3RW2 | RW | NCDOT |
| 179 | 1.5.4 | **Complete Roadway Design** |  | 40d | 2026-03-06 | 2026-05-01 |  | 150d |  | 3RD1 | RD |  |
| 180 | 1.5.4.1 | Complete & Submit Final Roadway Plan Set |  | 20d | 2026-03-06 | 2026-04-02 | 169, 161 | 150d | 0d | 3RD1 | RD | PEF |
| 181 | 1.5.4.2 | Review Final Roadway Plan Set |  | 10d | 2026-04-06 | 2026-04-17 | 180 | 150d | 0d | 3RD1 | RD | NCDOT |
| 182 | 1.5.4.3 | Revise & Resubmit Final Roadway Plan Set |  | 5d | 2026-04-20 | 2026-04-24 | 181 | 150d | 0d | 3RD1 | RD | PEF |
| 183 | 1.5.4.4 | Review Revised Final Roadway Plan Set |  | 5d | 2026-04-27 | 2026-05-01 | 182 | 150d | 0d | 3RD1 | RD | NCDOT |
| 184 | 1.5.4.5 | Final Roadway Plan Set Approved | milestone | 0d | 2026-05-01 | 2026-05-01 | 183 | 150d | 20d | 3RD1 | RD | NCDOT |
| 185 | 1.5.5 | **Complete Utility Coordination and/or Design** |  | 95d | 2026-03-06 | 2026-07-21 |  | 0d |  | 3UT1 | UT |  |
| 186 | 1.5.5.1 | Prepare & Submit Utilities By Other (UBO) Plans |  | 20d | 2026-03-06 | 2026-04-02 | 161 | 0d |  | 3UT1 | UT | UTILITY PEF |
| 187 | 1.5.5.2 | Review of UBO Plans |  | 10d | 2026-04-06 | 2026-04-17 | 186 | 0d |  | 3UT1 | UT | NCDOT |
| 188 | 1.5.5.3 | Revise & Resubmit UBO Plans |  | 5d | 2026-04-20 | 2026-04-24 | 187 | 0d |  | 3UT1 | UT | UTILITY PEF |
| 189 | 1.5.5.4 | Review of Revised UBO Plans |  | 5d | 2026-04-27 | 2026-05-01 | 188 | 0d |  | 3UT1 | UT | NCDOT |
| 190 | 1.5.5.5 | UBO Plans Approved | milestone | 0d | 2026-05-01 | 2026-05-01 | 189 | 0d |  | 3UT1 | UT | NCDOT |
| 191 | 1.5.5.6 | Prepare & Submit Final Utility Construction (UC) Plans to NCDOT & Utility Owners |  | 20d | 2026-03-06 | 2026-04-02 | 161 | 20d | 0d | 3UT1 | UT | UTILITY PEF |
| 192 | 1.5.5.7 | Review of Final UC Plans |  | 20d | 2026-04-06 | 2026-05-01 | 191 | 25d | 0d | 3UT1 | UT | NCDOT / UO |
| 193 | 1.5.5.8 | Revise & Resubmit Final UC Plans to Utility Owners |  | 10d | 2026-05-04 | 2026-05-15 | 192 | 25d | 0d | 3UT1 | UT | UTILITY PEF |
| 194 | 1.5.5.9 | Utility Owners Review of Revised Final UC Plans |  | 10d | 2026-05-18 | 2026-06-01 | 193 | 25d | 0d | 3UT1 | UT | UTILITY OWNERS |
| 195 | 1.5.5.10 | Final UC Plans Approved | milestone | 0d | 2026-06-01 | 2026-06-01 | 194 | 25d | 0d | 3UT1 | UT | UTILITY OWNERS |
| 196 | 1.5.5.11 | Finalize Permit Applications (Prepare/Submit/Receive Signatures) |  | 5d | 2026-06-02 | 2026-06-08 | 195 | 25d | 0d | 3UT1 | UT | UTILITY PEF |
| 197 | 1.5.5.12 | Submit Final UC Plan Package to NCDEQ Water Supply Section for Review | milestone | 0d | 2026-06-08 | 2026-06-08 | 196 | 25d | 0d | 3UT1 | UT | UTILITY PEF |
| 198 | 1.5.5.13 | Review of Final UC Plan Package |  | 20d | 2026-06-09 | 2026-07-07 | 197 | 25d | 0d | 3UT1 | UT | AGENCY |
| 199 | 1.5.5.14 | Revise & Resubmit Final UC Plan Package to Utility Owners |  | 5d | 2026-07-08 | 2026-07-14 | 198 | 25d | 0d | 3UT1 | UT | UTILITY PEF |
| 200 | 1.5.5.15 | Review of Revised Final UC Plan Package |  | 5d | 2026-07-15 | 2026-07-21 | 199 | 25d | 0d | 3UT1 | UT | AGENCY |
| 201 | 1.5.5.16 | Issue Authorization to Construct | milestone | 0d | 2026-07-21 | 2026-07-21 | 200 | 25d | 5d | 3UT1 | UT | AGENCY |

Notes:
- 172: 3 months prior to ROW Fund Request Complete ROW Consult. If needed
- 173: Includes Board Authorization of Funds, Match up with Board Dates
- 175: Concurrent with Start of ROW. Adjust as needed.
- 180: Tied to ROW Acquisition Phase 2 (adjust as needed)

| ID | WBS | Task | Type | Duration | Start | Finish | Predecessors | Total slack | Free slack | Task Code | Discipline Code | Responsible Party |
| --- | --- | --- | --- | --- | --- | --- | --- | --- | --- | --- | --- | --- |
| 202 | 1.5.6 | **Initiate Utility Relocations by Others** |  | 10d | 2026-05-04 | 2026-05-15 |  | 100d |  | 3UT2 | UT |  |
| 203 | 1.5.6.1 | Update the Utilities Relocation Schedule |  | 10d | 2026-05-04 | 2026-05-15 | 190 | 100d | 0d | 3UT2 | UT | UTILITY PEF |
| 204 | 1.5.6.2 | Hold Relocation Scheduling Conference | milestone | 0d | 2026-05-15 | 2026-05-15 | 203 | 100d | 70d | 3UT2 | UT | NCDOT |
| 205 | 1.5.7 | **Complete Erosion and Sediment Control Plans** |  | 30d | 2026-05-04 | 2026-06-15 |  | 0d |  | 3RE1 | RE |  |
| 206 | 1.5.7.1 | Prepare & Submit Erosion Control Plan Package |  | 10d | 2026-05-04 | 2026-05-15 | 161, 190, 191 | 0d |  | 3RE1 | RE | PEF |
| 207 | 1.5.7.2 | Review of Erosion Control Package |  | 10d | 2026-05-18 | 2026-06-01 | 206 | 0d |  | 3RE1 | RE | NCDOT |
| 208 | 1.5.7.3 | Revise & Resubmit Erosion Control Package |  | 5d | 2026-06-02 | 2026-06-08 | 207 | 0d |  | 3RE1 | RE | PEF |
| 209 | 1.5.7.4 | Approve Erosion Control Package |  | 5d | 2026-06-09 | 2026-06-15 | 208 | 0d |  | 3RE1 | RE | NCDOT |
| 210 | 1.5.7.5 | Erosion Control Package Approved | milestone | 0d | 2026-06-15 | 2026-06-15 | 209 | 0d |  | 3RE1 | RE | NCDOT |
| 211 | 1.5.8 | **Complete Hydraulic Permitting Tasks and Finalize Plans** |  | 30d | 2026-05-04 | 2026-06-15 |  | 0d |  | 3HY1 | HY |  |
| 212 | 1.5.8.1 | Prepare & Submit Permit Drawing Package |  | 10d | 2026-05-04 | 2026-05-15 | 161, 190, 191 | 0d |  | 3HY1 | HY | PEF |
| 213 | 1.5.8.2 | Review of Permit Drawing Package |  | 10d | 2026-05-18 | 2026-06-01 | 212 | 0d |  | 3HY1 | HY | NCDOT |
| 214 | 1.5.8.3 | Revise & Resubmit Permit Drawing Package |  | 5d | 2026-06-02 | 2026-06-08 | 213 | 0d |  | 3HY1 | HY | PEF |
| 215 | 1.5.8.4 | Approve Permit Drawing Package |  | 5d | 2026-06-09 | 2026-06-15 | 214 | 0d |  | 3HY1 | HY | NCDOT |
| 216 | 1.5.8.5 | Permit Drawing Package Approved | milestone | 0d | 2026-06-15 | 2026-06-15 | 215 | 0d |  | 3HY1 | HY | NCDOT |
| 217 | 1.5.9 | **Complete Permit Application Package** |  | 50d | 2026-06-16 | 2026-08-25 |  | 0d |  | 3EN2 | EN |  |
| 218 | 1.5.9.1 | Prepare & Submit Permit Application Package |  | 10d | 2026-06-16 | 2026-06-29 | 210, 216 | 0d |  | 3EN2 | EN | ENVIRONMENTAL PEF |
| 219 | 1.5.9.2 | Review of Permit Application Package |  | 40d | 2026-06-30 | 2026-08-25 | 218 | 0d |  | 3EN2 | EN | AGENCY |
| 220 | 1.5.10 | **Complete Structures Design** |  | 20d | 2025-10-07 | 2025-11-03 |  | 275d |  | 3ST1 | ST |  |
| 221 | 1.5.10.1 | Prepare & Submit Final (Unsealed) Structure Plans |  | 10d | 2025-10-07 | 2025-10-20 | 62, 115 | 275d | 0d | 3ST1 | ST | PEF |
| 222 | 1.5.10.2 | Review of Final (Unsealed) Structure Plans |  | 10d | 2025-10-21 | 2025-11-03 | 221 | 275d | 175d | 3ST1 | ST | NCDOT |
| 223 | 1.5.11 | **Complete Signal & ITS Design** |  | 180d | 2025-12-03 | 2026-08-26 |  | 90d |  | 3SG1 | SG |  |
| 224 | 1.5.11.1 | Prepare & Submit 1st Signal Submittal (Temporary Poles and Geometrics) |  | 40d | 2025-12-03 | 2026-02-06 | 225SF | 200d | 0d | 3SG1 | SG | PEF |
| 225 | 1.5.11.2 | Review of 1st Submittal |  | 20d | 2026-02-06 | 2026-03-06 | 226SF | 200d | 0d | 3SG1 | SG | NCDOT |
| 226 | 1.5.11.3 | Revise & Submit 2nd Signal Submittal (Include Wiring) |  | 40d | 2026-03-06 | 2026-05-04 | 227SF, 149 | 170d | 0d | 3SG1 | SG | PEF |
| 227 | 1.5.11.4 | Review of 2nd Submittal |  | 20d | 2026-05-04 | 2026-06-02 | 228SF | 150d | 0d | 3SG1 | SG | NCDOT |
| 228 | 1.5.11.5 | Revise & Submit 3rd Signal Submittal (Final Plans) |  | 40d | 2026-06-02 | 2026-07-29 | 229SF | 110d | 0d | 3SG1 | SG | PEF |
| 229 | 1.5.11.6 | Review of 3rd Submittal |  | 20d | 2026-07-29 | 2026-08-26 | 230SF | 90d | 0d | 3SG1 | SG | NCDOT |
| 230 | 1.5.11.7 | Signal Plans Approved | milestone | 0d | 2026-08-26 | 2026-08-26 | 259SF, 272SF | 90d | 0d | 3SG1 | SG | NCDOT |

| ID | WBS | Task | Type | Duration | Start | Finish | Predecessors | Total slack | Free slack | Task Code | Discipline Code | Responsible Party |
| --- | --- | --- | --- | --- | --- | --- | --- | --- | --- | --- | --- | --- |
| 231 | 1.5.12 | **Complete Signing and Delineation Design** |  | 180d | 2025-12-03 | 2026-08-26 |  | 90d |  | 3SD1 | SD |  |
| 232 | 1.5.12.1 | Prepare 100% Unsealed Signing and Delineation Plans |  | 40d | 2025-12-03 | 2026-02-05 | 224SS | 200d | 0d | 3SD1 | SD | PEF |
| 233 | 1.5.12.2 | Review of 100% Unsealed Submittal |  | 10d | 2026-02-06 | 2026-02-19 | 232 | 200d | 110d | 3SD1 | SD | NCDOT |
| 234 | 1.5.12.3 | Prepare 100% Sealed Signing and Delineation Plans |  | 20d | 2026-07-29 | 2026-08-26 | 233, 259SF, 272SF | 90d |  | 3SD1 | SD | PEF |
| 235 | 1.5.13 | Complete Transportation Management Plan |  | 20d | 2026-07-29 | 2026-08-26 | 259SF, 161, 272SF | 90d |  | 3TM1 | TM | PEF |
| 236 | 1.5.14 | Prepare Construction Estimate |  | 10d | 2026-06-02 | 2026-06-15 | 266SF-260d, 161, 195, 184, 278SF-260d | 140d |  | 3CS1 | CS | PEF |
| 237 | 1.5.15 | 15 Month Let Review Meeting | milestone | 0d | 2025-10-14 | 2025-10-14 | 269FS-300d, 281FS-300d | 300d |  | 3PM2 | PM | NCDOT |
| 238 | 1.5.16 | **Design Complete Review Meeting** |  | 20d | 2026-06-16 | 2026-07-14 |  | 120d |  | 3PM3 | PM |  |
| 239 | 1.5.16.1 | Finalize Design Completion Review Meeting Materials |  | 10d | 2026-06-16 | 2026-06-29 | 184, 190, 195, 210, 216 | 120d | 0d | 3PM3 | PM | PEF |
| 240 | 1.5.16.2 | Prepare for Completion Review Meeting |  | 10d | 2026-06-30 | 2026-07-14 | 239 | 120d | 0d | 3PM3 | PM | NCDOT |
| 241 | 1.5.16.3 | Conduct Design Complete Review Meeting | milestone | 0d | 2026-07-14 | 2026-07-14 | 240 | 120d | 20d | 3PM3 | PM | NCDOT |
| 242 | 1.6 | **Plans, Specifications, and Estimates (PS&E)/Letting (Stage 4)** |  | 170d | 2026-05-04 | 2027-01-15 |  | 0d |  |  |  |  |
| 243 | 1.6.1 | Secure Permits | milestone | 0d | 2026-08-25 | 2026-08-25 | 219 | 0d |  | 4EN1 | EN | PEF |
| 244 | 1.6.2 | Complete NEPA/SEPA Documentation | milestone | 0d | 2026-09-10 | 2026-09-10 | 266FS-60d, 278FS-60d | 80d |  | 4EP1 | EP | NCDOT |
| 245 | 1.6.3 | **Utility Relocation** |  | 140d | 2026-05-04 | 2026-11-19 |  | 30d |  | 4UT | UT |  |
| 246 | 1.6.3.1 | Finalize Utility Coordination and/or Utility Design PS&E |  | 20d | 2026-05-04 | 2026-06-01 | 190 | 90d | 0d | 4UT1 | UT | UTILITY PEF |
| 247 | 1.6.3.2 | Utility Certification | milestone | 0d | 2026-06-01 | 2026-06-01 | 246 | 105d | 80d | 4UT1 | UT | NCDOT |
| 248 | 1.6.3.3 | Complete Utility Relocation by Owner |  | 60d | 2026-08-26 | 2026-11-19 | 246, 243, 177, 204 | 30d | 5d | 4UT2 | UT | UTILITY OWNERS |
| 249 | 1.6.4 | **Finalize Structures Design PS&E** |  | 20d | 2026-07-29 | 2026-08-26 |  | 90d |  | 4ST1 | ST |  |
| 250 | 1.6.4.1 | Submit Final (Sealed) Structure Plans |  | 10d | 2026-07-29 | 2026-08-12 | 251SF, 222 | 100d |  | 4ST1 | ST | PEF |
| 251 | 1.6.4.2 | Review of Final (Sealed) Structure Plans |  | 10d | 2026-08-12 | 2026-08-26 | 252SF | 90d | 0d | 4ST1 | ST | NCDOT |
| 252 | 1.6.4.3 | Structure Plans Approved | milestone | 0d | 2026-08-26 | 2026-08-26 | 259SF, 272SF | 90d | 0d | 4ST1 | ST | NCDOT |
| 253 | 1.6.5 | Complete ROW Acquisition Surveys |  | 10d | 2026-07-15 | 2026-07-28 | 178 | 25d | 0d | 4LS1 | LS | NCDOT |
| 254 | 1.6.6 | Hydraulic Let Preparation |  | 10d | 2026-08-12 | 2026-08-26 | 259SF, 216, 272SF | 90d |  | 4HY1 | HY | PEF |
| 255 | 1.6.7 | Finalize Erosion & Sediment Control Contract Package |  | 10d | 2026-08-12 | 2026-08-26 | 259SF, 210, 272SF | 90d |  | 4RE1 | RE | PEF |
| 256 | 1.6.8 | PS&E Review Meeting | milestone | 0d | 2026-08-12 | 2026-08-12 | 260FS-30d, 241, 273FS-30d | 100d |  | 4PM2 | PM | NCDOT |

Notes:
- 236: Needs to be done 13 months prior to funding.
- 237: 15 Month Pre-Let Review Meeting
- 241: Tie to 4PM2, Allow time for changes to plans as needed
- 244: Construction Consultation 3 months prior to project authorization
- 256: 6 Weeks prior to PS&E Turn In (RPCP)

| ID | WBS | Task | Type | Duration | Start | Finish | Predecessors | Total slack | Free slack | Task Code | Discipline Code | Responsible Party | SAP MLSN |
| --- | --- | --- | --- | --- | --- | --- | --- | --- | --- | --- | --- | --- | --- |
| 257 | 1.6.9 | **Central Let Activities** |  | 90d | 2026-08-26 | 2027-01-15 |  | 0d |  |  |  |  |  |
| 258 | 1.6.9.1 | **Finalize the PS&E Package** |  | 55d | 2026-08-26 | 2026-11-12 |  | 0d |  | 4RD1 | RD |  |  |
| 259 | 1.6.9.1.1 | Submit 100% Unsealed Plans, Quantities, and Special Provisions |  | 20d | 2026-08-26 | 2026-09-23 | 243, 201, 178 | 0d |  | 4RD1 | RD | PEF |  |
| 260 | 1.6.9.1.2 | Roadway Plans to Contracts & Proposals (RPCP) | milestone | 0d | 2026-09-23 | 2026-09-23 | 259, 59 | 0d |  | 4RD1 | RD | PEF | MLSN |
| 261 | 1.6.9.1.3 | Review of 100% Unsealed Plans, Quantities and Special Provisions |  | 20d | 2026-09-24 | 2026-10-21 | 260 | 0d |  | 4RD1 | RD | NCDOT |  |
| 262 | 1.6.9.1.4 | Revise & Resubmit 100% Unsealed Plans, Quantities and Special Provisions |  | 10d | 2026-10-22 | 2026-11-04 | 253FF, 261 | 0d |  | 4RD1 | RD | PEF |  |
| 263 | 1.6.9.1.5 | Review of Revised 100% Unsealed Plans, Quantities and Special Provisions |  | 5d | 2026-11-05 | 2026-11-12 | 262 | 0d |  | 4RD1 | RD | NCDOT |  |
| 264 | 1.6.9.1.6 | Submit 100% Sealed Plans, Quantities, and Special Provisions | milestone | 0d | 2026-11-12 | 2026-11-12 | 263 | 0d |  | 4RD1 | RD | PEF | MLSN |
| 265 | 1.6.9.2 | **Complete PS&E Package and Advertise the Project** |  | 35d | 2026-11-13 | 2027-01-15 |  | 0d |  | 4CS1 | CS |  |  |
| 266 | 1.6.9.2.1 | Construction Funding Request and Project Authorization |  | 15d | 2026-11-13 | 2026-12-10 | 264, 178, 144, 247 | 0d |  | 4CS1 | CS | NCDOT |  |
| 267 | 1.6.9.2.2 | Advertise Project | milestone | 0d | 2026-12-10 | 2026-12-10 | 266 | 0d |  | 4CS1 | CS | NCDOT | MLSN |
| 268 | 1.6.9.2.3 | Project Advertisement |  | 20d | 2026-12-11 | 2027-01-15 | 267 | 0d |  | 4CS1 | CS | NCDOT |  |
| 269 | 1.6.9.3 | Central Let | milestone | 0d | 2027-01-15 | 2027-01-15 | 248FF, 268 | 0d |  | 4CS2 | CS | NCDOT | M0550 |
| 270 | 1.6.10 | **Division Let Activities** |  | 85d | 2026-07-29 | 2026-12-03 |  | 25d |  |  |  |  |  |
| 271 | 1.6.10.1 | **Finalize the PS&E Package** |  | 30d | 2026-07-29 | 2026-09-09 |  | 25d |  | 4RD1 | RD |  |  |
| 272 | 1.6.10.1.1 | Submit 100% Unsealed Plans, Quantities, and Special Provisions |  | 10d | 2026-07-29 | 2026-08-11 | 201, 178, 253 | 25d | 0d | 4RD1 | RD | PEF |  |
| 273 | 1.6.10.1.2 | Review of 100% Unsealed Plans, Quantities and Special Provisions |  | 10d | 2026-08-12 | 2026-08-25 | 272 | 25d | 0d | 4RD1 | RD | NCDOT |  |
| 274 | 1.6.10.1.3 | Revise & Submit 100% Sealed Plans, Quantities and Special Provisions |  | 10d | 2026-08-26 | 2026-09-09 | 273, 253FF | 25d | 0d | 4RD1 | RD | PEF |  |
| 275 | 1.6.10.1.4 | Submit 100% Sealed Plans, Quantities, and Special Provisions | milestone | 0d | 2026-09-09 | 2026-09-09 | 274 | 25d | 0d | 4RD1 | RD | PEF |  |
| 276 | 1.6.10.2 | **Complete PS&E Package and Advertise the Project** |  | 55d | 2026-09-10 | 2026-12-03 |  | 25d |  | 4CS1 | CS |  |  |
| 277 | 1.6.10.2.1 | Update Construction Estimate Pricing |  | 10d | 2026-09-10 | 2026-09-23 | 275 | 25d | 0d | 4CS1 | CS | NCDOT |  |
| 278 | 1.6.10.2.2 | Construction Funding Request and Project Authorization |  | 30d | 2026-09-24 | 2026-11-04 | 277, 178, 144, 247 | 25d | 0d | 4CS1 | CS | NCDOT |  |
| 279 | 1.6.10.2.3 | Complete PS&E Package |  | 15d | 2026-09-10 | 2026-09-30 | 243, 275, 144, 201, 59 | 50d | 25d | 4CS1 | CS | NCDOT |  |
| 280 | 1.6.10.2.4 | Project Advertisement |  | 15d | 2026-11-05 | 2026-12-03 | 278, 279 | 25d | 0d | 4CS1 | CS | NCDOT |  |
| 281 | 1.6.10.3 | Division POC Let (DPOC) | milestone | 0d | 2026-12-03 | 2026-12-03 | 280, 248FF | 25d |  | 4CS2 | CS | NCDOT |  |

Notes:
- 257: Delete if Division Let
- 268: Advertisement can be longer for larger more expensive projects
- 269: Adjust 4RD1/Critical durations to meet actual central let dates
- 270: Delete if Central Let
- 281: Adjust 4RD1/Critical durations to meet actual division let dates
