# NCDOT PDN 2 Schedule copy

Schedule from MS Project, 2021-06-14 to 2021-07-07.

## Calendars

- Standard: Mon-Fri 08:00-12:00, 13:00-17:00; Sat-Sun off.

## Resources

| Resource |
| --- |
| Transportation Planning |
| Division CDE's |
| Feasibility Studies |
| ? |
| Funds Administration |
| STIP Unit |
| STIP Unit? |

## Schedule

| ID | WBS | Task | Type | Duration | Start | Finish | Predecessors | Total slack | Free slack | Task Code | Discipline Code | SAP MLSN |
| --- | --- | --- | --- | --- | --- | --- | --- | --- | --- | --- | --- | --- |
| 1 | 1 | **Project Initiation (Stg 1)** |  | 5d? | 2021-06-14 | 2021-06-18 |  |  |  |  |  |  |
| 2 | 1.1 | Develop STIP | milestone | 0d | 2021-06-14 | 2021-06-14 |  | 0d |  | MLSN | MLSN |  |
| 3 | 1.2 | Initiate Environmental Analysis |  | 1d? | 2021-06-14 | 2021-06-14 | 2 | 3d |  | 1EN1 | EN |  |
| 4 | 1.3 | Draft STIP |  | 1d? | 2021-06-14 | 2021-06-14 | 2 | 0d |  | MLSN | MLSN |  |
| 5 | 1.4 | Compile Aerial Photography & Mapping |  | 1d? | 2021-06-15 | 2021-06-15 | 4 | 2d |  | 1PH2 | PH |  |
| 6 | 1.5 | Initiate CR-RAVE and CLEAR Activities |  | 1d? | 2021-06-15 | 2021-06-15 | 4 | 2d |  | 1VM1 | VM |  |
| 7 | 1.6 | Initiate Utility Investigations |  | 1d? | 2021-06-15 | 2021-06-15 | 4 | 2d |  | 1UT2 | UT |  |
| 8 | 1.7 | Initiate Public Engagement Tasks |  | 1d? | 2021-06-15 | 2021-06-15 | 4 | 0d |  | 1PI1 | PI |  |
| 9 | 1.8 | Review Project Scoping |  | 1d? | 2021-06-16 | 2021-06-16 | 8 | 0d |  | 1CG1 | CG |  |
| 10 | 1.9 | Provide Photogrammetric Control & Initiate Survey |  | 1d? | 2021-06-16 | 2021-06-16 | 8 | 15d |  | 1LS1 | LS |  |
| 11 | 1.10 | Complete Geotechnical & GeoEnvironmental Screening |  | 1d? | 2021-06-16 | 2021-06-16 | 8 | 15d |  | 1GT1 | GT |  |
| 12 | 1.11 | Initiate Environmental Review |  | 1d? | 2021-06-16 | 2021-06-16 | 8 | 0d |  | 1EP1 | EP |  |
| 13 | 1.12 | Complete Project Scoping Report |  | 1d? | 2021-06-17 | 2021-06-17 | 9, 12 | 0d |  | 1FS3 | FS |  |
| 14 | 1.13 | Request Preliminary Engineering Funds |  | 1d? | 2021-06-18 | 2021-06-18 | 13 | 13d |  |  | PM |  |
| 15 | 1.14 | NTP | milestone | 0d | 2021-06-17 | 2021-06-17 | 3, 5, 6, 7, 13 | 0d |  | MLSN | MLSN | M0965 |
| 16 | 2 | **Alignment Defined (Stg 2)** |  | 6d? | 2021-06-18 | 2021-06-25 |  | 0d |  |  |  |  |
| 17 | 2.1 | Complete Final Surveys |  | 1d? | 2021-06-18 | 2021-06-18 | 15 | 0d |  | 2LS1 | LS |  |
| 18 | 2.2 | Complete SUE Level A & ROW Advance Acquisition Surveys |  | 1d? | 2021-06-18 | 2021-06-18 | 15 | 13d |  | 2LS2 | LS |  |
| 19 | 2.3 | Complete Design Recommendation Plan Set |  | 1d? | 2021-06-21 | 2021-06-21 | 17 | 0d |  | 2RD1 | RD |  |
| 20 | 2.4 | Develop Preliminary Hydraulic Recommendations |  | 1d? | 2021-06-18 | 2021-06-18 | 15 | 2d | 1d | 2HY1 | HY |  |
| 21 | 2.5 | Complete Drainage Design for Field Inspection |  | 1d? | 2021-06-22 | 2021-06-22 | 20, 19 | 1d |  | 2HY2 | HY |  |
| 22 | 2.6 | Prepare GeoEnvironmental Phase I Report |  | 1d? | 2021-06-18 | 2021-06-18 | 15 | 13d |  | 2GT1 | GT |  |
| 23 | 2.7 | Conduct Subsurface Investigations & Provide Roadway Recommendations |  | 1d? | 2021-06-18 | 2021-06-18 | 15 | 13d |  | 2GT2 | GT |  |
| 24 | 2.8 | Complete Pavement & Subgrade Investigation and Recommendations Report (PSIRR) |  | 1d? | 2021-06-18 | 2021-06-18 | 15 | 3d |  | 2GT3 | GT |  |
| 25 | 2.9 | Complete Pavement Design |  | 1d? | 2021-06-18 | 2021-06-18 | 15 | 3d |  | 2PD1 | PD |  |
| 26 | 2.10 | Initiate Structures Design |  | 1d? | 2021-06-22 | 2021-06-22 | 15, 19 | 0d |  | 2ST1 | ST |  |
| 27 | 2.11 | Develop Preliminary General Drawings |  | 1d? | 2021-06-23 | 2021-06-23 | 26 | 0d |  | 2ST2 | ST |  |
| 28 | 2.12 | Advance Natural Environment Tasks |  | 1d? | 2021-06-18 | 2021-06-18 | 15 | 13d |  | 2EN1 | EN |  |
| 29 | 2.13 | Advance Human Environment Tasks |  | 1d? | 2021-06-18 | 2021-06-18 | 15 | 2d | 0d | 2EN2 | EN |  |
| 30 | 2.14 | Prepare Environmental Document |  | 1d? | 2021-06-21 | 2021-06-21 | 29 | 2d |  | 2EP1 | EP |  |
| 31 | 2.15 | Complete Traffic Analysis |  | 1d? | 2021-06-18 | 2021-06-18 | 15 | 2d | 0d | 2TM1 | TM |  |
| 32 | 2.16 | Initiate Transportation Management Plan |  | 1d? | 2021-06-21 | 2021-06-21 | 31 | 12d |  | 2TM2 | TM |  |
| 33 | 2.17 | Initiate Transportation Operations Plan (if a Significant Project) |  | 1d? | 2021-06-21 | 2021-06-21 | 31 | 2d |  | 2TO1 | TO |  |
| 34 | 2.18 | Initiate Railroad Review |  | 1d? | 2021-06-18 | 2021-06-18 | 15 | 3d |  | 2RR1 | RR |  |
| 35 | 2.19 | Initiate Advance Acquisition ROW Tasks |  | 1d? | 2021-06-22 | 2021-06-22 | 15, 19 | 1d |  | 2RW1 | RW |  |
| 36 | 2.20 | Prepare ROW Cost Estimate |  | 1d? | 2021-06-18 | 2021-06-18 | 15 | 2d | 0d | 2RW2 | RW |  |
| 37 | 2.21 | Request ROW Funds |  | 1d? | 2021-06-21 | 2021-06-21 | 36 | 2d |  |  | PM |  |
| 38 | 2.22 | Initiate Utility Coordination |  | 1d? | 2021-06-18 | 2021-06-18 | 15 | 3d |  | 2UT1 | UT |  |
| 39 | 2.23 | Prepare Utility Relocation and Construction Estimates |  | 1d? | 2021-06-18 | 2021-06-18 | 15 | 2d | 0d | 2UT2 | UT |  |
| 40 | 2.24 | Request Utility Funds |  | 1d? | 2021-06-21 | 2021-06-21 | 39 | 2d |  |  | PM |  |
| 41 | 2.25 | Initiate Signal and ITS Design |  | 1d? | 2021-06-22 | 2021-06-22 | 15, 19 | 1d |  | 2SG1 | SG |  |
| 42 | 2.26 | Complete Safety Analysis & Operational Review |  | 1d? | 2021-06-18 | 2021-06-18 | 15 | 3d |  | 2TS1 | TS |  |
| 43 | 2.27 | Initiate Signing and Delineation Design |  | 1d? | 2021-06-22 | 2021-06-22 | 15, 19 | 1d |  | 2SD1 | SD |  |
| 44 | 2.28 | Verify Complete Streets |  | 1d? | 2021-06-22 | 2021-06-22 | 15, 19 | 1d |  | 2IM1 | IM |  |
| 45 | 2.29 | Initiate Erosion and Sediment Control Plans |  | 1d? | 2021-06-22 | 2021-06-22 | 15, 19, 20 | 1d |  | 2RE1 | RE |  |
| 46 | 2.30 | Continue Public Engagement |  | 1d? | 2021-06-18 | 2021-06-18 | 15 | 2d | 0d | 2PI1 | PI |  |
| 47 | 2.31 | Assist with Public Engagement |  | 1d? | 2021-06-21 | 2021-06-21 | 46 | 2d |  | 2CG1 | CG |  |
| 48 | 2.32 | Complete CR-RAVE Studies/Reviews and CLEAR Activities |  | 1d? | 2021-06-18 | 2021-06-18 | 15 | 3d |  | 2VM1 | VM |  |
| 49 | 2.33 | Prepare Initial Design Estimates |  | 1d? | 2021-06-24 | 2021-06-24 | 30, 47, 33, 34, 35, 38, 41, 42, 43, 21, 19, 44, 45, 17, 27, 25, 24, 15, 48, 46, 31, 36, 39, 37, 40 | 0d |  | 2CS1 | CS |  |
| 50 | 2.34 | Prepare for Field Inspection |  | 1d? | 2021-06-25 | 2021-06-25 | 49 | 0d |  | 2RD2 | RD |  |
| 51 | 2.35 | Field Inspection & Environ. Document Complete | milestone | 0d | 2021-06-25 | 2021-06-25 | 50 | 0d |  | MLSN | MLSN | M1006 & # based on Env Doc Type |

Notes:
- 51: SAP number for Field Inspection is M1006. The SAP number for the Env. Doc is dependent on the type of document.

| ID | WBS | Task | Type | Duration | Start | Finish | Predecessors | Total slack | Free slack | Task Code | Discipline Code | SAP MLSN |
| --- | --- | --- | --- | --- | --- | --- | --- | --- | --- | --- | --- | --- |
| 52 | 3 | **Plan-in-Hand (Stg 3)** |  | 6d? | 2021-06-23 | 2021-06-30 |  | 3d |  |  |  |  |
| 53 | 3.1 | Complete Roadway Design |  | 1d? | 2021-06-28 | 2021-06-28 | 51 | 1d |  | 3RD1 | RD |  |
| 54 | 3.2 | Verify Pavement Design |  | 1d? | 2021-06-28 | 2021-06-28 | 51 | 1d |  | 3PD1 | PD |  |
| 55 | 3.3 | Complete Additional Surveys and Initiate ROW Acquisition Surveys |  | 1d? | 2021-06-28 | 2021-06-28 | 51 | 1d |  | 3LS1 | LS |  |
| 56 | 3.4 | Complete Transportation Management Plan |  | 1d? | 2021-06-28 | 2021-06-28 | 51 | 0d |  | 3TM1 | TM |  |
| 57 | 3.5 | Advance Transportation Operations Plan (if a Significant Project) |  | 1d? | 2021-06-28 | 2021-06-28 | 51 | 1d |  | 3TO1 | TO |  |
| 58 | 3.6 | Initiate Signal System Timing (if not a Significant Project) |  | 1d? | 2021-06-29 | 2021-06-29 | 56 | 0d |  | 3SS1 | SS |  |
| 59 | 3.7 | Complete Right-of-Way Consultation |  | 1d? | 2021-06-28 | 2021-06-28 | 51 | 1d |  | 3EP1 | EP |  |
| 60 | 3.8 | Prepare ROW Cost Estimate |  | 1d? | 2021-06-28 | 2021-06-28 | 51 | 0d |  | 3RW1 | RW |  |
| 61 | 3.9 | Complete ROW Authorization Package |  | 1d? | 2021-06-29 | 2021-06-29 | 60 | 0d |  | 3RW2 | RW |  |
| 62 | 3.10 | Advance Utility Coordination |  | 1d? | 2021-06-28 | 2021-06-28 | 51 | 1d |  | 3UT1 | UT |  |
| 63 | 3.11 | Prepare Utility Relocation and Construction Estimates |  | 1d? | 2021-06-28 | 2021-06-28 | 51 | 1d |  | 3UT2 | UT |  |
| 64 | 3.12 | Prepare GeoEnvironmental Phase II Report |  | 1d? | 2021-06-28 | 2021-06-28 | 51 | 1d |  | 3GT1 | GT |  |
| 65 | 3.13 | Conduct Subsurface Investigations & Provide Structures Recommendations |  | 1d? | 2021-06-23 | 2021-06-23 | 20, 26 | 4d |  | 3GT2 | GT |  |
| 66 | 3.14 | Complete Structures Design |  | 1d? | 2021-06-28 | 2021-06-28 | 51 | 1d |  | 3ST1 | ST |  |
| 67 | 3.15 | Complete Signal and ITS Design |  | 1d? | 2021-06-28 | 2021-06-28 | 51 | 1d |  | 3SG1 | SG |  |
| 68 | 3.16 | Complete Signing and Delineation Design |  | 1d? | 2021-06-28 | 2021-06-28 | 51 | 1d |  | 3SD1 | SD |  |
| 69 | 3.17 | Complete Hydraulic Design |  | 1d? | 2021-06-28 | 2021-06-28 | 51 | 1d |  | 3HY1 | HY |  |
| 70 | 3.18 | Complete Railroad Design & Agreements |  | 1d? | 2021-06-28 | 2021-06-28 | 51 | 1d |  | 3RR1 | RR |  |
| 71 | 3.19 | Complete Erosion and Sediment Control Plans |  | 1d? | 2021-06-28 | 2021-06-28 | 51 | 1d |  | 3RE1 | RE |  |
| 72 | 3.20 | Complete Permit, Commitments, and Design Noise Report or Addendum |  | 1d? | 2021-06-28 | 2021-06-28 | 51 | 1d | 0d | 3EN1 | EN |  |
| 73 | 3.21 | Determine Final Noise Abatement |  | 1d? | 2021-06-29 | 2021-06-29 | 72 | 6d |  | 3EN2 | EN |  |
| 74 | 3.22 | Incorporate CR-RAVE Outcomes and Complete CLEAR Activities |  | 1d? | 2021-06-28 | 2021-06-28 | 51 | 1d |  | 3VM1 | VM |  |
| 75 | 3.23 | Prepare Plan-in-Hand Estimates |  | 1d? | 2021-06-30 | 2021-06-30 | 55, 57, 58, 61, 62, 54, 66, 65, 67, 53, 68, 69, 70, 71, 72, 64, 59, 60, 63, 74 | 0d |  | 3CS1 | CS |  |
| 76 | 3.24 | Design Complete & All Permit Applications Submitted | milestone | 0d | 2021-06-30 | 2021-06-30 | 75 | 0d |  | MLSN | MLSN | M1007 |

| ID | WBS | Task | Type | Duration | Start | Finish | Predecessors | Total slack | Task Code | Discipline Code | SAP MLSN |
| --- | --- | --- | --- | --- | --- | --- | --- | --- | --- | --- | --- |
| 77 | 4 | **Plans, Specifications, and Estimates (Stage 4)** |  | 5d? | 2021-07-01 | 2021-07-07 |  | 0d |  |  |  |
| 78 | 4.1 | **Complete ROW Acquisitions and Relocations** |  | 1d? | 2021-07-01 | 2021-07-01 |  | 0d | 4RW1 | RW |  |
| 79 | 4.1.1 | Request ROW Certification |  | 1d? | 2021-07-01 | 2021-07-01 | 76 | 0d | 4RW1 | RW |  |
| 80 | 4.2 | Prepare GeoEnvironmental Phase III Reports |  | 1d? | 2021-07-01 | 2021-07-01 | 76 | 0d | 4GT1 | GT |  |
| 81 | 4.3 | Finalize Structures Design PS&E |  | 1d? | 2021-07-01 | 2021-07-01 | 76 | 0d | 4ST1 | ST |  |
| 82 | 4.4 | Complete ROW Acquisition Surveys |  | 1d? | 2021-07-01 | 2021-07-01 | 76 | 0d | 4LS1 | LS |  |
| 83 | 4.5 | Complete Any Open Hydraulic Tasks |  | 1d? | 2021-07-01 | 2021-07-01 | 76 | 0d | 4HY1 | HY |  |
| 84 | 4.6 | Finalize Erosion and Sediment Control Contract Package |  | 1d? | 2021-07-01 | 2021-07-01 | 76 | 0d | 4RE1 | RE |  |
| 85 | 4.7 | Complete Construction Consultation |  | 1d? | 2021-07-01 | 2021-07-01 | 76 | 0d | 4EP1 | EP |  |
| 86 | 4.8 | Complete Utility Coordination |  | 1d? | 2021-07-01 | 2021-07-01 | 76 | 0d | 4UT1 | UT |  |
| 87 | 4.9 | Complete Utility Relocation by Owner |  | 1d? | 2021-07-01 | 2021-07-01 | 76 | 0d | 4UT2 | UT |  |
| 88 | 4.10 | Prepare Final Utility Construction Estimates |  | 1d? | 2021-07-01 | 2021-07-01 | 76 | 0d | 4UT3 | UT |  |
| 89 | 4.11 | Complete Transportation Operations Plan-Related Tasks (if a Significant Project) |  | 1d? | 2021-07-01 | 2021-07-01 | 76 | 0d | 4TO1 | TO |  |
| 90 | 4.12 | Complete CR-RAVE and CLEAR Activities |  | 1d? | 2021-07-01 | 2021-07-01 | 76 | 0d | 4WM1 | VM |  |
| 91 | 4.13 | Secure Environmental Permits |  | 1d? | 2021-07-01 | 2021-07-01 | 76 | 0d | 4EN1 | EN |  |
| 92 | 4.14 | Complete Railroad Coordination |  | 1d? | 2021-07-01 | 2021-07-01 | 76 | 0d | 4RR1 | RR |  |
| 93 | 4.15 | Prepare Construction Communication Activities |  | 1d? | 2021-07-01 | 2021-07-01 | 76 | 0d | 4CG1 | CG |  |
| 94 | 4.16 | Request Construction Funds |  | 1d? | 2021-07-01 | 2021-07-01 | 76 | 0d |  | PM |  |
| 95 | 4.17 | Finalize the Final PS&E Package |  | 1d? | 2021-07-02 | 2021-07-02 | 80, 81, 82, 83, 87, 89, 91, 92, 93, 86, 84, 85, 88, 90, 79, 94 | 0d | 4RD1 | RD |  |
| 96 | 4.18 | Complete PS&E Package and Advertise the Project |  | 1d? | 2021-07-05 | 2021-07-05 | 95 | 0d | 4CS1 | CS |  |
| 97 | 4.19 | Let Project | milestone | 0d | 2021-07-05 | 2021-07-05 | 96 | 0d | MLSN | MLSN | M1008 |
| 98 | 4.20 | Let, Award and Execute |  | 1d? | 2021-07-06 | 2021-07-06 | 97 | 0d | 4CS2 | CS |  |
| 99 | 4.21 | Post-Letting Activities |  | 1d? | 2021-07-07 | 2021-07-07 | 98 | 0d |  |  |  |
