# NCDOT PDN Schedule

Schedule from MS Project, 2025-07-01 to 2032-11-16.

## Calendars

- NCDOT Holiday Calendar: Mon-Fri 08:00-12:00, 13:00-17:00; Sat-Sun off. Exceptions (off unless hours are given): 2025-07-04 (Independence Day), 2025-09-01 (Labor Day), 2025-11-11 (Veterans Day), 2025-11-24 to 2025-11-28 (Thanksgiving [Week]), 2025-12-22 to 2025-12-26 (Christmas [Week]), 2026-01-01 (New Years), 2026-01-19 (MLK), 2026-04-03 (Good Friday), 2026-05-25 (Memorial Day), 2026-07-03 (Independence Day), 2026-09-07 (Labor Day), 2026-11-11 (Veterans Day), 2026-11-23 to 2026-11-27 (Thanksgiving [Week]), 2026-12-21 to 2026-12-25 (Christmas [Week]), 2027-01-01 (New Years), 2027-01-18 (MLK), 2027-03-26 (Good Friday), 2027-05-31 (Memorial Day), 2027-07-05 (Independence Day), 2027-09-06 (Labor Day), 2027-11-11 (Veterans Day), 2027-11-22 to 2027-11-26 (Thanksgiving [Week]), 2027-12-24 to 2027-12-31 (Christmas [Week]), 2028-01-03 (New Year), 2028-01-17 (MLK), 2028-04-14 (Good Friday), 2028-05-29 (Memorial Day), 2028-07-04 (Independence Day), 2028-09-04 (Labor Day), 2028-11-10 (Veterans Day), 2028-11-20 to 2028-11-24 (Thanksgiving [Week]), 2028-12-25 to 2028-12-29 (Christmas [Week]), 2029-01-01 (New Years), 2029-01-15 (MLK), 2029-03-30 (Good Friday), 2029-05-28 (Memorial Day), 2029-07-04 (Independence Day), 2029-09-03 (Labor Day), 2029-11-09 (Veterans Day), 2029-11-19 to 2029-11-23 (Thanksgiving [Week]), 2029-12-24 to 2029-12-28 (Christmas [Week]), 2030-01-01 (New Years), 2030-01-21 (MLK), 2030-04-19 (Good Friday), 2030-05-27 (Memorial Day), 2030-07-04 (Independence Day), 2030-09-02 (Labor Day), 2030-11-11 (Veterans Day), 2030-11-25 to 2030-11-29 (Thanksgiving [Week]), 2030-12-23 to 2030-12-27 (Christmas [Week]), 2031-01-01 (Ney Years), 2031-01-20 (MLK), 2031-04-11 (Good Friday), 2031-05-26 (Memorial Day), 2031-07-04 (Independence Day), 2031-09-01 (Labor Day), 2031-11-11 (Veterans Day), 2031-11-24 to 2031-11-28 (Thanksgiving [Week]), 2031-12-22 to 2031-12-26 (Christmas [Week]), 2032-01-01 (New Years), 2032-01-19 (MLK), 2032-03-26 (Good Friday), 2032-05-31 (Memorial Day), 2032-07-05 (Independence Day), 2032-09-06 (Labor Day), 2032-11-11 (Veterans Day).
- Central Let Dates: Mon off; Tue 08:00-12:00, 13:00-17:00; Wed-Sun off. Exceptions (off unless hours are given): 2025-05-01 to 2040-12-04 (Non Working Days (1st Tues), recurring), 2025-05-01 to 2040-12-11 (Non Working Days (2nd Tues), recurring), 2025-05-01 to 2040-12-25 (Non Working Days (4th Tues), recurring), 2025-05-01 to 2040-12-31 (Non Working Days (Last Tues), recurring), 2025-05-20 to 2040-12-18 08:00-12:00, 13:00-17:00 (Central Let (3rd Tues), recurring).
- Div 1, 6, 10 and 13 Let Dates: Mon-Tue off; Wed 08:00-12:00, 13:00-17:00; Thu-Sun off. Exceptions (off unless hours are given): 2025-05-01 to 2040-12-31 (Non Working Days (Last Wed), recurring), 2025-05-01 to 2040-12-31 08:00-12:00, 13:00-17:00 (Let Days (1st Wed), recurring), 2025-05-01 to 2040-12-31 (Non Working Days (2nd Wed), recurring), 2025-05-01 to 2040-12-31 08:00-12:00, 13:00-17:00 (Let Days (3rd Wed), recurring), 2025-05-01 to 2040-12-31 (Non Working Days (4th Wed), recurring).

## Resources

| Resource |
| --- |
| Transportation Planning |
| Division CDE's |
| Feasibility Studies |
| Funds Administration |
| STIP Unit |
| All Parties |
| NCDOT |
| HNTB |
| UTILITY PEF |
| NCDOT/HNTB |

## Schedule

| ID | WBS | Task | Type | Duration | Start | Finish | Predecessors | Total slack | Free slack | Task Code | Discipline Code | Responsible Party | SAP MLSN |
| --- | --- | --- | --- | --- | --- | --- | --- | --- | --- | --- | --- | --- | --- |
| 1 | 1 | **WBS# - PROJECT NAME/DESCRIPTION** |  | 1803d | 2025-07-01 | 2032-11-16 |  | 0d |  |  |  |  |  |
| 2 | 1.1 | **Scoping, Fee Estimate, and Notice to Proceed (Stage 1)** |  | 40d | 2025-07-01 | 2025-08-26 |  | 17d |  | SCOPE | SCOPE |  |  |
| 3 | 1.1.1 | Project Scoping Meeting | milestone | 0d | 2025-07-01 | 2025-07-01 |  | 17d | 0d | SCOPE | SCOPE | All Parties |  |
| 4 | 1.1.2 | Scope Development |  | 10d | 2025-07-01 | 2025-07-15 | 3 | 27d | 0d | SCOPE | SCOPE | PEF |  |
| 5 | 1.1.3 | Review/Approve Scope |  | 10d | 2025-07-16 | 2025-07-29 | 4 | 27d | 0d | SCOPE | SCOPE | NCDOT |  |
| 6 | 1.1.4 | Fee Estimate Development |  | 10d | 2025-07-30 | 2025-08-12 | 5 | 27d | 0d | SCOPE | SCOPE | PEF |  |
| 7 | 1.1.5 | Review/Approve Fee Estimate |  | 10d | 2025-08-13 | 2025-08-26 | 6 | 27d | 0d | SCOPE | SCOPE | NCDOT |  |
| 8 | 1.1.6 | Notice To Proceed (Stage 1) | milestone | 0d | 2025-08-26 | 2025-08-26 | 7 | 27d | 0d | SCOPE | SCOPE | NCDOT | M0965 |
| 9 | 1.2 | **Project Initiation (Stage 1)** |  | 235d | 2025-07-01 | 2026-06-17 |  | 17d |  |  |  |  |  |
| 10 | 1.2.1 | Provide Photogrammetric Control & Initiate Surveys |  | 60d | 2025-07-01 | 2025-09-24 | 3 | 17d | 0d | 1LS1 | LS | NCDOT |  |
| 11 | 1.2.2 | Reviews & Provides Best Available Geospatial Data |  | 20d | 2025-07-01 | 2025-07-29 | 3 | 57d | 40d | 1PH1 | PH | NCDOT |  |
| 12 | 1.2.3 | Compile Aerial Photography & Mapping |  | 60d | 2025-07-01 | 2025-09-24 | 3 | 17d | 0d | 1PH2 | PH | NCDOT |  |
| 13 | 1.2.4 | Identify Railroad Impacts |  | 20d | 2025-07-01 | 2025-07-29 | 3 | 1067d | 255d | 1RR1 | RR | NCDOT |  |
| 14 | 1.2.5 | **Investigate Existing ITS & Signal Communications** |  | 75d | 2025-07-01 | 2025-10-15 |  | 117d |  | 1SG1 | SG |  |  |
| 15 | 1.2.5.1 | Initiate Signal System Fiber Owners and Contacts |  | 10d | 2025-07-01 | 2025-07-15 | 3 | 597d | 0d | 1SG1 | SG | PEF |  |
| 16 | 1.2.5.2 | Conduct Preliminary Signal System Investigation |  | 10d | 2025-07-01 | 2025-07-15 | 3 | 597d | 0d | 1SG1 | SG | PEF |  |
| 17 | 1.2.5.3 | Prepare & Submit Draft ITS Risk Analysis and Report |  | 10d | 2025-07-16 | 2025-07-29 | 15, 16 | 597d | 0d | 1SG1 | SG | PEF |  |
| 18 | 1.2.5.4 | Review of Draft ITS Risk Analysis and Report |  | 10d | 2025-07-30 | 2025-08-12 | 17 | 597d | 0d | 1SG1 | SG | NCDOT |  |
| 19 | 1.2.5.5 | Revise & Submit Final ITS Risk Analysis and Report |  | 5d | 2025-08-13 | 2025-08-19 | 18 | 597d | 0d | 1SG1 | SG | PEF |  |
| 20 | 1.2.5.6 | Review of Final ITS Risk Analysis and Report |  | 5d | 2025-08-20 | 2025-08-26 | 19 | 597d | 235d | 1SG1 | SG | NCDOT |  |
| 21 | 1.2.5.7 | Final ITS Risk Analysis and Report Approved | milestone | 0d | 2025-10-15 | 2025-10-15 | 41 | 42d | 0d | 1EN1 | EN | NCDOT |  |
| 22 | 1.2.6 | **Determine Affected Coordinated Corridors** |  | 10d | 2025-07-01 | 2025-07-15 |  | 1122d |  | 1SS1 | SS |  |  |
| 23 | 1.2.6.1 | Complete List of Affected Signal Systems |  | 10d | 2025-07-01 | 2025-07-15 | 3 | 1122d | 1105d | 1SS1 | SS | NCDOT |  |
| 24 | 1.2.7 | **Scope Traffic System Operations** |  | 20d | 2025-07-01 | 2025-07-29 |  | 1112d |  | 1TO1 | TO |  |  |
| 25 | 1.2.7.1 | Determine Impacted Intelligent Transportation System (ITS) Devices & Coordinating Corridors |  | 20d | 2025-07-01 | 2025-07-29 | 3 | 1112d | 1095d | 1TO1 | TO | NCDOT |  |

Notes:
- 13: Tied to Stage 2 Rail Activities
- 20: Tied to Stage 2 ITS Activities
- 23: Tied to Stage 2 Field Inspection Activities
- 25: Tied to Stage 2 Field Inspection Activities

| ID | WBS | Task | Type | Duration | Start | Finish | Predecessors | Total slack | Free slack | Task Code | Discipline Code | Responsible Party |
| --- | --- | --- | --- | --- | --- | --- | --- | --- | --- | --- | --- | --- |
| 26 | 1.2.8 | **Assess Safety Planning** |  | 20d | 2025-07-01 | 2025-07-29 |  | 1092d |  | 1TS1 | TS |  |
| 27 | 1.2.8.1 | Conduct Traffic Safety Review |  | 20d | 2025-07-01 | 2025-07-29 | 3 | 1092d | 255d | 1TS1 | TS | NCDOT |
| 28 | 1.2.9 | **Geotechnical, Replacement & GeoEnvironmental Planning** |  | 10d | 2025-07-01 | 2025-07-15 |  | 67d |  | 1GT1 | GT |  |
| 29 | 1.2.9.1 | Develop Geotechnical Planning Report |  | 10d | 2025-07-01 | 2025-07-15 | 3 | 67d | 50d | 1GT1 | GT | NCDOT |
| 30 | 1.2.9.2 | Develop GeoEnvironmental Scoping Comments Report |  | 10d | 2025-07-01 | 2025-07-15 | 3 | 67d | 50d | 1GT1 | GT | NCDOT |
| 31 | 1.2.10 | **Structures Screening** |  | 10d | 2025-07-01 | 2025-07-15 |  | 67d |  | 1ST1 | ST |  |
| 32 | 1.2.10.1 | Structures Cost Estimate for Express Design |  | 10d | 2025-07-01 | 2025-07-15 | 3 | 67d | 50d | 1ST1 | ST | NCDOT |
| 33 | 1.2.11 | **Review Project Scoping** |  | 15d | 2025-08-27 | 2025-09-17 |  | 612d |  | 1CG1 | CG |  |
| 34 | 1.2.11.1 | Submit ETRACS Request to Initiate Communications Support |  | 5d | 2025-08-27 | 2025-09-03 | 8 | 612d | 0d | 1CG1 | CG | PEF |
| 35 | 1.2.11.2 | Review of Communications Support Needs |  | 10d | 2025-09-04 | 2025-09-17 | 34 | 612d | 585d | 1CG1 | CG | NCDOT |
| 36 | 1.2.12 | **Establish Environmental Needs** |  | 40d | 2025-08-27 | 2025-10-22 |  | 42d |  | 1EN1 | EN |  |
| 37 | 1.2.12.1 | **Data Collection and Mapping** |  | 35d | 2025-08-27 | 2025-10-15 |  | 42d |  | 1EN1 | EN |  |
| 38 | 1.2.12.1.1 | Collect & Review Existing Data |  | 5d | 2025-08-27 | 2025-09-03 | 8 | 57d | 15d | 1EN1 | EN | PEF |
| 39 | 1.2.12.1.2 | Conduct Site Visit | milestone | 0d | 2025-09-24 | 2025-09-24 | 38, 49 | 42d | 0d | 1EN1 | EN | PEF |
| 40 | 1.2.12.1.3 | Update Environmental Features Map & Study Area |  | 10d | 2025-09-25 | 2025-10-08 | 39, 11 | 42d | 0d | 1EN1 | EN | PEF |
| 41 | 1.2.12.1.4 | Review of Updated Environmental Features Map & Study Area |  | 5d | 2025-10-09 | 2025-10-15 | 40 | 42d | 0d | 1EN1 | EN | NCDOT |
| 42 | 1.2.12.1.5 | Environmental Features Map & Study Area Approved | milestone | 0d | 2025-10-15 | 2025-10-15 | 41 | 42d | 0d | 1EN1 | EN | NCDOT |
| 43 | 1.2.12.2 | **Requests for Human & Environment Studies** |  | 5d | 2025-10-16 | 2025-10-22 |  | 42d |  | 1EN1 | EN |  |
| 44 | 1.2.12.2.1 | Prepare & Submit ETRACS Request for Historic Architecture |  | 5d | 2025-10-16 | 2025-10-22 | 42, 21 | 42d | 0d | 1EN1 | EN | PEF |
| 45 | 1.2.12.2.2 | Prepare & Submit ETRACS Request for Archaeology |  | 5d | 2025-10-16 | 2025-10-22 | 42, 21 | 42d | 0d | 1EN1 | EN | PEF |
| 46 | 1.2.12.3 | **Land Owner Notification Letters** |  | 20d | 2025-08-27 | 2025-09-24 |  | 42d |  | 1EN1 | EN |  |
| 47 | 1.2.12.3.1 | Prepare & Submit Land Owner Notification Letters |  | 10d | 2025-08-27 | 2025-09-10 | 8 | 42d | 0d | 1EN1 | EN | PEF |
| 48 | 1.2.12.3.2 | Review and Approve Land Owner Notification Letters |  | 10d | 2025-09-11 | 2025-09-24 | 47 | 42d | 0d | 1EN1 | EN | NCDOT |
| 49 | 1.2.12.3.3 | Send Out Land Owner Notification Letters | milestone | 0d | 2025-09-24 | 2025-09-24 | 48 | 42d | 0d | 1EN1 | EN | PEF |

Notes:
- 27: Tied to Signal Recommendations in Stage 2
- 35: Tied to Public Meeting Maps in Stage 2
- 39: Need land owner notifications for site visit.
- 44: Tied to Stage 2 Screenings
- 45: Tied to Stage 2 Screenings

| ID | WBS | Task | Type | Duration | Start | Finish | Predecessors | Total slack | Free slack | Task Code | Discipline Code | Responsible Party |
| --- | --- | --- | --- | --- | --- | --- | --- | --- | --- | --- | --- | --- |
| 50 | 1.2.13 | **Initiate NEPA/SEPA Review** |  | 125d | 2025-08-27 | 2026-03-09 |  | 42d |  | 1EP1 | EP |  |
| 51 | 1.2.13.1 | **Project Initiation and Merger Process** |  | 125d | 2025-08-27 | 2026-03-09 |  | 42d |  | 1EP1 | EP |  |
| 52 | 1.2.13.1.1 | Prepare Project Initiation Form |  | 10d | 2025-08-27 | 2025-09-10 | 8 | 72d | 0d | 1EP1 | EP | PEF |
| 53 | 1.2.13.1.2 | Prepare Start of Study E-mail List |  | 10d | 2025-08-27 | 2025-09-10 | 8 | 72d | 0d | 1EP1 | EP | PEF |
| 54 | 1.2.13.1.3 | Prepare Merger Pre-Screening Form |  | 10d | 2025-08-27 | 2025-09-10 | 8 | 72d | 0d | 1EP1 | EP | PEF |
| 55 | 1.2.13.1.4 | Review of Project Initiation Items |  | 10d | 2025-09-11 | 2025-09-24 | 53, 52, 54 | 72d | 0d | 1EP1 | EP | NCDOT |
| 56 | 1.2.13.1.5 | Approve Start of Study/Project Initiation Items | milestone | 0d | 2025-09-24 | 2025-09-24 | 55 | 72d | 0d | 1EP1 | EP | NCDOT |
| 57 | 1.2.13.1.6 | Send out Start of Study E-mail Package | milestone | 0d | 2025-09-24 | 2025-09-24 | 56 | 72d | 0d | 1EP1 | EP | PEF |
| 58 | 1.2.13.1.7 | **Merger CP1 Meeting (Purpose and Need and Study Area Defined)** |  | 85d | 2025-10-22 | 2026-03-09 |  | 42d |  |  |  |  |
| 59 | 1.2.13.1.7.1 | Request Merger CP1 Meeting | milestone | 0d | 2025-10-22 | 2025-10-22 | 56, 84 | 82d | 40d | 1EP1 | EP | PEF |
| 60 | 1.2.13.1.7.2 | Prepare for Merger CP1 Meeting |  | 25d | 2026-01-05 | 2026-02-09 | 59, 280, 281 | 42d | 0d | 1EP1 | EP | PEF |
| 61 | 1.2.13.1.7.3 | Merger CP1 Pre-Meeting |  | 15d | 2026-02-10 | 2026-03-02 | 60 | 42d | 0d | 1EP1 | EP | PEF |
| 62 | 1.2.13.1.7.4 | Hold Merger CP1 Meeting (Purpose and Need and Study Area Defined) | milestone | 0d | 2026-03-02 | 2026-03-02 | 61 | 42d | 0d | 1EP1 | EP | PEF |
| 63 | 1.2.13.1.7.5 | Obtain CP1 Signatures |  | 5d | 2026-03-03 | 2026-03-09 | 62 | 42d | 0d | 2EN1 | EN | AGENCY |
| 64 | 1.2.13.1.7.6 | CP1 (Purpose and Need and Study Area Defined) Concurrence | milestone | 0d | 2026-03-09 | 2026-03-09 | 63 | 42d | 0d | 1EP1 | EP | PEF |
| 65 | 1.2.14 | **Complete Express Design** |  | 105d | 2025-09-25 | 2026-03-09 |  | 17d |  | 1FS1 | FS |  |
| 66 | 1.2.14.1 | **Roadway Typical Sections, Design Criteria, and Corridor Details** |  | 30d | 2025-09-25 | 2025-11-05 |  | 17d |  | 1FS1 | FS |  |
| 67 | 1.2.14.1.1 | Prepare & Submit Design Criteria Package |  | 10d | 2025-09-25 | 2025-10-08 | 30, 32, 10, 12, 11, 8, 29 | 17d | 0d | 1FS1 | FS | PEF |
| 68 | 1.2.14.1.2 | Review of Design Criteria Package |  | 10d | 2025-10-09 | 2025-10-22 | 67 | 17d | 0d | 1FS1 | FS | NCDOT |
| 69 | 1.2.14.1.3 | Prepare & Resubmit Design Criteria Package |  | 5d | 2025-10-23 | 2025-10-29 | 68 | 17d | 0d | 1FS1 | FS | PEF |
| 70 | 1.2.14.1.4 | Review of Revised Design Criteria Package |  | 5d | 2025-10-30 | 2025-11-05 | 69 | 17d | 0d | 1FS1 | FS | NCDOT |
| 71 | 1.2.14.1.5 | Design Criteria Package Approved | milestone | 0d | 2025-11-05 | 2025-11-05 | 70 | 17d | 0d | 1FS1 | FS | NCDOT |
| 72 | 1.2.14.2 | **Express Designs** |  | 75d | 2025-11-06 | 2026-03-09 |  | 17d |  | 1FS1 | FS |  |
| 73 | 1.2.14.2.1 | Prepare & Submit Draft Express Designs for Merger Alternatives |  | 40d | 2025-11-06 | 2026-01-16 | 71 | 17d | 0d | 1FS1 | FS | PEF |
| 74 | 1.2.14.2.2 | Review of Draft Express Designs for Merger Alternatives |  | 10d | 2026-01-20 | 2026-02-02 | 73 | 17d | 0d | 1FS1 | FS | NCDOT |
| 75 | 1.2.14.2.3 | Prepare & Submit Final Express Designs for Merger Alternatives |  | 20d | 2026-02-03 | 2026-03-02 | 74, 92 | 17d | 0d | 1FS1 | FS | PEF |
| 76 | 1.2.14.2.4 | Review of Final Express Designs for Merger Alternatives |  | 5d | 2026-03-03 | 2026-03-09 | 75 | 17d | 0d | 1FS1 | FS | NCDOT |
| 77 | 1.2.14.2.5 | Express Designs Approved | milestone | 0d | 2026-03-09 | 2026-03-09 | 76 | 17d | 0d | 1FS1 | FS | NCDOT |

Notes:
- 56: Tied to Start of CE
- 57: Tied to sending out complete streets request
- 59: Request needs to be 6-8 weeks prior to CP1 Meeting
- 60: Can take 6-8 weeks to schedule and hold CP1 Mtg, Need Historic Results
- 61: Pre-meeting is required for CP1, 3 weeks minimum before the CP1 Mtg
- 64: Tie to CP2
- 73: Develop Multiple Alternatives for CP2
- 75: Tied to the approval of the traffic analysis
- 77: Tie to CP2

| ID | WBS | Task | Type | Duration | Start | Finish | Predecessors | Total slack | Free slack | Task Code | Discipline Code | Responsible Party |
| --- | --- | --- | --- | --- | --- | --- | --- | --- | --- | --- | --- | --- |
| 78 | 1.2.15 | **Complete Express Design Traffic Volume** |  | 40d | 2025-08-27 | 2025-10-22 |  | 27d |  | 1TP1 | TP |  |
| 79 | 1.2.15.1 | Prepare & Submit Interim Review Information |  | 10d | 2025-08-27 | 2025-09-10 | 8 | 27d | 0d | 1TP1 | TP | PEF |
| 80 | 1.2.15.2 | Prepare & Submit Draft Traffic Forecast |  | 10d | 2025-09-11 | 2025-09-24 | 79 | 27d | 0d | 1TP1 | TP | PEF |
| 81 | 1.2.15.3 | Review of Draft Traffic Forecast |  | 10d | 2025-09-25 | 2025-10-08 | 80 | 27d | 0d | 1TP1 | TP | NCDOT |
| 82 | 1.2.15.4 | Revise & Resubmit Traffic Forecast |  | 5d | 2025-10-09 | 2025-10-15 | 81 | 27d | 0d | 1TP1 | TP | PEF |
| 83 | 1.2.15.5 | Review of Revised Traffic Forecast |  | 5d | 2025-10-16 | 2025-10-22 | 82 | 27d | 0d | 1TP1 | TP | NCDOT |
| 84 | 1.2.15.6 | Traffic Forecast Approved | milestone | 0d | 2025-10-22 | 2025-10-22 | 83 | 27d | 0d | 1TP1 | TP | NCDOT |
| 85 | 1.2.16 | **Complete Express Design Traffic Analysis** |  | 50d | 2025-10-23 | 2026-01-16 |  | 27d |  | 1TM1 | TM |  |
| 86 | 1.2.16.1 | Prepare & Submit Interim Review Information |  | 10d | 2025-10-23 | 2025-11-05 | 84 | 27d | 0d | 1TM1 | TM | PEF |
| 87 | 1.2.16.2 | Review of Interim Information |  | 10d | 2025-11-06 | 2025-11-20 | 86 | 27d | 0d | 1TM1 | TM | NCDOT |
| 88 | 1.2.16.3 | Prepare & Submit Draft Traffic Operations Analysis |  | 10d | 2025-11-21 | 2025-12-11 | 87 | 27d | 0d | 1TM1 | TM | PEF |
| 89 | 1.2.16.4 | Review of Draft Traffic Operations Analysis |  | 10d | 2025-12-12 | 2026-01-02 | 88 | 27d | 0d | 1TM1 | TM | NCDOT |
| 90 | 1.2.16.5 | Revise & Resubmit Traffic Operations Analysis |  | 5d | 2026-01-05 | 2026-01-09 | 89 | 27d | 0d | 1TM1 | TM | PEF |
| 91 | 1.2.16.6 | Review of Revised Traffic Operations Analysis |  | 5d | 2026-01-12 | 2026-01-16 | 90 | 27d | 0d | 1TM1 | TM | NCDOT |
| 92 | 1.2.16.7 | Express Design Traffic Analysis Approved | milestone | 0d | 2026-01-16 | 2026-01-16 | 91 | 27d | 10d | 1TM1 | TM | NCDOT |
| 93 | 1.2.17 | **Initiate Complete Streets Review** |  | 50d | 2025-09-25 | 2025-12-11 |  | 72d |  | 1IM1 | IM |  |
| 94 | 1.2.17.1 | Prepare & Submit Complete Streets Project Sheet |  | 10d | 2025-09-25 | 2025-10-08 | 57 | 72d | 0d | 1IM1 | IM | PEF |
| 95 | 1.2.17.2 | Review of Complete Streets Project Sheet |  | 40d | 2025-10-09 | 2025-12-11 | 94 | 72d | 0d | 1IM1 | IM | NCDOT |
| 96 | 1.2.17.3 | Complete Streets Recommendations | milestone | 0d | 2025-12-11 | 2025-12-11 | 95 | 72d | 30d | 1IM1 | IM | NCDOT |
| 97 | 1.2.18 | **Initiate Public Engagement Tasks** |  | 30d | 2026-02-24 | 2026-04-07 |  | 42d |  | 1PI1 | PI |  |
| 98 | 1.2.18.1 | Prepare & Submit Draft Public Involvement Plan (PIP) |  | 10d | 2026-02-24 | 2026-03-09 | 271 | 42d | 0d | 1PI1 | PI | PEF |
| 99 | 1.2.18.2 | Review of Draft PIP |  | 10d | 2026-03-10 | 2026-03-23 | 98 | 42d | 0d | 1PI1 | PI | NCDOT |
| 100 | 1.2.18.3 | Revise & Submit Final PIP |  | 5d | 2026-03-24 | 2026-03-30 | 99 | 42d | 0d | 1PI1 | PI | PEF |
| 101 | 1.2.18.4 | Review of Final PIP |  | 5d | 2026-03-31 | 2026-04-07 | 100 | 42d | 0d | 1PI1 | PI | NCDOT |
| 102 | 1.2.18.5 | Final PIP Approved | milestone | 0d | 2026-04-07 | 2026-04-07 | 101 | 42d | 20d | 1PI1 | PI | NCDOT |

Notes:
- 92: Tie to final express design
- 102: Tied to Public Meeting Maps

| ID | WBS | Task | Type | Duration | Start | Finish | Predecessors | Total slack | Free slack | Task Code | Discipline Code | Responsible Party |
| --- | --- | --- | --- | --- | --- | --- | --- | --- | --- | --- | --- | --- |
| 103 | 1.2.19 | **Prepare Conceptual Construction Cost Estimate** |  | 20d | 2026-03-10 | 2026-04-07 |  | 42d |  | 1CS1 | CS |  |
| 104 | 1.2.19.1 | Prepare Draft Quantities & Submit Estimate Request |  | 5d | 2026-03-10 | 2026-03-16 | 77 | 42d | 0d | 1CS1 | CS | PEF |
| 105 | 1.2.19.2 | Prepare Construction Cost Estimate |  | 10d | 2026-03-17 | 2026-03-30 | 104 | 42d | 0d | 1CS1 | CS | NCDOT |
| 106 | 1.2.19.3 | Request Cost Verification Letter | milestone | 0d | 2026-03-30 | 2026-03-30 | 105 | 42d | 0d | 1CS1 | CS | NCDOT |
| 107 | 1.2.19.4 | Prepare Cost Verification Letter |  | 5d | 2026-03-31 | 2026-04-07 | 106 | 42d | 0d | 1CS1 | CS | NCDOT |
| 108 | 1.2.19.5 | Issue Cost Verification Letter | milestone | 0d | 2026-04-07 | 2026-04-07 | 107 | 42d | 20d | 1CS1 | CS | NCDOT |
| 109 | 1.2.20 | Prepare Conceptual ROW Cost Estimate |  | 10d | 2026-03-10 | 2026-03-23 | 77 | 52d | 30d | 1RW1 | RW | NCDOT |
| 110 | 1.2.21 | Develop Initial Utility Relocation and Utility Construction Estimates |  | 10d | 2026-03-10 | 2026-03-23 | 77 | 22d | 0d | 1UT1 | UT | UTILITY PEF |
| 111 | 1.2.22 | **Investigate Existing Utilities** |  | 30d | 2026-03-24 | 2026-05-05 |  | 22d |  | 1UT2 | UT |  |
| 112 | 1.2.22.1 | Prepare & Submit Draft Critical Utilities Strategy |  | 10d | 2026-03-24 | 2026-04-07 | 110 | 22d | 0d | 1UT2 | UT | UTILITY PEF |
| 113 | 1.2.22.2 | Review of Draft Critical Utilities Strategy |  | 10d | 2026-04-08 | 2026-04-21 | 112 | 22d | 0d | 1UT2 | UT | NCDOT |
| 114 | 1.2.22.3 | Revise & Submit Final Critical Utilities Strategy |  | 5d | 2026-04-22 | 2026-04-28 | 113 | 22d | 0d | 1UT2 | UT | UTILITY PEF |
| 115 | 1.2.22.4 | Review of Final Critical Utilities Strategy |  | 5d | 2026-04-29 | 2026-05-05 | 114 | 22d | 0d | 1UT2 | UT | NCDOT |
| 116 | 1.2.22.5 | Final Critical Utilities Strategy Approved | milestone | 0d | 2026-05-05 | 2026-05-05 | 115 | 22d | 0d | 1UT2 | UT | NCDOT |
| 117 | 1.2.23 | Initiate Value Management Activities |  | 10d | 2026-03-10 | 2026-03-23 | 77 | 32d | 0d | 1VM1 | VM | NCDOT |
| 118 | 1.2.24 | **Complete Project Scoping Report** |  | 70d | 2026-03-10 | 2026-06-17 |  | 22d |  | 1FS2 | FS |  |
| 119 | 1.2.24.1 | **Project Scoping Level-Of-Detail Evaluation** |  | 30d | 2026-03-10 | 2026-04-21 |  | 32d |  | 1FS2 | FS |  |
| 120 | 1.2.24.1.1 | Prepare & Submit Project Scoping Report Level-of-Detail Screening Form |  | 10d | 2026-03-10 | 2026-03-23 | 77, 117FF | 32d | 0d | 1FS2 | FS | PEF |
| 121 | 1.2.24.1.2 | Review of Project Scoping Report Level-of-Detail Screening Form |  | 10d | 2026-03-24 | 2026-04-07 | 120 | 32d | 0d | 1FS2 | FS | NCDOT |
| 122 | 1.2.24.1.3 | Revise & Resubmit Project Scoping Report Level-of-Detail Screening Form |  | 5d | 2026-04-08 | 2026-04-14 | 121 | 32d | 0d | 1FS2 | FS | PEF |
| 123 | 1.2.24.1.4 | Review of Revised Project Scoping Report Level-of-Detail Screening Form |  | 5d | 2026-04-15 | 2026-04-21 | 122 | 32d | 0d | 1FS2 | FS | NCDOT |
| 124 | 1.2.24.1.5 | Project Scoping Report Tier Determination | milestone | 0d | 2026-04-21 | 2026-04-21 | 123 | 32d | 10d | 1FS2 | FS | NCDOT |
| 125 | 1.2.24.2 | **Project Scoping Report** |  | 30d | 2026-05-06 | 2026-06-17 |  | 22d |  | 1FS2 | FS |  |
| 126 | 1.2.24.2.1 | Prepare & Submit Project Scoping Report |  | 10d | 2026-05-06 | 2026-05-19 | 124, 102, 108, 109, 110, 116 | 22d | 0d | 1FS2 | FS | PEF |
| 127 | 1.2.24.2.2 | Review of Project Scoping Report |  | 10d | 2026-05-20 | 2026-06-03 | 126 | 22d | 0d | 1FS2 | FS | NCDOT |
| 128 | 1.2.24.2.3 | Revise & Resubmit Project Scoping Report |  | 5d | 2026-06-04 | 2026-06-10 | 127 | 22d | 0d | 1FS2 | FS | PEF |
| 129 | 1.2.24.2.4 | Review of Revised Project Scoping Report |  | 5d | 2026-06-11 | 2026-06-17 | 128 | 22d | 0d | 1FS2 | FS | NCDOT |
| 130 | 1.2.24.2.5 | Project Scoping Report Approved | milestone | 0d | 2026-06-17 | 2026-06-17 | 129 | 22d | 0d | 1FS2 | FS | NCDOT |

Notes:
- 108: Tied to Start of Env. Document
- 109: Tied to Start of Env. Document

| ID | WBS | Task | Type | Duration | Start | Finish | Predecessors | Total slack | Free slack | Task Code | Discipline Code | Responsible Party |
| --- | --- | --- | --- | --- | --- | --- | --- | --- | --- | --- | --- | --- |
| 131 | 1.3 | **Scoping, Fee Estimate, and Notice to Proceed (Stage 2)** |  | 40d | 2026-03-10 | 2026-05-05 |  | 17d |  | SCOPE | SCOPE |  |
| 132 | 1.3.1 | Scope Development |  | 10d | 2026-03-10 | 2026-03-23 | 77 | 17d | 0d | SCOPE | SCOPE | PEF |
| 133 | 1.3.2 | Review/Approve Scope |  | 10d | 2026-03-24 | 2026-04-07 | 132 | 17d | 0d | SCOPE | SCOPE | NCDOT |
| 134 | 1.3.3 | Fee Estimate Development |  | 10d | 2026-04-08 | 2026-04-21 | 133 | 17d | 0d | SCOPE | SCOPE | PEF |
| 135 | 1.3.4 | Review/Approve Fee Estimate |  | 10d | 2026-04-22 | 2026-05-05 | 134 | 17d | 0d | SCOPE | SCOPE | NCDOT |
| 136 | 1.3.5 | Notice To Proceed (Stage 2) | milestone | 0d | 2026-05-05 | 2026-05-05 | 135 | 17d | 0d | SCOPE | SCOPE |  |
| 137 | 1.4 | **Environmental and ROW Plans (Stage 2)** |  | 1305d | 2025-08-27 | 2031-01-13 |  | 82d |  |  |  |  |
| 138 | 1.4.1 | Complete Final Surveys |  | 80d | 2025-09-25 | 2026-02-02 | 10 | 117d | 95d | 2LS1 | LS | NCDOT |
| 139 | 1.4.2 | Complete Traffic Analysis |  | 20d | 2026-05-06 | 2026-06-03 | 92, 136 | 32d | 10d | 2TM1 | TM | PEF |
| 140 | 1.4.3 | **Initiate Utility Coordination and/or Design** |  | 35d | 2026-05-06 | 2026-06-24 |  | 782d |  | 2UT1 | UT |  |
| 141 | 1.4.3.1 | Initiate Utility Owner Contacts |  | 10d | 2026-05-06 | 2026-05-19 | 136 | 782d | 0d | 2UT1 | UT | UTILITY PEF |
| 142 | 1.4.3.2 | Conduct Preliminary Utility Investigations |  | 10d | 2026-05-06 | 2026-05-19 | 136 | 782d | 0d | 2UT1 | UT | UTILITY PEF |
| 143 | 1.4.3.3 | Prepare & Submit Utility Project Outline |  | 10d | 2026-05-20 | 2026-06-03 | 136, 141, 142 | 782d | 0d | 2UT1 | UT | UTILITY PEF |
| 144 | 1.4.3.4 | Review of Utility Project Outline |  | 10d | 2026-06-04 | 2026-06-17 | 143 | 782d | 0d | 2UT1 | UT | NCDOT |
| 145 | 1.4.3.5 | Prepare & Submit Construction Request |  | 5d | 2026-06-18 | 2026-06-24 | 144 | 782d | 35d | 2UT1 | UT | UTILITY PEF |
| 146 | 1.4.4 | **Develop Preliminary Hydraulic Recommendations** |  | 30d | 2026-05-06 | 2026-06-17 |  | 17d |  | 2HY1 | HY |  |
| 147 | 1.4.4.1 | Prepare & Submit Hydraulic Planning Report (HPR) |  | 10d | 2026-05-06 | 2026-05-19 | 136 | 17d | 0d | 2HY1 | HY | PEF |
| 148 | 1.4.4.2 | Review of HPR |  | 10d | 2026-05-20 | 2026-06-03 | 147 | 17d | 0d | 2HY1 | HY | NCDOT |
| 149 | 1.4.4.3 | Revise & Resubmit HPR |  | 5d | 2026-06-04 | 2026-06-10 | 148 | 17d | 0d | 2HY1 | HY | PEF |
| 150 | 1.4.4.4 | Review of Revised HPR |  | 5d | 2026-06-11 | 2026-06-17 | 149 | 17d | 0d | 2HY1 | HY | NCDOT |
| 151 | 1.4.4.5 | Hydraulic Planning Report Approved | milestone | 0d | 2026-06-17 | 2026-06-17 | 150 | 17d | 0d | 2HY1 | HY | NCDOT |
| 152 | 1.4.5 | **Complete Design Recommendation Plan Set** |  | 40d | 2026-06-18 | 2026-08-13 |  | 22d |  | 2RD2 | RD |  |
| 153 | 1.4.5.1 | Prepare & Submit Design Recommendation Plan Set |  | 20d | 2026-06-18 | 2026-07-16 | 138, 136, 96, 130, 139, 278FF, 327 | 22d | 0d | 2RD2 | RD | PEF |
| 154 | 1.4.5.2 | Prepare Initial Design Estimates |  | 20d | 2026-06-18 | 2026-07-16 | 153FF, 136 | 22d | 0d | 2CS1 | CS | PEF |
| 155 | 1.4.5.3 | Review of Design Recommendation Plan Set |  | 10d | 2026-07-17 | 2026-07-30 | 153, 154 | 22d | 0d | 2RD2 | RD | NCDOT |
| 156 | 1.4.5.4 | Revise & Resubmit Design Recommendation Plan Set |  | 5d | 2026-07-31 | 2026-08-06 | 155 | 22d | 0d | 2RD2 | RD | PEF |
| 157 | 1.4.5.5 | Review of Revised Design Recommendation Plan Set |  | 5d | 2026-08-07 | 2026-08-13 | 156 | 22d | 0d | 2RD2 | RD | NCDOT |
| 158 | 1.4.5.6 | Design Recommendation Plan Set Approved | milestone | 0d | 2026-08-13 | 2026-08-13 | 157 | 22d | 0d | 2RD2 | RD | NCDOT |
| 159 | 1.4.6 | Prepare Utility Relocation and Construction Estimates |  | 10d | 2026-08-14 | 2026-08-27 | 145, 158 | 747d | 490d | 2UT2 | UT | UTILITY PEF |
| 160 | 1.4.7 | Prepare ROW Cost Estimate |  | 10d | 2029-09-26 | 2029-10-09 | 158, 403SS-140d | 758d |  | 2RW2 | RW | ROW PEF |

Notes:
- 139: Complete this before DRPS
- 151: Required for CP2A
- 154: Estimate needed 7 months prior to ROW Fund Request
- 158: DRPS Approval Needed for Draft EA/EIS and CP3
- 159: Estimate needed 7 months prior to ROW Fund Request
- 160: Estimate needed 7 months prior to ROW Fund Request

| ID | WBS | Task | Type | Duration | Start | Finish | Predecessors | Total slack | Free slack | Task Code | Discipline Code | Responsible Party |
| --- | --- | --- | --- | --- | --- | --- | --- | --- | --- | --- | --- | --- |
| 161 | 1.4.8 | **Coordinate Railroad Review** |  | 45d | 2026-08-14 | 2026-10-16 |  | 812d |  | 2RR1 | RR |  |
| 162 | 1.4.8.1 | Prepare & Submit Railroad Design Line and Grade |  | 10d | 2026-08-14 | 2026-08-27 | 158, 13 | 812d | 0d | 2RR1 | RR | PEF |
| 163 | 1.4.8.2 | Review of Railroad Line and Grade |  | 10d | 2026-08-28 | 2026-09-11 | 162 | 822d | 10d | 2RR1 | RR | NCDOT |
| 164 | 1.4.8.3 | Rail Review of Railroad Line and Grade |  | 20d | 2026-08-28 | 2026-09-25 | 162 | 812d | 0d | 2RR1 | RR | RAILROAD |
| 165 | 1.4.8.4 | Revise & Resubmit Railroad Line and Grade |  | 10d | 2026-09-28 | 2026-10-09 | 164, 163 | 812d | 0d | 2RR1 | RR | PEF |
| 166 | 1.4.8.5 | Review of Revised Railroad Line and Grade |  | 5d | 2026-10-12 | 2026-10-16 | 165 | 812d | 0d | 2RR1 | RR | NCDOT |
| 167 | 1.4.8.6 | Railroad Line and Grade Approved | milestone | 0d | 2026-10-16 | 2026-10-16 | 166 | 812d | 795d | 2RR1 | RR | NCDOT |
| 168 | 1.4.9 | **Complete Drainage Design** |  | 100d | 2028-07-07 | 2028-12-04 |  | 157d |  | 2HY2 | HY |  |
| 169 | 1.4.9.1 | Prepare & Submit Hydraulic Designs & BSR |  | 40d | 2028-07-07 | 2028-08-31 | 158, 151, 348 | 157d | 0d | 2HY2 | HY | PEF |
| 170 | 1.4.9.2 | Review of Hydraulic Designs & BSR |  | 20d | 2028-09-01 | 2028-09-29 | 169 | 182d | 25d | 2HY2 | HY | NCDOT |
| 171 | 1.4.9.3 | Revise & Resubmit Hydraulic Designs & BSR |  | 10d | 2028-11-06 | 2028-11-27 | 170, 360 | 157d | 0d | 2HY2 | HY | PEF |
| 172 | 1.4.9.4 | Review of Revised Hydraulic Designs & BSR |  | 5d | 2028-11-28 | 2028-12-04 | 171 | 157d | 0d | 2HY2 | HY | NCDOT |
| 173 | 1.4.9.5 | Hydraulic Designs & BSR Approved | milestone | 0d | 2028-12-04 | 2028-12-04 | 172 | 157d | 0d | 2HY2 | HY | NCDOT |
| 174 | 1.4.10 | Establish Signal & ITS Locations |  | 20d | 2026-08-14 | 2026-09-11 | 158, 20 | 362d | 345d | 2SG1 | SG | PEF |
| 175 | 1.4.11 | **Advance Utility Coordination and/or Design** |  | 110d | 2028-09-01 | 2029-02-21 |  | 257d |  | 2UT3 | UT |  |
| 176 | 1.4.11.1 | Provide Plans to Utility Owners |  | 5d | 2028-09-01 | 2028-09-08 | 169, 159 | 257d | 0d | 2UT3 | UT | UTILITY PEF |
| 177 | 1.4.11.2 | Identify Major Utility Conflicts and Relocation Impacts |  | 5d | 2028-09-01 | 2028-09-08 | 169 | 257d | 0d | 2UT3 | UT | UTILITY PEF |
| 178 | 1.4.11.3 | Conduct Utility Coordination Meeting (All Utilities) | milestone | 0d | 2028-09-08 | 2028-09-08 | 177, 176 | 257d | 0d | 2UT3 | UT | UTILITY PEF |
| 179 | 1.4.11.4 | Initiate Cost Responsibility Analysis |  | 5d | 2028-09-11 | 2028-09-15 | 178 | 347d | 330d | 2UT3 | UT | UTILITY PEF |
| 180 | 1.4.11.5 | Utility Owners Develop Routing Plans |  | 80d | 2028-09-11 | 2029-01-17 | 178 | 257d | 0d | 2UT3 | UT | UTILITY OWNERS |
| 181 | 1.4.11.6 | Submit Routing Plan/Preliminary UBO Plans |  | 10d | 2029-01-18 | 2029-01-31 | 180, 174FF | 257d | 0d | 2UT3 | UT | UTILITY PEF |
| 182 | 1.4.11.7 | Create Relocation Schedule |  | 5d | 2029-02-01 | 2029-02-07 | 181 | 257d | 240d | 2UT3 | UT | UTILITY PEF |
| 183 | 1.4.11.8 | Submit Preliminary Utility Construction Routing Plans (30%) |  | 20d | 2028-09-11 | 2028-10-06 | 178 | 332d | 0d | 2UT3 | UT | UTILITY PEF |
| 184 | 1.4.11.9 | Review of 30% UC Plans |  | 10d | 2028-10-09 | 2028-10-20 | 183 | 332d | 0d | 2UT3 | UT | NCDOT |
| 185 | 1.4.11.10 | Request Geotechnical Investigation for Trenchless Construction |  | 5d | 2028-10-23 | 2028-10-27 | 184 | 367d | 340d | 2UT3 | UT | UTILITY PEF |
| 186 | 1.4.11.11 | Submit Required Utility Easements and Parcel List |  | 5d | 2028-10-23 | 2028-10-27 | 184 | 367d | 340d | 2UT3 | UT | UTILITY PEF |
| 187 | 1.4.11.12 | Request Subsurface Utility Engineering (SUE) Level A |  | 5d | 2028-10-23 | 2028-10-27 | 184 | 482d | 0d | 2UT3 | UT | UTILITY PEF |
| 188 | 1.4.11.13 | Complete SUE Level A |  | 40d | 2028-10-30 | 2029-01-09 | 187 | 482d | 0d | 2LS2 | LS | NCDOT |
| 189 | 1.4.11.14 | Submit Preliminary Utility Construction Plans (60%) |  | 20d | 2029-01-10 | 2029-02-07 | 184, 188 | 482d | 0d | 2UT3 | UT | UTILITY PEF |
| 190 | 1.4.11.15 | Review of 60% UC Plans |  | 10d | 2029-02-08 | 2029-02-21 | 189 | 482d | 310d | 2UT3 | UT | NCDOT |
| 191 | 1.4.12 | Prepare Utility Relocation and Construction Estimates |  | 10d | 2029-02-01 | 2029-02-14 | 181, 184 | 272d | 255d | 2UT4 | UT | UTILITY PEF |

Notes:
- 171: CP4B needed prior to final Hydro Designs
- 174: Need initial signal location for UBO routing, Tie to Public Involvement
- 182: Tied to FI Plans
- 185: Tied to ROW Plans
- 186: Tied to ROW Plans
- 190: Tie to Final UC's
- 191: Tied to Field Inspection

| ID | WBS | Task | Type | Duration | Start | Finish | Predecessors | Total slack | Free slack | Task Code | Discipline Code | Responsible Party |
| --- | --- | --- | --- | --- | --- | --- | --- | --- | --- | --- | --- | --- |
| 192 | 1.4.13 | **Begin Advanced Right of Way Tasks** |  | 160d | 2028-12-05 | 2029-07-30 |  | 157d |  | 2RW1 | RW |  |
| 193 | 1.4.13.1 | Prepare Advanced ROW Acquisition Cost Estimate |  | 10d | 2028-12-05 | 2028-12-18 | 173 | 157d | 0d | 2RW1 | RW | ROW PEF |
| 194 | 1.4.13.2 | Request Advanced ROW Acquisition Funds |  | 30d | 2028-12-19 | 2029-02-07 | 193 | 157d | 0d | 2RW1 | RW | NCDOT |
| 195 | 1.4.13.3 | Advanced ROW Acquisition Funds Released | milestone | 0d | 2029-02-07 | 2029-02-07 | 194 | 157d | 0d | 2RW1 | RW | NCDOT |
| 196 | 1.4.13.4 | ROW Advanced Acquisition Surveys |  | 20d | 2028-12-19 | 2029-01-24 | 193 | 167d | 10d | 2RW1 | RW | NCDOT |
| 197 | 1.4.13.5 | Advanced ROW Acquisition |  | 120d | 2029-02-08 | 2029-07-30 | 195, 196 | 157d | 140d | 2RW1 | RW | ROW PEF |
| 198 | 1.4.14 | **Develop Preliminary General Drawings** |  | 30d | 2028-12-05 | 2029-01-24 |  | 267d |  | 2ST2 | ST |  |
| 199 | 1.4.14.1 | Prepare & Submit PGDs |  | 20d | 2028-12-05 | 2029-01-09 | 173 | 267d | 0d | 2ST2 | ST | PEF |
| 200 | 1.4.14.2 | Review of PGDs |  | 10d | 2029-01-10 | 2029-01-24 | 199 | 267d | 0d | 2ST2 | ST | NCDOT |
| 201 | 1.4.15 | **Initiate Erosion and Sediment Control Plans** |  | 30d | 2028-12-05 | 2029-01-24 |  | 267d |  | 2RE1 | RE |  |
| 202 | 1.4.15.1 | Prepare & Submit E&SC Field Inspection Plans |  | 10d | 2028-12-05 | 2028-12-18 | 173 | 267d | 0d | 2RE1 | RE | PEF |
| 203 | 1.4.15.2 | Review of E&SC Field Inspection Plans |  | 10d | 2028-12-19 | 2029-01-09 | 202 | 267d | 0d | 2RE1 | RE | NCDOT |
| 204 | 1.4.15.3 | Revise & Resubmit E&SC Field Inspection Plans |  | 5d | 2029-01-10 | 2029-01-17 | 203 | 267d | 0d | 2RE1 | RE | PEF |
| 205 | 1.4.15.4 | Review of Revised E&SC Field Inspection Plans |  | 5d | 2029-01-18 | 2029-01-24 | 204 | 267d | 0d | 2RE1 | RE | NCDOT |
| 206 | 1.4.15.5 | E&SC Field Inspection Plans Approved | milestone | 0d | 2029-01-24 | 2029-01-24 | 205 | 267d | 0d | 2RE1 | RE | NCDOT |
| 207 | 1.4.16 | **Public Engagement** |  | 80d | 2028-02-22 | 2028-06-14 |  | 17d |  | 2PI1 | PI |  |
| 208 | 1.4.16.1 | **Public Meeting Map** |  | 30d | 2028-02-22 | 2028-04-03 |  | 27d |  | 2PI1 | PI |  |
| 209 | 1.4.16.1.1 | Develop Public Meeting Maps |  | 10d | 2028-02-22 | 2028-03-06 | 158, 102, 35, 278, 341, 335, 174 | 27d | 0d | 2PI1 | PI | PEF |
| 210 | 1.4.16.1.2 | Review of Public Meeting Maps |  | 10d | 2028-03-07 | 2028-03-20 | 209 | 27d | 0d | 2PI1 | PI | NCDOT |
| 211 | 1.4.16.1.3 | Revise & Resubmit Public Meeting Maps |  | 5d | 2028-03-21 | 2028-03-27 | 210 | 27d | 0d | 2PI1 | PI | PEF |
| 212 | 1.4.16.1.4 | Review of Revised Public Meeting Maps |  | 5d | 2028-03-28 | 2028-04-03 | 211 | 27d | 0d | 2PI1 | PI | NCDOT |
| 213 | 1.4.16.1.5 | Public Meeting Maps Approved | milestone | 0d | 2028-04-03 | 2028-04-03 | 212 | 27d | 10d | 2PI1 | PI | NCDOT |
| 214 | 1.4.16.2 | **Postcard** |  | 50d | 2028-02-22 | 2028-05-02 |  | 1113d |  | 2PI1 | PI |  |
| 215 | 1.4.16.2.1 | Develop Postcard |  | 5d | 2028-02-22 | 2028-02-28 | 158, 341, 335 | 1138d | 0d | 2PI1 | PI | PEF |
| 216 | 1.4.16.2.2 | Review of Postcard |  | 10d | 2028-02-29 | 2028-03-13 | 215 | 1138d | 0d | 2PI1 | PI | NCDOT |
| 217 | 1.4.16.2.3 | Revise & Resubmit Postcard |  | 5d | 2028-03-14 | 2028-03-20 | 216 | 1138d | 0d | 2PI1 | PI | PEF |
| 218 | 1.4.16.2.4 | Review of Revised Postcard |  | 5d | 2028-03-21 | 2028-03-27 | 217 | 1138d | 0d | 2PI1 | PI | NCDOT |
| 219 | 1.4.16.2.5 | Postcards Approved | milestone | 0d | 2028-03-27 | 2028-03-27 | 218 | 1138d | 25d | 2PI1 | PI | NCDOT |
| 220 | 1.4.16.2.6 | Send Out Postcard | milestone | 0d | 2028-05-02 | 2028-05-02 | 219, 239SF | 1113d |  | 2PI1 | PI | PEF |

Notes:
- 197: Tied to FI plans but may be able to go beyond field inspection
- 209: Tie to Draft EA/EIS, Tie to Signal Locations
- 215: Tie to Draft EA/EIS

| ID | WBS | Task | Type | Duration | Start | Finish | Predecessors | Total slack | Free slack | Task Code | Discipline Code | Responsible Party |
| --- | --- | --- | --- | --- | --- | --- | --- | --- | --- | --- | --- | --- |
| 221 | 1.4.16.3 | **Visualization** |  | 40d | 2028-02-22 | 2028-04-18 |  | 17d |  | 2PI1 | PI |  |
| 222 | 1.4.16.3.1 | Prepare & Submit Draft VISSIM Model for Visualizations |  | 10d | 2028-02-22 | 2028-03-06 | 158, 341, 335, 174 | 17d | 0d | 2PI1 | PI | PEF |
| 223 | 1.4.16.3.2 | NCDOT Review of Draft VISSIM Model for Visualizations |  | 10d | 2028-03-07 | 2028-03-20 | 222 | 17d | 0d | 2PI1 | PI | NCDOT |
| 224 | 1.4.16.3.3 | Prepare & Submit Final VISSIM Model for Visualizations |  | 5d | 2028-03-21 | 2028-03-27 | 223 | 17d | 0d | 2PI1 | PI | PEF |
| 225 | 1.4.16.3.4 | NCDOT Review of Final VISSIM Model for Visualizations |  | 5d | 2028-03-28 | 2028-04-03 | 224 | 17d | 0d | 2PI1 | PI | NCDOT |
| 226 | 1.4.16.3.5 | NCDOT Approves VISSIM Model for Visualizations | milestone | 0d | 2028-04-03 | 2028-04-03 | 225 | 17d | 0d | 2PI1 | PI | NCDOT |
| 227 | 1.4.16.3.6 | Develop Draft Visualization |  | 20d | 2028-02-22 | 2028-03-20 | 158, 341, 335, 174 | 17d | 0d | 2PI1 | PI | PEF |
| 228 | 1.4.16.3.7 | Review of Draft Visualization |  | 10d | 2028-03-21 | 2028-04-03 | 227 | 17d | 0d | 2PI1 | PI | NCDOT |
| 229 | 1.4.16.3.8 | Revise & Submit Final Visualization |  | 5d | 2028-04-04 | 2028-04-10 | 228, 226 | 17d | 0d | 2PI1 | PI | PEF |
| 230 | 1.4.16.3.9 | Review of Final Visualization |  | 5d | 2028-04-11 | 2028-04-18 | 229 | 17d | 0d | 2PI1 | PI | NCDOT |
| 231 | 1.4.16.3.10 | Visualization Approved | milestone | 0d | 2028-04-18 | 2028-04-18 | 230 | 17d | 0d | 2PI1 | PI | NCDOT |
| 232 | 1.4.16.4 | **Website** |  | 50d | 2028-02-22 | 2028-05-02 |  | 17d |  | 2PI1 | PI |  |
| 233 | 1.4.16.4.1 | Develop Website Template |  | 10d | 2028-02-22 | 2028-03-06 | 158, 341, 335 | 27d | 0d | 2PI1 | PI | PEF |
| 234 | 1.4.16.4.2 | Review of Website Template |  | 10d | 2028-03-07 | 2028-03-20 | 233 | 27d | 0d | 2PI1 | PI | NCDOT |
| 235 | 1.4.16.4.3 | Revise & Resubmit Website Template |  | 5d | 2028-03-21 | 2028-03-27 | 234 | 27d | 0d | 2PI1 | PI | PEF |
| 236 | 1.4.16.4.4 | Review of Revised Website Template |  | 5d | 2028-03-28 | 2028-04-03 | 235 | 27d | 0d | 2PI1 | PI | NCDOT |
| 237 | 1.4.16.4.5 | Website Template Approved | milestone | 0d | 2028-04-03 | 2028-04-03 | 236 | 27d | 10d | 2PI1 | PI | NCDOT |
| 238 | 1.4.16.4.6 | Creation of Website |  | 10d | 2028-04-19 | 2028-05-02 | 237, 231, 213 | 17d | 0d | 2PI1 | PI | NCDOT |
| 239 | 1.4.16.4.7 | Website Goes Live | milestone | 0d | 2028-05-02 | 2028-05-02 | 238 | 17d | 0d | 2PI1 | PI | NCDOT |
| 240 | 1.4.16.5 | **Public Involvement Comment and Responses** |  | 30d | 2028-05-02 | 2028-06-14 |  | 17d |  | 2PI1 | PI |  |
| 241 | 1.4.16.5.1 | Hold Public Hearing/Meeting | milestone | 0d | 2028-05-02 | 2028-05-02 | 239 | 17d | 0d | 2PI1 | PI | NCDOT |
| 242 | 1.4.16.5.2 | Gathering Public Comments |  | 20d | 2028-05-03 | 2028-05-31 | 241 | 72d | 0d | 2PI1 | PI | NCDOT |
| 243 | 1.4.16.5.3 | Response to Public Comments |  | 10d | 2028-06-01 | 2028-06-14 | 242 | 72d | 55d | 2PI1 | PI | PEF |
| 244 | 1.4.17 | Prepare GeoEnvironmental Phase I Report |  | 20d | 2026-05-06 | 2026-06-03 | 136 | 907d | 0d | 2GT1 | GT | NCDOT |
| 245 | 1.4.18 | Roadway Geotechnical & Geopavement Investigations |  | 40d | 2026-08-14 | 2026-10-09 | 158 | 817d | 800d | 2GT2 | GT | NCDOT |
| 246 | 1.4.19 | Geotechnical Structure Investigations |  | 40d | 2028-12-05 | 2029-02-07 | 173 | 257d | 0d | 2GT3 | GT | NCDOT |

Notes:
- 222: Tie to Draft EA/EIS, Tie to Signal Locations
- 227: Tie to Draft EA/EIS, Tie to Signal Locations
- 233: Tie to Draft EA/EIS
- 241: Public Hearing/Meeting Required for CP3
- 246: Includes Foundation Recs. Start after Hydro approval.

| ID | WBS | Task | Type | Duration | Start | Finish | Predecessors | Total slack | Free slack | Task Code | Discipline Code | Responsible Party |
| --- | --- | --- | --- | --- | --- | --- | --- | --- | --- | --- | --- | --- |
| 247 | 1.4.20 | **Complete Pavement Design** |  | 60d | 2026-08-14 | 2026-11-06 |  | 797d |  | 2PD1 | PD |  |
| 248 | 1.4.20.1 | Final Pavement Design Memo |  | 60d | 2026-08-14 | 2026-11-06 | 158 | 797d | 780d | 2PD1 | PD | NCDOT |
| 249 | 1.4.21 | **Complete Safety Analysis and Operational Review** |  | 20d | 2026-08-14 | 2026-09-11 |  | 837d |  | 2TS1 | TS |  |
| 250 | 1.4.21.1 | Traffic Signal Recommendations |  | 20d | 2026-08-14 | 2026-09-11 | 158, 27 | 837d | 820d | 2TS1 | TS | NCDOT |
| 251 | 1.4.22 | **Initiate Natural Resources Analysis** |  | 95d | 2025-08-27 | 2026-01-26 |  | 657d |  | 2EN1 | EN |  |
| 252 | 1.4.22.1 | **Complete NRTR and WEX File** |  | 40d | 2025-09-25 | 2025-11-20 |  | 657d |  | 2EN1 | EN |  |
| 253 | 1.4.22.1.1 | Conduct Wetland Delineations and Field Surveys |  | 10d | 2025-09-25 | 2025-10-08 | 49 | 662d | 0d | 2LS1 | LS | ENVIRONMENTAL PEF |
| 254 | 1.4.22.1.2 | Prepare & Submit Draft NRTR and PJD Package |  | 10d | 2025-10-09 | 2025-10-22 | 253 | 662d | 0d | 2EN1 | EN | ENVIRONMENTAL PEF |
| 255 | 1.4.22.1.3 | Review of Draft NRTR and PJD Package |  | 10d | 2025-10-23 | 2025-11-05 | 254 | 662d | 5d | 2EN1 | EN | NCDOT |
| 256 | 1.4.22.1.4 | Revise & Resubmit Final NRTR and PJD Package |  | 5d | 2025-11-14 | 2025-11-20 | 255, 266FF | 657d | 0d | 2EN1 | EN | ENVIRONMENTAL PEF |
| 257 | 1.4.22.2 | **Signed PJD** |  | 35d | 2025-11-21 | 2026-01-26 |  | 657d |  | 2EN1 | EN |  |
| 258 | 1.4.22.2.1 | Review PJD Package |  | 25d | 2025-11-21 | 2026-01-09 | 256 | 657d | 0d | 2EN1 | EN | AGENCY |
| 259 | 1.4.22.2.2 | Conduct Agency Field Review |  | 5d | 2026-01-12 | 2026-01-16 | 258 | 657d | 0d | 2EN1 | EN | AGENCY |
| 260 | 1.4.22.2.3 | Create WET File and Revise PJD Package (If Necessary) |  | 5d | 2026-01-20 | 2026-01-26 | 259 | 657d | 0d | 2EN1 | EN | ENVIRONMENTAL PEF |
| 261 | 1.4.22.2.4 | Sign PJD | milestone | 0d | 2026-01-26 | 2026-01-26 | 260 | 657d | 640d | 2EN1 | EN | AGENCY |
| 262 | 1.4.22.3 | **Threatened & Endangered (T&E) Species Survey** |  | 60d | 2025-08-27 | 2025-11-20 |  | 657d |  | 2EN1 | EN |  |
| 263 | 1.4.22.3.1 | T&E Survey and Submit Biological Assessment |  | 10d | 2025-08-27 | 2025-09-10 | 8 | 657d | 0d | 2EN1 | EN | ENVIRONMENTAL PEF |
| 264 | 1.4.22.3.2 | Initiate Section 7 Consultation |  | 20d | 2025-09-11 | 2025-10-08 | 263 | 657d | 0d | 2EN1 | EN | NCDOT |
| 265 | 1.4.22.3.3 | Review Biological Opinion/Commitments |  | 30d | 2025-10-09 | 2025-11-20 | 264 | 657d | 0d | 2EN1 | EN | AGENCY |
| 266 | 1.4.22.3.4 | Renders Biological Opinion/Commitments | milestone | 0d | 2025-11-20 | 2025-11-20 | 265 | 657d | 0d | 2EN1 | EN | AGENCY |
| 267 | 1.4.23 | **Initiate Human Environment Analysis** |  | 780d | 2025-10-23 | 2029-01-17 |  | 42d |  | 2EN2 | EN |  |
| 268 | 1.4.23.1 | **Complete Community Studies Report** |  | 40d | 2026-02-03 | 2026-03-30 |  | 42d |  | 2EN2 | EN |  |
| 269 | 1.4.23.1.1 | Delineate the Direct Community Impact Area (DCIA) and Demographic Study Area (DSA) Boundary |  | 5d | 2026-02-03 | 2026-02-09 | 96, 74 | 42d | 0d | 2EN2 | EN | PEF |
| 270 | 1.4.23.1.2 | Submit DCIA & DSA Boundary to Community Studies for Review & Approval |  | 5d | 2026-02-10 | 2026-02-16 | 269 | 42d | 0d | 2EN2 | EN | PEF |
| 271 | 1.4.23.1.3 | Compile Demographic information from Community Studies Demographic Tool |  | 5d | 2026-02-17 | 2026-02-23 | 270 | 42d | 0d | 2EN2 | EN | PEF |
| 272 | 1.4.23.1.4 | Community Studies Field Visit | milestone | 0d | 2026-02-23 | 2026-02-23 | 271, 38 | 97d | 0d | 2EN2 | EN | PEF |
| 273 | 1.4.23.1.5 | Prepare & Send Out Local Officials Input Forms |  | 10d | 2026-02-03 | 2026-02-16 | 96, 74 | 102d | 5d | 2EN2 | EN | PEF |
| 274 | 1.4.23.1.6 | Prepare & Submit Draft Community Impact Assessment (CIA) |  | 5d | 2026-02-24 | 2026-03-02 | 272, 273 | 97d | 0d | 2EN2 | EN | PEF |
| 275 | 1.4.23.1.7 | Review of Draft CIA |  | 10d | 2026-03-03 | 2026-03-16 | 274 | 97d | 0d | 2EN2 | EN | NCDOT |
| 276 | 1.4.23.1.8 | Revise & Submit Final CIA |  | 5d | 2026-03-17 | 2026-03-23 | 275 | 97d | 0d | 2EN2 | EN | PEF |
| 277 | 1.4.23.1.9 | Review of Final CIA |  | 5d | 2026-03-24 | 2026-03-30 | 276 | 97d | 0d | 2EN2 | EN | NCDOT |
| 278 | 1.4.23.1.10 | Approve Final CIA | milestone | 0d | 2026-03-30 | 2026-03-30 | 277 | 97d | 75d | 2EN2 | EN | NCDOT |

Notes:
- 261: Tied to Start of CE
- 263: Adjust Survey to the appropriate time of the year as needed
- 266: Tied to Start of CE
- 278: Complete CIA by draft DRPS Submission

| ID | WBS | Task | Type | Duration | Start | Finish | Predecessors | Total slack | Free slack | Task Code | Discipline Code | Responsible Party |
| --- | --- | --- | --- | --- | --- | --- | --- | --- | --- | --- | --- | --- |
| 279 | 1.4.23.2 | **Complete Cultural Resource Screenings** |  | 40d | 2025-10-23 | 2026-01-02 |  | 42d |  | 2EN2 | EN |  |
| 280 | 1.4.23.2.1 | Complete Historic Architecture and Landscapes No Survey Required Form |  | 40d | 2025-10-23 | 2026-01-02 | 44 | 42d | 0d | 2EN2 | EN | NCDOT |
| 281 | 1.4.23.2.2 | Complete No Archaeological Survey Required Form |  | 40d | 2025-10-23 | 2026-01-02 | 45 | 42d | 0d | 2EN2 | EN | NCDOT |
| 282 | 1.4.23.3 | **Identify Section 4(f) Resources** |  | 655d | 2026-05-06 | 2029-01-17 |  | 262d |  | 2EN2 | EN |  |
| 283 | 1.4.23.3.1 | Identify Section 4(f) Resource Ownership |  | 5d | 2026-05-06 | 2026-05-12 | 136 | 887d | 625d | 2EN2 | EN | PEF |
| 284 | 1.4.23.3.2 | Determine Impacts to Resource |  | 5d | 2028-12-05 | 2028-12-11 | 283, 173 | 262d | 0d | 2EN2 | EN | PEF |
| 285 | 1.4.23.3.3 | Sign de minimis Agreement |  | 20d | 2028-12-12 | 2029-01-17 | 284 | 262d | 0d | 2EN2 | EN | AGENCY |
| 286 | 1.4.23.4 | **Traffic Noise Report (TNR)** |  | 185d | 2026-05-06 | 2027-02-10 |  | 147d |  | 2EN2 | EN |  |
| 287 | 1.4.23.4.1 | Prepare & Submit Workplan |  | 20d | 2026-05-06 | 2026-06-03 | 136 | 147d | 0d | 2EN2 | EN | PEF |
| 288 | 1.4.23.4.2 | Review of Workplan |  | 20d | 2026-06-04 | 2026-07-01 | 287 | 147d | 0d | 2EN2 | EN | NCDOT |
| 289 | 1.4.23.4.3 | Revise & Resubmit Workplan |  | 10d | 2026-07-02 | 2026-07-16 | 288 | 147d | 0d | 2EN2 | EN | PEF |
| 290 | 1.4.23.4.4 | Review of Final Workplan |  | 10d | 2026-07-17 | 2026-07-30 | 289 | 147d | 0d | 2EN2 | EN | NCDOT |
| 291 | 1.4.23.4.5 | Field Data Collection & Base Modeling/Validation |  | 20d | 2026-07-31 | 2026-08-27 | 290 | 147d | 0d | 2EN2 | EN | PEF |
| 292 | 1.4.23.4.6 | Review of Validation |  | 10d | 2026-08-28 | 2026-09-11 | 291 | 147d | 0d | 2EN2 | EN | NCDOT |
| 293 | 1.4.23.4.7 | Revise & Resubmit Validation |  | 10d | 2026-09-14 | 2026-09-25 | 292 | 147d | 0d | 2EN2 | EN | PEF |
| 294 | 1.4.23.4.8 | Review of Final Validation |  | 10d | 2026-09-28 | 2026-10-09 | 293 | 147d | 0d | 2EN2 | EN | NCDOT |
| 295 | 1.4.23.4.9 | Future Year No-Build Modeling |  | 10d | 2026-10-12 | 2026-10-23 | 294 | 157d | 10d | 2EN2 | EN | PEF |
| 296 | 1.4.23.4.10 | Future Year Build Modeling |  | 20d | 2026-10-12 | 2026-11-06 | 158, 294 | 147d | 0d | 2EN2 | EN | PEF |
| 297 | 1.4.23.4.11 | Prepare & Submit Draft TNR |  | 15d | 2026-11-09 | 2026-12-07 | 296, 295 | 147d | 0d | 2EN2 | EN | PEF |
| 298 | 1.4.23.4.12 | Review of Draft TNR |  | 20d | 2026-12-08 | 2027-01-12 | 297 | 147d | 0d | 2EN2 | EN | NCDOT |
| 299 | 1.4.23.4.13 | Revise & Submit Final TNR |  | 10d | 2027-01-13 | 2027-01-27 | 298 | 147d | 0d | 2EN2 | EN | PEF |
| 300 | 1.4.23.4.14 | Review of Final TNR |  | 10d | 2027-01-28 | 2027-02-10 | 299 | 147d | 0d | 2EN2 | EN | NCDOT |
| 301 | 1.4.23.4.15 | Final TNR Approved | milestone | 0d | 2027-02-10 | 2027-02-10 | 300 | 147d | 130d | 2EN2 | EN | NCDOT |
| 302 | 1.4.24 | **Develop Noise Report or Addendum** |  | 150d | 2030-05-29 | 2031-01-13 |  | 359d |  | 2EN3 | EN |  |
| 303 | 1.4.24.1 | Future Year No-Build Modeling |  | 10d | 2030-05-29 | 2030-06-11 | 389 | 359d | 0d | 2EN3 | EN | PEF |
| 304 | 1.4.24.2 | Future Year Build Modeling |  | 10d | 2030-05-29 | 2030-06-11 | 389 | 359d | 0d | 2EN3 | EN | PEF |
| 305 | 1.4.24.3 | Prepare & Submit Draft DNR |  | 20d | 2030-06-12 | 2030-07-10 | 303, 304 | 359d | 0d | 2EN3 | EN | PEF |
| 306 | 1.4.24.4 | Review of Draft DNR |  | 20d | 2030-07-11 | 2030-08-07 | 305 | 359d | 0d | 2EN3 | EN | NCDOT |
| 307 | 1.4.24.5 | Revise & Resubmit Draft DNR |  | 10d | 2030-08-08 | 2030-08-21 | 306 | 359d | 0d | 2EN3 | EN | PEF |
| 308 | 1.4.24.6 | Review of Revised Draft DNR |  | 10d | 2030-08-22 | 2030-09-05 | 307 | 359d | 0d | 2EN3 | EN | NCDOT |
| 309 | 1.4.24.7 | Revise & Submit Final DNR |  | 10d | 2030-09-06 | 2030-09-19 | 308 | 359d | 0d | 2EN3 | EN | PEF |
| 310 | 1.4.24.8 | Review of Final DNR |  | 10d | 2030-09-20 | 2030-10-03 | 309 | 359d | 0d | 2EN3 | EN | NCDOT |
| 311 | 1.4.24.9 | Final DNR Approved | milestone | 0d | 2030-10-03 | 2030-10-03 | 310 | 359d | 0d | 2EN3 | EN | NCDOT |

Notes:
- 280: Tied to Request in Stage 1
- 281: Tied to Request in Stage 1
- 284: Based off of Hydro/BSR Approval

| ID | WBS | Task | Type | Duration | Start | Finish | Predecessors | Total slack | Free slack | Task Code | Discipline Code | Responsible Party |
| --- | --- | --- | --- | --- | --- | --- | --- | --- | --- | --- | --- | --- |
| 312 | 1.4.24.10 | **Document Noise Abatement Decision** |  | 60d | 2030-10-04 | 2031-01-13 |  | 359d |  | 2EN3 | EN |  |
| 313 | 1.4.24.10.1 | Prepare & Submit Draft Balloting Figures |  | 10d | 2030-10-04 | 2030-10-17 | 311 | 359d | 0d | 2EN3 | EN | PEF |
| 314 | 1.4.24.10.2 | Review of Draft Balloting Figures |  | 10d | 2030-10-18 | 2030-10-31 | 313 | 359d | 0d | 2EN3 | EN | NCDOT |
| 315 | 1.4.24.10.3 | Revise & Resubmit Final Balloting Figures |  | 10d | 2030-11-01 | 2030-11-15 | 314 | 359d | 0d | 2EN3 | EN | PEF |
| 316 | 1.4.24.10.4 | Review of Final Balloting Figures |  | 10d | 2030-11-18 | 2030-12-06 | 315 | 359d | 0d | 2EN3 | EN | NCDOT |
| 317 | 1.4.24.10.5 | Final Balloting Figures Approved | milestone | 0d | 2030-12-06 | 2030-12-06 | 316 | 359d | 0d | 2EN3 | EN | NCDOT |
| 318 | 1.4.24.10.6 | Public Input from Final Balloting Figures |  | 20d | 2030-12-09 | 2031-01-13 | 317 | 359d | 0d | 2EN3 | EN | NCDOT |
| 319 | 1.4.24.10.7 | Final Noise Wall Determination | milestone | 0d | 2031-01-13 | 2031-01-13 | 318 | 359d | 180d | 2EN3 | EN | NCDOT |
| 320 | 1.4.25 | **Advance NEPA/SEPA Documentation** |  | 950d | 2026-03-09 | 2030-02-01 |  | 17d |  | 2EP1 | EP |  |
| 321 | 1.4.25.1 | **Merger CP2 Meeting (Detailed Study Alternatives Carried Forward)** |  | 45d | 2026-03-09 | 2026-05-12 |  | 42d |  |  |  |  |
| 322 | 1.4.25.1.1 | Request Merger CP2 Meeting | milestone | 0d | 2026-03-09 | 2026-03-09 | 77, 64 | 42d | 0d | 2EP1 | EP | PEF |
| 323 | 1.4.25.1.2 | Prepare for Merger CP2 Meeting |  | 25d | 2026-03-10 | 2026-04-14 | 322 | 42d | 0d | 2EP1 | EP | PEF |
| 324 | 1.4.25.1.3 | Merger CP2 Pre-Meeting [Recommended Not Required] |  | 15d | 2026-04-15 | 2026-05-05 | 323 | 42d | 0d | 2EP1 | EP | PEF |
| 325 | 1.4.25.1.4 | Hold Merger CP2 Meeting (Detailed Study Alternatives Carried Forward) | milestone | 0d | 2026-05-05 | 2026-05-05 | 324 | 42d | 0d | 2EP1 | EP | PEF |
| 326 | 1.4.25.1.5 | Obtain CP2 Signatures |  | 5d | 2026-05-06 | 2026-05-12 | 325 | 42d | 0d | 2EN1 | EN | AGENCY |
| 327 | 1.4.25.1.6 | CP2 (Detailed Study Alternatives Carried Forward) Concurrence | milestone | 0d | 2026-05-12 | 2026-05-12 | 326 | 42d | 25d | 1EP1 | EP | PEF |
| 328 | 1.4.25.2 | **Merger CP2A Meeting (Bridging Decisions and Alignment Review)** |  | 45d | 2026-06-17 | 2026-08-20 |  | 17d |  |  |  |  |
| 329 | 1.4.25.2.1 | Request Merger CP2A Meeting | milestone | 0d | 2026-06-17 | 2026-06-17 | 151, 327 | 17d | 0d | 2EP1 | EP | PEF |
| 330 | 1.4.25.2.2 | Develop Cost Estimates for Potential Crossing Structures |  | 20d | 2026-06-18 | 2026-07-16 | 329 | 22d | 5d | 2EP1 | EP | PEF |
| 331 | 1.4.25.2.3 | Prepare for Merger CP2A Meeting |  | 25d | 2026-06-18 | 2026-07-23 | 329 | 17d | 0d | 2EP1 | EP | PEF |
| 332 | 1.4.25.2.4 | Merger CP2A Pre-Meeting [Recommended Not Required] |  | 15d | 2026-07-24 | 2026-08-13 | 331, 330 | 17d | 0d | 2EP1 | EP | PEF |
| 333 | 1.4.25.2.5 | Hold Merger CP2A Meeting (Bridging Decisions and Alignment Review) | milestone | 0d | 2026-08-13 | 2026-08-13 | 332 | 17d | 0d | 2EP1 | EP | PEF |
| 334 | 1.4.25.2.6 | Obtain CP2A Signatures |  | 5d | 2026-08-14 | 2026-08-20 | 333 | 17d | 0d | 2EN1 | EN | AGENCY |
| 335 | 1.4.25.2.7 | CP2A (Bridging Decisions and Alignment Review) Concurrence | milestone | 0d | 2026-08-20 | 2026-08-20 | 334 | 17d | 0d | 1EP1 | EP | PEF |

Notes:
- 322: Request needs to be 6-8 weeks prior to CP2 Meeting
- 323: Can take 6-8 weeks to schedule and hold CP2 Meeting
- 324: Pre-meeting is not required for CP2, 3 weeks minimum before the CP2 Mtg
- 327: Tie to CP2A and DRPS Development
- 329: HPR is required for CP2A, Needs to be 6-8 weeks prior to CP2A Meeting
- 330: Need Cost Comparison Between Culverts and Bridges
- 331: Can take 6-8 weeks to schedule and hold CP2A Meeting
- 332: Pre-meeting is not req. for CP2A, 3 weeks minimum before the CP2A Mtg
- 335: Tie to Public Hearing and Draft EA/EIS

| ID | WBS | Task | Type | Duration | Start | Finish | Predecessors | Total slack | Free slack | Task Code | Discipline Code | Responsible Party |
| --- | --- | --- | --- | --- | --- | --- | --- | --- | --- | --- | --- | --- |
| 336 | 1.4.25.3 | **Draft Environmental Assessment (EA)/Environmental Impact Statement (EIS)** |  | 360d | 2026-08-21 | 2028-02-21 |  | 17d |  |  |  |  |
| 337 | 1.4.25.3.1 | Prepare & Submit Draft EA/EIS |  | 240d | 2026-08-21 | 2027-08-16 | 158, 301FF, 335 | 17d | 0d | 2EP1 | EP | PEF |
| 338 | 1.4.25.3.2 | Review of Draft EA/EIS |  | 40d | 2027-08-17 | 2027-10-12 | 337 | 17d | 0d | 2EP1 | EP | NCDOT |
| 339 | 1.4.25.3.3 | Prepare & Submit Revised Draft EA/EIS |  | 60d | 2027-10-13 | 2028-01-24 | 338 | 17d | 0d | 2EP1 | EP | PEF |
| 340 | 1.4.25.3.4 | Review of Revised Draft EA/EIS |  | 20d | 2028-01-25 | 2028-02-21 | 339 | 17d | 0d | 2EP1 | EP | NCDOT |
| 341 | 1.4.25.3.5 | Draft EA/EIS Approved | milestone | 0d | 2028-02-21 | 2028-02-21 | 340 | 17d | 0d | 2EP1 | EP | PEF |
| 342 | 1.4.25.4 | **Merger CP3 Meeting (Least Environmentally Damaging Practicable Alternative)** |  | 45d | 2028-05-02 | 2028-07-06 |  | 17d |  |  |  |  |
| 343 | 1.4.25.4.1 | Request Merger CP3 Meeting | milestone | 0d | 2028-05-02 | 2028-05-02 | 158, 241 | 17d | 0d | 2EP1 | EP | PEF |
| 344 | 1.4.25.4.2 | Prepare for Merger CP3 Meeting |  | 25d | 2028-05-03 | 2028-06-07 | 343 | 17d | 0d | 2EP1 | EP | PEF |
| 345 | 1.4.25.4.3 | Merger CP3 Pre-Meeting |  | 15d | 2028-06-08 | 2028-06-28 | 344 | 17d | 0d | 2EP1 | EP | PEF |
| 346 | 1.4.25.4.4 | Hold Merger CP3 Meeting (LEDPA/Preferred Alternative) | milestone | 0d | 2028-06-28 | 2028-06-28 | 345 | 17d | 0d | 2EP1 | EP | PEF |
| 347 | 1.4.25.4.5 | Obtain CP3 Signatures |  | 5d | 2028-06-29 | 2028-07-06 | 346 | 17d | 0d | 2EN1 | EN | AGENCY |
| 348 | 1.4.25.4.6 | CP3 (LEDPA/Preferred Alternative) Concurrence | milestone | 0d | 2028-07-06 | 2028-07-06 | 347 | 17d | 0d | 1EP1 | EP | PEF |
| 349 | 1.4.25.5 | **Merger CP4A Meeting (Avoidance and Minimization Measures)** |  | 40d | 2028-07-06 | 2028-08-31 |  | 17d |  |  |  |  |
| 350 | 1.4.25.5.1 | Request Merger CP4A Meeting | milestone | 0d | 2028-07-06 | 2028-07-06 | 348 | 17d | 0d | 2EP1 | EP | PEF |
| 351 | 1.4.25.5.2 | Prepare for Merger CP4A Meeting |  | 25d | 2028-07-07 | 2028-08-10 | 350 | 17d | 0d | 2EP1 | EP | PEF |
| 352 | 1.4.25.5.3 | Merger CP4A Pre-Meeting [Not Required] |  | 15d | 2028-08-11 | 2028-08-31 | 351 | 17d | 0d | 2EP1 | EP | PEF |
| 353 | 1.4.25.5.4 | Hold Merger CP4A Meeting CP4A Meeting (Avoidance and Minimization Measures) | milestone | 0d | 2028-08-31 | 2028-08-31 | 352 | 17d | 0d | 2EP1 | EP | PEF |
| 354 | 1.4.25.6 | **Merger CP4B Meeting (Hydraulic Design Review)** |  | 45d | 2028-08-31 | 2028-11-03 |  | 157d |  |  |  |  |
| 355 | 1.4.25.6.1 | Request Merger CP4B Meeting | milestone | 0d | 2028-08-31 | 2028-08-31 | 169, 353 | 157d | 0d | 2EP1 | EP | PEF |
| 356 | 1.4.25.6.2 | Prepare for Merger CP4B Meeting |  | 25d | 2028-09-01 | 2028-10-06 | 355 | 157d | 0d | 2EP1 | EP | PEF |
| 357 | 1.4.25.6.3 | Merger CP4B Pre-Meeting [Not Required] |  | 15d | 2028-10-09 | 2028-10-27 | 356 | 157d | 0d | 2EP1 | EP | PEF |
| 358 | 1.4.25.6.4 | Hold Merger CP4B Meeting (Hydraulic Design Review) | milestone | 0d | 2028-10-27 | 2028-10-27 | 357 | 157d | 0d | 2EP1 | EP | PEF |
| 359 | 1.4.25.6.5 | Obtain CP4B Signatures |  | 5d | 2028-10-30 | 2028-11-03 | 358 | 157d | 0d | 2EN1 | EN | AGENCY |
| 360 | 1.4.25.6.6 | CP4B (Hydraulic Design Review) Concurrence | milestone | 0d | 2028-11-03 | 2028-11-03 | 359 | 157d | 0d | 1EP1 | EP | PEF |

Notes:
- 337: Can Take 1-2 Years Depending on The Project, Need DRPS and TNR for Draft
- 338: Minimum of 1.5 - 2 months for review
- 341: Tie to Public Hearing/Meeting
- 343: Request needs to be 6-8 weeks prior to CP3 Meeting, Need PI and DRPS
- 344: Can take 6-8 weeks to schedule and hold CP3 Meeting
- 345: Pre-meeting is required for CP3, 3 weeks minimum before the CP3 Mtg
- 346: Tie to CE, CP4A, and Hydro Design
- 348: Tie to CE, CP4A, and Hydro Design
- 350: Needs to be 6-8 weeks prior to CP4A Meeting
- 351: Can take 6-8 weeks to schedule and hold CP4A Meeting
- 352: Pre-meeting is not req. for CP4A, 3 weeks minimum before the CP4A Mtg
- 353: Tie to the CE and Final EA/EIS
- 355: Needs to be 6-8 weeks prior to CP4B Meeting, Tie to Redline Hydro
- 356: Can take 6-8 weeks to schedule and hold CP4B Meeting
- 357: Pre-meeting is not req. for CP4B, 3 weeks minimum before the CP4B Mtg
- 358: Tie to the CP4C and Final Hydro
- 360: Tie to the CP4C and Final Hydro

| ID | WBS | Task | Type | Duration | Start | Finish | Predecessors | Total slack | Free slack | Task Code | Discipline Code | Responsible Party |
| --- | --- | --- | --- | --- | --- | --- | --- | --- | --- | --- | --- | --- |
| 361 | 1.4.25.7 | **Categorical Exclusion (CE)** |  | 95d | 2028-09-01 | 2029-01-31 |  | 262d |  |  |  |  |
| 362 | 1.4.25.7.1 | Prepare & Submit Draft Categorical Exclusion (CE) |  | 10d | 2028-09-01 | 2028-09-15 | 280, 281, 243, 158, 108, 109, 261, 56, 353, 348 | 327d | 0d | 2EP1 | EP | PEF |
| 363 | 1.4.25.7.2 | Review of Draft CE |  | 10d | 2028-09-18 | 2028-09-29 | 362 | 327d | 65d | 2EP1 | EP | NCDOT |
| 364 | 1.4.25.7.3 | Revise & Submit Final CE |  | 5d | 2029-01-18 | 2029-01-24 | 363, 301, 285 | 262d | 0d | 2EP1 | EP | PEF |
| 365 | 1.4.25.7.4 | Review of Final CE |  | 5d | 2029-01-25 | 2029-01-31 | 364 | 262d | 245d | 2EP1 | EP | NCDOT |
| 366 | 1.4.25.8 | **Final EA/EIS/FONSI** |  | 340d | 2028-09-01 | 2030-02-01 |  | 17d |  |  |  |  |
| 367 | 1.4.25.8.1 | Prepare & Submit Final EA/EIS/FONSI |  | 240d | 2028-09-01 | 2029-08-27 | 353, 280, 281, 243, 158, 108, 109, 261, 56, 348 | 17d | 0d | 2EP1 | EP | PEF |
| 368 | 1.4.25.8.2 | Agency Review of Final EA/EIS/FONSI |  | 40d | 2029-08-28 | 2029-10-23 | 367 | 17d | 0d | 2EP1 | EP | AGENCY |
| 369 | 1.4.25.8.3 | Final EA/EIS/FONSI Approved | milestone | 0d | 2029-10-23 | 2029-10-23 | 368 | 17d | 0d | 2EP1 | EP | PEF |
| 370 | 1.4.25.8.4 | Record of Decision Development (ROD) |  | 60d | 2029-10-24 | 2030-02-01 | 369 | 17d | 0d | 2EP1 | EP | PEF |
| 371 | 1.4.25.8.5 | Issue Record of Decision (ROD) | milestone | 0d | 2030-02-01 | 2030-02-01 | 370 | 17d | 0d | 2EP1 | EP | PEF |
| 372 | 1.4.25.9 | Environmental Document Approved | milestone | 0d | 2030-02-01 | 2030-02-01 | 365, 371 | 17d | 0d | 2EP1 | EP | NCDOT |
| 373 | 1.4.26 | **Initiate Transportation Management Plan** |  | 20d | 2030-01-04 | 2030-02-04 |  | 357d |  | 2TM2 | TM |  |
| 374 | 1.4.26.1 | Complete Concept Temporary Traffic Control (TTC) Plans |  | 20d | 2030-01-04 | 2030-02-04 | 380SF, 381SF, 158 | 357d | 0d | 2TM2 | TM | PEF |
| 375 | 1.4.27 | **Initiate Signing and Delineation Design** |  | 20d | 2030-01-04 | 2030-02-04 |  | 688d |  | SD | SD |  |
| 376 | 1.4.27.1 | Prepare Preliminary Signing and Delineation Strip Map |  | 20d | 2030-01-04 | 2030-02-04 | 380SF, 381SF, 158 | 688d |  | 2SD1 | SD | PEF |
| 377 | 1.4.28 | Complete Value Management Activities |  | 60d | 2026-05-06 | 2026-07-30 | 136 | 867d | 850d | 2VM1 | VM | NCDOT |
| 378 | 1.4.29 | Initiate Signal System Timing |  | 20d | 2030-02-04 | 2030-03-01 | 374 | 628d | 430d | 2SS1 | SS | PEF |
| 379 | 1.4.30 | **Prepare for Field Inspection** |  | 40d | 2030-02-04 | 2030-03-29 |  | 17d |  | 2RD3 | RD |  |
| 380 | 1.4.30.1 | Prepare Field Construction Estimate |  | 20d | 2030-02-04 | 2030-03-01 | 377, 200, 245, 246, 248, 173, 372, 179, 206, 244, 167, 23, 25, 182, 197FF, 250, 191FF | 17d | 0d | 2CS2 | CS | PEF |
| 381 | 1.4.30.2 | Prepare Field Inspection Plans Set |  | 20d | 2030-02-04 | 2030-03-01 | 200, 377, 250, 245, 246, 248, 173, 372, 197FF, 182, 206, 244, 167, 23, 25, 191FF, 179 | 17d | 0d | 2RD3 | RD | PEF |
| 382 | 1.4.30.3 | Review of Field Inspection Plan Set |  | 20d | 2030-03-04 | 2030-03-29 | 380, 381 | 17d | 0d | 2RD3 | RD | NCDOT |
| 383 | 1.4.30.4 | Field Inspection | milestone | 0d | 2030-03-29 | 2030-03-29 | 382 | 17d | 0d | 2RD3 | RD | NCDOT |
| 384 | 1.4.31 | **ROW Plans Completed** |  | 40d | 2030-04-01 | 2030-05-28 |  | 17d |  | 2RD4 | RD |  |
| 385 | 1.4.31.1 | Complete & Submit ROW Plan Set |  | 20d | 2030-04-01 | 2030-04-29 | 397, 383, 399FF, 400FF, 185, 186 | 27d | 0d | 2RD4 | RD | PEF |
| 386 | 1.4.31.2 | Review of ROW Plan Set |  | 10d | 2030-04-30 | 2030-05-13 | 385 | 27d | 0d | 2RD4 | RD | NCDOT |
| 387 | 1.4.31.3 | Revise & Resubmit ROW Plan Set |  | 5d | 2030-05-14 | 2030-05-20 | 386 | 27d | 0d | 2RD4 | RD | PEF |
| 388 | 1.4.31.4 | Review of Revised ROW Plan Set |  | 5d | 2030-05-21 | 2030-05-28 | 387 | 27d | 0d | 2RD4 | RD | NCDOT |
| 389 | 1.4.31.5 | ROW Plans Complete (RPC) | milestone | 0d | 2030-05-28 | 2030-05-28 | 388 | 27d | 0d | 2RD4 | RD |  |
| 390 | 1.4.31.6 | Prepare ROW Cost Estimate |  | 10d | 2030-04-01 | 2030-04-12 | 383 | 17d | 0d | 2RW3 | RW | ROW PEF |
| 391 | 1.4.31.7 | Review of ROW Cost Estimate |  | 10d | 2030-04-15 | 2030-04-29 | 390 | 17d | 0d | 2RW3 | RW | NCDOT |

Notes:
- 361: Remove from Schedule if EA/EIS/FONSI
- 364: Need Final TNR and 4(f) Signed de minimis Agreement for Final CE
- 367: Can Take 1-2 Years Depending on The Project, Tie to CP4A
- 368: Minimum of 1.5 - 2 months for review
- 369: Tie to ROD if EIS, Tie to Document Approved if FONSI
- 370: Issued Minimum of 3 months after Agency Review

| ID | WBS | Task | Type | Duration | Start | Finish | Predecessors | Total slack | Free slack | Task Code | Discipline Code | Responsible Party |
| --- | --- | --- | --- | --- | --- | --- | --- | --- | --- | --- | --- | --- |
| 392 | 1.5 | **Scoping, Fee Estimate, and Notice to Proceed (Stage 3 & 4)** |  | 40d | 2029-01-25 | 2029-03-21 |  | 277d |  | SCOPE | SCOPE |  |
| 393 | 1.5.1 | Scope Development |  | 10d | 2029-01-25 | 2029-02-07 | 173, 200, 206 | 277d | 0d | SCOPE | SCOPE | PEF |
| 394 | 1.5.2 | Review/Approve Scope |  | 10d | 2029-02-08 | 2029-02-21 | 393 | 277d | 0d | SCOPE | SCOPE | NCDOT |
| 395 | 1.5.3 | Fee Estimate Development |  | 10d | 2029-02-22 | 2029-03-07 | 394 | 277d | 0d | SCOPE | SCOPE | PEF |
| 396 | 1.5.4 | Review/Approve Fee Estimate |  | 10d | 2029-03-08 | 2029-03-21 | 395 | 277d | 0d | SCOPE | SCOPE | NCDOT |
| 397 | 1.5.5 | Notice To Proceed (Stage 3 & 4) | milestone | 0d | 2029-03-21 | 2029-03-21 | 396 | 277d | 250d | SCOPE | SCOPE |  |
| 398 | 1.6 | **Final Plans (Stage 3)** |  | 1460d | 2026-06-04 | 2032-06-01 |  | 118d |  |  |  |  |
| 399 | 1.6.1 | Verify and Revise Pavement Design |  | 5d | 2030-04-01 | 2030-04-05 | 383, 248, 397 | 42d | 15d | 3PD1 | PD | PEF |
| 400 | 1.6.2 | Incorporate Value Management Activities |  | 5d | 2030-04-01 | 2030-04-05 | 377, 383, 397 | 42d | 15d | 3VM1 | VM | PEF |
| 401 | 1.6.3 | **Right of Way Funding** |  | 90d | 2030-02-04 | 2030-06-11 |  | 77d |  | 3RW1 | RW |  |
| 402 | 1.6.3.1 | Complete NEPA/SEPA Documentation |  | 10d | 2030-02-04 | 2030-02-15 | 403SS-60d | 678d |  | 3EP1 | EP | PEF |
| 403 | 1.6.3.2 | Complete ROW Authorization Package |  | 30d | 2030-04-30 | 2030-06-11 | 391, 372 | 17d | 0d | 3RW1 | RW | NCDOT |
| 404 | 1.6.3.3 | ROW Funds Released | milestone | 0d | 2030-06-11 | 2030-06-11 | 403 | 17d | 0d | 3RW1 | RW | NCDOT |
| 405 | 1.6.4 | Complete Additional Surveys and ROW Acquisition Surveys |  | 20d | 2030-05-29 | 2030-06-25 | 389 | 167d | 150d | 3LS1 | LS | NCDOT |
| 406 | 1.6.5 | **Complete ROW Acquisitions and Relocations** |  | 480d | 2030-06-12 | 2032-05-28 |  | 17d |  | 3RW2 | RW | ROW PEF |
| 407 | 1.6.5.1 | Phase 1 - ROW Acquisitions and Relocations (Utility/Priority Parcels) |  | 160d | 2030-06-12 | 2031-02-11 | 404, 405FF, 442, 389 | 17d | 0d | 3RW2 | RW | ROW PEF |
| 408 | 1.6.5.2 | Phase 2 - ROW Acquisitions and Relocations (Utility/Priority Parcels) |  | 160d | 2031-02-12 | 2031-09-29 | 407 | 17d | 0d | 3RW2 | RW | ROW PEF |
| 409 | 1.6.5.3 | Remaining ROW Acquisitions and Relocations |  | 160d | 2031-09-30 | 2032-05-28 | 408 | 19d | 0d | 3RW2 | RW | ROW PEF |
| 410 | 1.6.5.4 | ROW Certification | milestone | 0d | 2032-05-28 | 2032-05-28 | 409 | 19d | 0d | 3RW2 | RW | NCDOT |
| 411 | 1.6.6 | **Complete Roadway Design** |  | 40d | 2031-09-30 | 2031-12-02 |  | 218d |  | 3RD1 | RD |  |
| 412 | 1.6.6.1 | Complete & Submit Final Roadway Plan Set |  | 20d | 2031-09-30 | 2031-10-27 | 397, 389, 399, 400, 408, 319 | 218d | 0d | 3RD1 | RD | PEF |
| 413 | 1.6.6.2 | Review Final Roadway Plan Set |  | 10d | 2031-10-28 | 2031-11-10 | 412 | 218d | 0d | 3RD1 | RD | NCDOT |
| 414 | 1.6.6.3 | Revise & Resubmit Final Roadway Plan Set |  | 5d | 2031-11-12 | 2031-11-18 | 413 | 218d | 0d | 3RD1 | RD | PEF |
| 415 | 1.6.6.4 | Review Revised Final Roadway Plan Set |  | 5d | 2031-11-19 | 2031-12-02 | 414 | 218d | 0d | 3RD1 | RD | NCDOT |
| 416 | 1.6.6.5 | Final Roadway Plan Set Approved | milestone | 0d | 2031-12-02 | 2031-12-02 | 415 | 218d | 0d | 3RD1 | RD | NCDOT |

Notes:
- 402: 3 months prior to ROW Fund Request Complete ROW Consult. If needed
- 403: Includes Board Authorization of Funds, Match up with Board Dates
- 405: Concurrent with Start of ROW. Adjust as needed.
- 412: Tied to ROW Acquisition Phase 2 (adjust as needed)

| ID | WBS | Task | Type | Duration | Start | Finish | Predecessors | Total slack | Free slack | Task Code | Discipline Code | Responsible Party |
| --- | --- | --- | --- | --- | --- | --- | --- | --- | --- | --- | --- | --- |
| 417 | 1.6.7 | **Complete Utility Coordination and/or Design** |  | 135d | 2030-05-29 | 2030-12-13 |  | 172d |  | 3UT1 | UT |  |
| 418 | 1.6.7.1 | Prepare & Submit Utilities By Other (UBO) Plans |  | 20d | 2030-05-29 | 2030-06-25 | 389 | 172d | 0d | 3UT1 | UT | UTILITY PEF |
| 419 | 1.6.7.2 | Review of UBO Plans |  | 10d | 2030-06-26 | 2030-07-10 | 418 | 172d | 0d | 3UT1 | UT | NCDOT |
| 420 | 1.6.7.3 | Revise & Resubmit UBO Plans |  | 5d | 2030-07-11 | 2030-07-17 | 419 | 172d | 0d | 3UT1 | UT | UTILITY PEF |
| 421 | 1.6.7.4 | Review of Revised UBO Plans |  | 5d | 2030-07-18 | 2030-07-24 | 420 | 172d | 0d | 3UT1 | UT | NCDOT |
| 422 | 1.6.7.5 | UBO Plans Approved | milestone | 0d | 2030-07-24 | 2030-07-24 | 421 | 172d | 0d | 3UT1 | UT | NCDOT |
| 423 | 1.6.7.6 | Prepare & Submit Final Utility Construction (UC) Plans to NCDOT & Utility Owners |  | 40d | 2030-05-29 | 2030-07-24 | 389, 190 | 172d | 0d | 3UT1 | UT | UTILITY PEF |
| 424 | 1.6.7.7 | Review of Final UC Plans |  | 20d | 2030-07-25 | 2030-08-21 | 423 | 374d | 0d | 3UT1 | UT | NCDOT / UO |
| 425 | 1.6.7.8 | Revise & Resubmit Final UC Plans to Utility Owners |  | 10d | 2030-08-22 | 2030-09-05 | 424 | 374d | 0d | 3UT1 | UT | UTILITY PEF |
| 426 | 1.6.7.9 | Utility Owners Review of Revised Final UC Plans |  | 10d | 2030-09-06 | 2030-09-19 | 425 | 374d | 0d | 3UT1 | UT | UTILITY OWNERS |
| 427 | 1.6.7.10 | Final UC Plans Approved | milestone | 0d | 2030-09-19 | 2030-09-19 | 426 | 374d | 0d | 3UT1 | UT | UTILITY OWNERS |
| 428 | 1.6.7.11 | Finalize Permit Applications (Prepare/Submit/Receive Signatures) |  | 5d | 2030-09-20 | 2030-09-26 | 427 | 374d | 0d | 3UT1 | UT | UTILITY PEF |
| 429 | 1.6.7.12 | Submit Final UC Plan Package to NCDEQ Water Supply Section for Review | milestone | 0d | 2030-09-26 | 2030-09-26 | 428 | 374d | 0d | 3UT1 | UT | UTILITY PEF |
| 430 | 1.6.7.13 | Review of Final UC Plan Package |  | 40d | 2030-09-27 | 2030-11-22 | 429 | 374d | 0d | 3UT1 | UT | AGENCY |
| 431 | 1.6.7.14 | Revise & Resubmit Final UC Plan Package to Utility Owners |  | 5d | 2030-12-02 | 2030-12-06 | 430 | 374d | 0d | 3UT1 | UT | UTILITY PEF |
| 432 | 1.6.7.15 | Review of Revised Final UC Plan Package |  | 5d | 2030-12-09 | 2030-12-13 | 431 | 374d | 0d | 3UT1 | UT | AGENCY |
| 433 | 1.6.7.16 | Issue Authorization to Construct | milestone | 0d | 2030-12-13 | 2030-12-13 | 432 | 374d | 355d | 3UT1 | UT | AGENCY |
| 434 | 1.6.8 | **Initiate Utility Relocations by Others** |  | 10d | 2030-07-25 | 2030-08-07 |  | 280d |  | 3UT2 | UT |  |
| 435 | 1.6.8.1 | Update the Utilities Relocation Schedule |  | 10d | 2030-07-25 | 2030-08-07 | 422 | 280d | 0d | 3UT2 | UT | UTILITY PEF |
| 436 | 1.6.8.2 | Hold Relocation Scheduling Conference | milestone | 0d | 2030-08-07 | 2030-08-07 | 435, 438 | 310d | 125d | 3UT2 | UT | NCDOT |
| 437 | 1.6.9 | **Prepare Final Utility Relocation and Construction Estimates** |  | 40d | 2030-07-25 | 2030-09-19 |  | 280d |  | 3UT3 | UT |  |
| 438 | 1.6.9.1 | Prepare Utility Relocation and Construction Estimates |  | 10d | 2030-07-25 | 2030-08-07 | 422 | 280d | 0d | 3UT3 | UT | UTILITY PEF |
| 439 | 1.6.9.2 | Utility Relocation Funding Request |  | 30d | 2030-08-08 | 2030-09-19 | 438, 435 | 280d | 0d | 3UT3 | UT | NCDOT |
| 440 | 1.6.9.3 | Utility Relocation Funds Released | milestone | 0d | 2030-09-19 | 2030-09-19 | 439 | 280d | 95d | 3UT3 | UT | NCDOT |

| ID | WBS | Task | Type | Duration | Start | Finish | Predecessors | Total slack | Free slack | Task Code | Discipline Code | Responsible Party |
| --- | --- | --- | --- | --- | --- | --- | --- | --- | --- | --- | --- | --- |
| 441 | 1.6.10 | **GeoEnvironmental and Subsurface Investigation** |  | 660d | 2026-06-04 | 2029-02-21 |  | 768d |  | 3GT | GT |  |
| 442 | 1.6.10.1 | Prepare GeoEnvironmental Phase II Report |  | 40d | 2026-06-04 | 2026-07-30 | 244 | 957d | 940d | 3GT1 | GT | NCDOT |
| 443 | 1.6.10.2 | Verify Geotechnical Deliverables |  | 10d | 2029-02-08 | 2029-02-21 | 246 | 768d | 0d | 3GT2 | GT | NCDOT |
| 444 | 1.6.11 | **Complete Erosion and Sediment Control Plans** |  | 30d | 2030-07-25 | 2030-09-05 |  | 212d |  | 3RE1 | RE |  |
| 445 | 1.6.11.1 | Prepare & Submit Erosion Control Plan Package |  | 10d | 2030-07-25 | 2030-08-07 | 389, 422, 423 | 212d | 0d | 3RE1 | RE | PEF |
| 446 | 1.6.11.2 | Review of Erosion Control Package |  | 10d | 2030-08-08 | 2030-08-21 | 445 | 212d | 0d | 3RE1 | RE | NCDOT |
| 447 | 1.6.11.3 | Revise & Resubmit Erosion Control Package |  | 5d | 2030-08-22 | 2030-08-28 | 446 | 212d | 0d | 3RE1 | RE | PEF |
| 448 | 1.6.11.4 | Approve Erosion Control Package |  | 5d | 2030-08-29 | 2030-09-05 | 447 | 212d | 0d | 3RE1 | RE | NCDOT |
| 449 | 1.6.11.5 | Erosion Control Package Approved | milestone | 0d | 2030-09-05 | 2030-09-05 | 448 | 212d | 40d | 3RE1 | RE | NCDOT |
| 450 | 1.6.12 | **Complete Hydraulic Permitting Tasks and Finalize Plans** |  | 110d | 2030-05-29 | 2030-10-31 |  | 212d |  | 3HY1 | HY |  |
| 451 | 1.6.12.1 | State Floodplain Compliance (SFC) Package |  | 5d | 2030-05-29 | 2030-06-04 | 173, 389 | 472d | 0d | 3HY1 | HY | PEF |
| 452 | 1.6.12.2 | NC SFC Review & Approval |  | 60d | 2030-06-05 | 2030-08-28 | 451 | 472d | 445d | 3HY1 | HY | AGENCY |
| 453 | 1.6.12.3 | Prepare & Submit Permit Drawing Package |  | 10d | 2030-07-25 | 2030-08-07 | 389, 422, 423 | 172d | 0d | 3HY1 | HY | PEF |
| 454 | 1.6.12.4 | Review of Permit Drawing Package |  | 10d | 2030-08-08 | 2030-08-21 | 453 | 172d | 0d | 3HY1 | HY | NCDOT |
| 455 | 1.6.12.5 | **Merger CP4C Meeting (Permit Drawing Review)** |  | 40d | 2030-08-21 | 2030-10-17 |  | 172d |  |  |  |  |
| 456 | 1.6.12.5.1 | Request Merger CP4C Meeting | milestone | 0d | 2030-08-21 | 2030-08-21 | 454, 360, 372 | 172d | 0d | 2EP1 | EP | PEF |
| 457 | 1.6.12.5.2 | Prepare for Merger CP4C Meeting |  | 25d | 2030-08-22 | 2030-09-26 | 456 | 172d | 0d | 2EP1 | EP | PEF |
| 458 | 1.6.12.5.3 | Merger CP4C Pre-Meeting [Not Required] |  | 15d | 2030-09-27 | 2030-10-17 | 457 | 172d | 0d | 2EP1 | EP | PEF |
| 459 | 1.6.12.5.4 | Hold Merger CP4C Meeting (Permit Drawing Review) | milestone | 0d | 2030-10-17 | 2030-10-17 | 458 | 172d | 0d | 2EP1 | EP | PEF |
| 460 | 1.6.12.6 | Revise & Resubmit Permit Drawing Package |  | 5d | 2030-10-18 | 2030-10-24 | 454, 459 | 172d | 0d | 3HY1 | HY | PEF |
| 461 | 1.6.12.7 | Approve Permit Drawing Package |  | 5d | 2030-10-25 | 2030-10-31 | 460 | 172d | 0d | 3HY1 | HY | NCDOT |
| 462 | 1.6.12.8 | Permit Drawing Package Approved | milestone | 0d | 2030-10-31 | 2030-10-31 | 461 | 172d | 0d | 3HY1 | HY | NCDOT |
| 463 | 1.6.13 | **Complete Permit Application Package** |  | 65d | 2030-11-01 | 2031-02-18 |  | 172d |  | 3EN1 | EN |  |
| 464 | 1.6.13.1 | Prepare & Submit Permit Application Package |  | 10d | 2030-11-01 | 2030-11-15 | 449, 462 | 172d | 0d | 3EN1 | EN | PEF |
| 465 | 1.6.13.2 | Review of Permit Application Package |  | 10d | 2030-11-18 | 2030-12-06 | 464 | 172d | 0d | 3EN1 | EN | NCDOT |
| 466 | 1.6.13.3 | Revise & Submit Permit Application Package |  | 5d | 2030-12-09 | 2030-12-13 | 465 | 172d | 0d | 3EN1 | EN | PEF |
| 467 | 1.6.13.4 | Review of Permit Application Package |  | 40d | 2030-12-16 | 2031-02-18 | 466 | 172d | 0d | 3EN1 | EN | AGENCY |

Notes:
- 442: Tie to ROW Acq. For Priority Parcel Identification
- 456: Needs to be 6-8 weeks prior to CP4C Meeting, Tie to Permit Drawing
- 457: Can take 6-8 weeks to schedule and hold CP4C Meeting
- 458: Pre-meeting is not req. for CP4C, 3 weeks minimum before the CP4C Mtg
- 459: Tie to Final Permit Drawing Submittal

| ID | WBS | Task | Type | Duration | Start | Finish | Predecessors | Total slack | Free slack | Task Code | Discipline Code | Responsible Party |
| --- | --- | --- | --- | --- | --- | --- | --- | --- | --- | --- | --- | --- |
| 468 | 1.6.14 | **Complete Structures Design** |  | 140d | 2029-02-22 | 2029-09-11 |  | 768d |  | 3ST1 | ST |  |
| 469 | 1.6.14.1 | Prepare & Submit Final (Unsealed) Structure Plans |  | 120d | 2029-02-22 | 2029-08-13 | 200, 443 | 768d | 0d | 3ST1 | ST | PEF |
| 470 | 1.6.14.2 | Review of Final (Unsealed) Structure Plans |  | 20d | 2029-08-14 | 2029-09-11 | 469 | 768d | 640d | 3ST1 | ST | NCDOT |
| 471 | 1.6.15 | **Complete Signal & ITS Design** |  | 180d | 2031-09-02 | 2032-06-01 |  | 118d |  | 3SG1 | SG |  |
| 472 | 1.6.15.1 | Prepare & Submit 1st Signal Submittal (Temporary Poles and Geometrics) |  | 40d | 2031-09-02 | 2031-10-28 | 473SF | 228d | 0d | 3SG1 | SG | PEF |
| 473 | 1.6.15.2 | Review of 1st Submittal |  | 20d | 2031-10-28 | 2031-12-03 | 474SF | 228d | 0d | 3SG1 | SG | NCDOT |
| 474 | 1.6.15.3 | Revise & Submit 2nd Signal Submittal (Include Wiring) |  | 40d | 2031-12-03 | 2032-02-06 | 475SF, 378 | 198d | 0d | 3SG1 | SG | PEF |
| 475 | 1.6.15.4 | Review of 2nd Submittal |  | 20d | 2032-02-06 | 2032-03-05 | 476SF | 178d | 0d | 3SG1 | SG | NCDOT |
| 476 | 1.6.15.5 | Revise & Submit 3rd Signal Submittal (Final Plans) |  | 40d | 2032-03-05 | 2032-05-03 | 477SF | 138d | 0d | 3SG1 | SG | PEF |
| 477 | 1.6.15.6 | Review of 3rd Submittal |  | 20d | 2032-05-03 | 2032-06-01 | 478SF | 118d | 0d | 3SG1 | SG | NCDOT |
| 478 | 1.6.15.7 | Signal Plans Approved | milestone | 0d | 2032-06-01 | 2032-06-01 | 528SF, 541SF | 118d | 0d | 3SG1 | SG | NCDOT |
| 479 | 1.6.16 | **Complete Signing and Delineation Design** |  | 180d | 2031-09-02 | 2032-06-01 |  | 118d |  | 3SD1 | SD |  |
| 480 | 1.6.16.1 | Prepare 100% Unsealed Signing and Delineation Plans |  | 40d | 2031-09-02 | 2031-10-27 | 472SS | 228d | 0d | 3SD1 | SD | PEF |
| 481 | 1.6.16.2 | Review of 100% Unsealed Submittal |  | 10d | 2031-10-28 | 2031-11-10 | 480 | 228d | 110d | 3SD1 | SD | NCDOT |
| 482 | 1.6.16.3 | Prepare 100% Sealed Signing and Delineation Plans |  | 20d | 2032-05-03 | 2032-06-01 | 481, 528SF, 541SF | 118d |  | 3SD1 | SD | PEF |
| 483 | 1.6.17 | **Finalize Railroad Design & Agreements** |  | 1150d | 2026-08-14 | 2031-05-07 |  | 357d |  | 3RR1 | RR |  |
| 484 | 1.6.17.1 | Prepare PE Agreement between NCDOT and Railroad |  | 10d | 2026-08-14 | 2026-08-27 | 158 | 1127d | 0d | 3RR1 | RR | NCDOT |
| 485 | 1.6.17.2 | Review of PE Agreement |  | 60d | 2026-08-28 | 2026-11-30 | 484 | 1127d | 0d | 3RR1 | RR | RAIL |
| 486 | 1.6.17.3 | PE Agreement between NCDOT and Railroad Signed | milestone | 0d | 2026-11-30 | 2026-11-30 | 485 | 1127d | 770d | 3RR1 | RR | NCDOT |
| 487 | 1.6.17.4 | Hold Field Diagnostics Meeting with NCDOT and Railroad |  | 10d | 2030-02-04 | 2030-02-15 | 173, 374, 486 | 357d | 0d | 3RR1 | RR | PEF |
| 488 | 1.6.17.5 | Prepare & Submit Initial Planimetric for Railroad Signal and Gates |  | 20d | 2030-02-18 | 2030-03-15 | 487 | 357d | 0d | 3RR1 | RR | PEF |
| 489 | 1.6.17.6 | Review of Initial Planimetric for Railroad Signal and Gates |  | 20d | 2030-03-18 | 2030-04-12 | 488 | 357d | 0d | 3RR1 | RR | NCDOT |
| 490 | 1.6.17.7 | Prepare & Submit Final Planimetric for Railroad Signal and Gates |  | 10d | 2030-04-15 | 2030-04-29 | 489 | 357d | 0d | 3RR1 | RR | PEF |
| 491 | 1.6.17.8 | Review of Final Planimetric for Railroad Signal and Gates |  | 10d | 2030-04-30 | 2030-05-13 | 490 | 357d | 0d | 3RR1 | RR | NCDOT |
| 492 | 1.6.17.9 | Review of Planimetric to Include Material Procurement |  | 240d | 2030-05-14 | 2031-05-07 | 491 | 357d | 0d | 3RR1 | RR | RAIL |
| 493 | 1.6.17.10 | Planimetric and Material Procurement Complete | milestone | 0d | 2031-05-07 | 2031-05-07 | 492 | 357d | 340d | 3RR1 | RR | NCDOT |

Notes:
- 484: Assume DRPS needed to begin process, may be done earlier
- 487: Assume PE Agreement with Railroad, Hydro, and WZTC are needed.
- 492: Could take up to 12 months for Rail to procure gate materials
- 493: Assume procurement of materials complete by let

| ID | WBS | Task | Type | Duration | Start | Finish | Predecessors | Total slack | Free slack | Task Code | Discipline Code | Responsible Party |
| --- | --- | --- | --- | --- | --- | --- | --- | --- | --- | --- | --- | --- |
| 494 | 1.6.18 | **Complete Railroad Coordination** |  | 80d | 2030-05-29 | 2030-09-19 |  | 457d |  | 3RR2 | RR |  |
| 495 | 1.6.18.1 | Prepare & Submit Railroad Encroachment Agreement |  | 10d | 2030-05-29 | 2030-06-11 | 389 | 457d | 0d | 3RR2 | RR | PEF |
| 496 | 1.6.18.2 | Review of Railroad Encroachment Agreement |  | 10d | 2030-06-12 | 2030-06-25 | 495 | 457d | 0d | 3RR2 | RR | NCDOT |
| 497 | 1.6.18.3 | Review of Railroad Encroachment Agreement |  | 60d | 2030-06-26 | 2030-09-19 | 496 | 457d | 0d | 3RR2 | RR | RAIL |
| 498 | 1.6.18.4 | Railroad Encroachment Agreement Signed | milestone | 0d | 2030-09-19 | 2030-09-19 | 497 | 457d | 0d | 3RR2 | RR | NCDOT |
| 499 | 1.6.18.5 | Railroad Certification | milestone | 0d | 2030-09-19 | 2030-09-19 | 498 | 469d | 450d | 3RR2 | RR | NCDOT |
| 500 | 1.6.19 | Complete Transportation Management Plan |  | 20d | 2032-05-03 | 2032-06-01 | 528SF, 389, 541SF | 118d |  | 3TM1 | TM | PEF |
| 501 | 1.6.20 | Prepare Construction Estimate |  | 10d | 2031-12-03 | 2031-12-16 | 535SF-260d, 389, 427, 319, 416, 547SF-260d | 228d |  | 3CS1 | CS | PEF |
| 502 | 1.6.21 | 15 Month Let Review | milestone | 0d | 2031-08-28 | 2031-08-28 | 538FS-300d, 550FS-300d | 300d |  | 3PM2 | PM | NCDOT |
| 503 | 1.6.22 | **Design Complete Review Meeting** |  | 20d | 2031-12-03 | 2032-01-07 |  | 218d |  | 3PM3 | PM |  |
| 504 | 1.6.22.1 | Finalize Design Completion Review Field Inspection Materials |  | 10d | 2031-12-03 | 2031-12-16 | 416, 422, 427, 449, 462 | 218d | 0d | 3PM3 | PM | PEF |
| 505 | 1.6.22.2 | Prepare for Completion Review Field Inspection |  | 10d | 2031-12-17 | 2032-01-07 | 504 | 218d | 0d | 3PM3 | PM | NCDOT |
| 506 | 1.6.22.3 | Conduct Design Complete Field Inspection | milestone | 0d | 2032-01-07 | 2032-01-07 | 505 | 218d | 90d | 3PM3 | PM | NCDOT |
| 507 | 1.7 | **Plans, Specifications, and Estimates (PS&E)/Letting (Stage 4)** |  | 568d | 2030-07-25 | 2032-11-16 |  | 0d |  |  |  |  |
| 508 | 1.7.1 | Secure Permits | milestone | 0d | 2031-02-18 | 2031-02-18 | 467 | 172d | 0d | 4EN1 | EN | PEF |
| 509 | 1.7.2 | Complete NEPA/SEPA Documentation | milestone | 0d | 2032-06-22 | 2032-06-22 | 535FS-60d, 547FS-60d | 103d |  | 4EP1 | EP | NCDOT |
| 510 | 1.7.3 | **Utility Relocation** |  | 530d | 2030-07-25 | 2032-09-22 |  | 30d |  | 4UT | UT |  |
| 511 | 1.7.3.1 | Finalize Utility Coordination and/or Utility Design PS&E |  | 20d | 2030-07-25 | 2030-08-21 | 422 | 300d | 0d | 4UT1 | UT | UTILITY PEF |
| 512 | 1.7.3.2 | Utility Certification | milestone | 0d | 2030-08-21 | 2030-08-21 | 511 | 489d | 470d | 4UT1 | UT | NCDOT |
| 513 | 1.7.3.3 | Complete Utility Relocation by Owner [Phase 1] |  | 240d | 2031-02-19 | 2032-02-12 | 511, 508, 440, 407, 436 | 185d | 175d | 4UT2 | UT | UTILITY OWNERS |
| 514 | 1.7.3.4 | Complete Utility Relocation by Owner [Phase 2] [Tentative Beyond Let] |  | 240d | 2031-09-30 | 2032-09-22 | 508, 408 | 17d | 0d | 4UT2 | UT | UTILITY OWNERS |
| 515 | 1.7.4 | **Finalize Structures Design PS&E** |  | 20d | 2032-05-03 | 2032-06-01 |  | 118d |  | 4ST1 | ST |  |
| 516 | 1.7.4.1 | Submit Final (Sealed) Structure Plans |  | 10d | 2032-05-03 | 2032-05-17 | 517SF, 470 | 128d |  | 4ST1 | ST | PEF |
| 517 | 1.7.4.2 | Review of Final (Sealed) Structure Plans |  | 10d | 2032-05-17 | 2032-06-01 | 518SF | 118d | 0d | 4ST1 | ST | NCDOT |
| 518 | 1.7.4.3 | Structure Plans Approved | milestone | 0d | 2032-06-01 | 2032-06-01 | 528SF, 541SF | 118d | 0d | 4ST1 | ST | NCDOT |
| 519 | 1.7.5 | Manage GeoEnvironmental Impacts |  | 20d | 2032-05-03 | 2032-06-01 | 528SF, 442, 541SF | 118d |  | 4GT1 | GT | NCDOT |
| 520 | 1.7.6 | Complete ROW Acquisition Surveys |  | 30d | 2032-06-01 | 2032-07-13 | 410 | 19d | 0d | 4LS1 | LS | NCDOT |
| 521 | 1.7.7 | Hydraulic Let Preparation |  | 20d | 2032-05-03 | 2032-06-01 | 528SF, 462, 541SF | 118d |  | 4HY1 | HY | PEF |
| 522 | 1.7.8 | Finalize Erosion & Sediment Control Contract Package |  | 20d | 2032-05-03 | 2032-06-01 | 528SF, 449, 541SF | 118d |  | 4RE1 | RE | PEF |
| 523 | 1.7.9 | Prepare Construction Communication Activities |  | 20d | 2032-05-03 | 2032-06-01 | 528SF, 541SF | 118d |  | 4CG1 | CG | NCDOT |
| 524 | 1.7.10 | Complete Value Management Activities |  | 20d | 2032-05-03 | 2032-06-01 | 528SF, 541SF | 118d |  | 4VM1 | VM | NCDOT |
| 525 | 1.7.11 | PS&E Review Meeting | milestone | 0d | 2032-05-17 | 2032-05-17 | 529FS-30d, 506, 542FS-30d | 128d |  | 4PM2 | PM | NCDOT |

Notes:
- 495: Tied to the ROW plans, but may be able to submit earlier
- 498: Assume complete by RPCP
- 501: Needs to be done 13 months prior to funding.
- 502: 15 Month Pre-Let Review Meeting
- 506: Tie to 4PM2, Allow time for changes to plans as needed
- 509: Construction Consultation 3 months prior to project authorization
- 514: Assume Phase 2 by let, but could go beyond as needed
- 525: 6 Weeks prior to PS&E Turn In (RPCP)

| ID | WBS | Task | Type | Duration | Start | Finish | Predecessors | Total slack | Free slack | Calendar | Task Code | Discipline Code | Responsible Party | SAP MLSN |
| --- | --- | --- | --- | --- | --- | --- | --- | --- | --- | --- | --- | --- | --- | --- |
| 526 | 1.7.12 | **Central Let Activities** |  | 118d | 2032-06-01 | 2032-11-16 |  | 0d |  |  |  |  |  |  |
| 527 | 1.7.12.1 | **Finalize the PS&E Package** |  | 55d | 2032-06-01 | 2032-08-17 |  | 27d |  |  | 4RD1 | RD |  |  |
| 528 | 1.7.12.1.1 | Submit 100% Unsealed Plans, Quantities, and Special Provisions |  | 20d | 2032-06-01 | 2032-06-28 | 508, 319, 433, 410 | 27d | 0d |  | 4RD1 | RD | PEF |  |
| 529 | 1.7.12.1.2 | Roadway Plans to Contracts & Proposals (RPCP) | milestone | 0d | 2032-06-28 | 2032-06-28 | 528, 498, 452 | 27d | 0d |  | 4RD1 | RD | PEF | MLSN |
| 530 | 1.7.12.1.3 | Review of 100% Unsealed Plans, Quantities and Special Provisions |  | 20d | 2032-06-29 | 2032-07-27 | 529 | 27d | 0d |  | 4RD1 | RD | NCDOT |  |
| 531 | 1.7.12.1.4 | Revise & Resubmit 100% Unsealed Plans, Quantities and Special Provisions |  | 10d | 2032-07-28 | 2032-08-10 | 520FF, 530 | 27d | 0d |  | 4RD1 | RD | PEF |  |
| 532 | 1.7.12.1.5 | Review of Revised 100% Unsealed Plans, Quantities and Special Provisions |  | 5d | 2032-08-11 | 2032-08-17 | 531 | 27d | 0d |  | 4RD1 | RD | NCDOT |  |
| 533 | 1.7.12.1.6 | Submit 100% Sealed Plans, Quantities, and Special Provisions | milestone | 0d | 2032-08-17 | 2032-08-17 | 532 | 27d | 0d |  | 4RD1 | RD | PEF | MLSN |
| 534 | 1.7.12.2 | **Complete PS&E Package and Advertise the Project** |  | 45d | 2032-08-18 | 2032-10-20 |  | 17d |  |  | 4CS1 | CS |  |  |
| 535 | 1.7.12.2.1 | Construction Funding Request and Project Authorization |  | 15d | 2032-08-18 | 2032-09-08 | 533, 410, 372, 499, 512 | 27d | 5d |  | 4CS1 | CS | NCDOT |  |
| 536 | 1.7.12.2.2 | Advertise Project | milestone | 0d | 2032-09-22 | 2032-09-22 | 535, 493FF, 514FF | 17d | 0d |  | 4CS1 | CS | NCDOT | MLSN |
| 537 | 1.7.12.2.3 | Project Advertisement |  | 20d | 2032-09-23 | 2032-10-20 | 536 | 17d |  |  | 4CS1 | CS | NCDOT |  |
| 538 | 1.7.12.3 | Central Let | milestone | 1d | 2032-11-16 | 2032-11-16 | 513FF, 537 | 0d |  | Central Let Dates | 4CS2 | CS | NCDOT | M0550 |
| 539 | 1.7.13 | **Division Let Activities** |  | 100d | 2032-06-01 | 2032-10-20 |  | 10d |  |  |  |  |  |  |
| 540 | 1.7.13.1 | **Finalize the PS&E Package** |  | 30d | 2032-06-01 | 2032-07-13 |  | 19d |  |  | 4RD1 | RD |  |  |
| 541 | 1.7.13.1.1 | Submit 100% Unsealed Plans, Quantities, and Special Provisions |  | 10d | 2032-06-01 | 2032-06-14 | 508, 319, 433, 410 | 19d | 0d |  | 4RD1 | RD | PEF |  |
| 542 | 1.7.13.1.2 | Review of 100% Unsealed Plans, Quantities and Special Provisions |  | 10d | 2032-06-15 | 2032-06-28 | 541 | 19d | 0d |  | 4RD1 | RD | NCDOT |  |
| 543 | 1.7.13.1.3 | Revise & Submit 100% Sealed Plans, Quantities and Special Provisions |  | 10d | 2032-06-29 | 2032-07-13 | 542, 520FF | 19d | 0d |  | 4RD1 | RD | PEF |  |
| 544 | 1.7.13.1.4 | Submit 100% Sealed Plans, Quantities, and Special Provisions | milestone | 0d | 2032-07-13 | 2032-07-13 | 543 | 19d | 0d |  | 4RD1 | RD | PEF |  |
| 545 | 1.7.13.2 | **Complete PS&E Package and Advertise the Project** |  | 60d | 2032-07-14 | 2032-10-06 |  | 19d |  |  | 4CS1 | CS |  |  |
| 546 | 1.7.13.2.1 | Update Construction Estimate Pricing |  | 10d | 2032-07-14 | 2032-07-27 | 544 | 19d | 0d |  | 4CS1 | CS | NCDOT |  |
| 547 | 1.7.13.2.2 | Construction Funding Request and Project Authorization |  | 35d | 2032-07-28 | 2032-09-15 | 546, 410, 372, 499, 512 | 19d | 0d |  | 4CS1 | CS | NCDOT |  |
| 548 | 1.7.13.2.3 | Complete PS&E Package |  | 15d | 2032-07-14 | 2032-08-03 | 498, 508, 544, 372, 433, 452 | 49d | 30d |  | 4CS1 | CS | NCDOT |  |
| 549 | 1.7.13.2.4 | Project Advertisement |  | 15d | 2032-09-16 | 2032-10-06 | 547, 548, 493FF, 514FF | 19d | 9d |  | 4CS1 | CS | NCDOT |  |
| 550 | 1.7.13.3 | Division POC Let (DPOC) | milestone | 1d | 2032-10-20 | 2032-10-20 | 549, 513FF | 1d |  | Div 1, 6, 10 and 13 Let Dates | 4CS2 | CS | NCDOT |  |

Notes:
- 526: Delete if Division Let
- 537: Advertisement can be longer for larger more expensive projects
- 538: Choose Correct Central Let Task Calendar
- 539: Delete if Central Let
- 550: Choose Correct Division Let Task Calendar
