# NCDOT PDN Schedule

Schedule from MS Project, 2024-11-01 to 2029-03-05.

## Calendars

- NCDOT Holiday Calendar: Mon-Fri 08:00-12:00, 13:00-17:00; Sat-Sun off. Exceptions (off unless hours are given): 2024-11-11 (Veterans Day), 2024-11-25 to 2024-11-29 (Thanksgiving [Week]), 2024-12-23 to 2024-12-27 (Christmas [Week]), 2025-01-01 (New Years), 2025-01-20 (MLK), 2025-04-18 (Good Friday), 2025-05-26 (Memorial Day), 2025-07-04 (Independence Day), 2025-09-01 (Labor Day), 2025-11-11 (Veterans Day), 2025-11-24 to 2025-11-28 (Thanksgiving [Week]), 2025-12-22 to 2025-12-26 (Christmas [Week]), 2026-01-01 (New Years), 2026-01-19 (MLK), 2026-04-03 (Good Friday), 2026-05-25 (Memorial Day), 2026-07-03 (Independence Day), 2026-09-07 (Labor Day), 2026-11-11 (Veterans Day), 2026-11-23 to 2026-11-27 (Thanksgiving [Week]), 2026-12-21 to 2026-12-25 (Christmas [Week]), 2027-01-01 (New Years), 2027-01-18 (MLK), 2027-03-26 (Good Friday), 2027-05-31 (Memorial Day), 2027-07-05 (Independence Day), 2027-09-06 (Labor Day), 2027-11-11 (Veterans Day), 2027-11-22 to 2027-11-26 (Thanksgiving [Week]), 2027-12-24 to 2027-12-31 (Christmas [Week]), 2028-01-03 (New Year), 2028-01-17 (MLK), 2028-04-14 (Good Friday), 2028-05-29 (Memorial Day), 2028-07-04 (Independence Day), 2028-09-04 (Labor Day), 2028-11-10 (Veterans Day), 2028-11-20 to 2028-11-24 (Thanksgiving [Week]), 2028-12-25 to 2028-12-29 (Christmas [Week]), 2029-01-01 (New Years), 2029-01-15 (MLK).

## Resources

| Resource |
| --- |
| Transportation Planning |
| Division CDE's |
| Feasibility Studies |
| Funds Administration |
| STIP Unit |
| All Parties |
| NCDOT |
| HNTB |
| UTILITY PEF |
| NCDOT/HNTB |

## Schedule

| ID | WBS | Task | Type | Duration | Start | Finish | Predecessors | Total slack | Free slack | Task Code | Discipline Code | Responsible Party | SAP MLSN |
| --- | --- | --- | --- | --- | --- | --- | --- | --- | --- | --- | --- | --- | --- |
| 1 | 1 | **WBS# - PROJECT NAME/DESCRIPTION** |  | 1050d | 2024-11-01 | 2029-03-05 |  | 0d |  |  |  |  |  |
| 2 | 1.1 | **Scoping, Fee Estimate, and Notice to Proceed (Stage 1)** |  | 40d | 2024-11-01 | 2025-01-13 |  | 0d |  | SCOPE | SCOPE |  |  |
| 3 | 1.1.1 | Project Scoping Meeting | milestone | 0d | 2024-11-01 | 2024-11-01 |  | 0d |  | SCOPE | SCOPE | All Parties |  |
| 4 | 1.1.2 | Scope Development |  | 10d | 2024-11-01 | 2024-11-15 | 3 | 0d |  | SCOPE | SCOPE | PEF |  |
| 5 | 1.1.3 | Review/Approve Scope |  | 10d | 2024-11-18 | 2024-12-06 | 4 | 0d |  | SCOPE | SCOPE | NCDOT |  |
| 6 | 1.1.4 | Fee Estimate Development |  | 10d | 2024-12-09 | 2024-12-20 | 5 | 0d |  | SCOPE | SCOPE | PEF |  |
| 7 | 1.1.5 | Review/Approve Fee Estimate |  | 10d | 2024-12-30 | 2025-01-13 | 6 | 0d |  | SCOPE | SCOPE | NCDOT |  |
| 8 | 1.1.6 | Notice To Proceed (Stage 1) | milestone | 0d | 2025-01-13 | 2025-01-13 | 7 | 0d |  | SCOPE | SCOPE | NCDOT | M0965 |
| 9 | 1.2 | **Project Initiation (Stage 1)** |  | 215d | 2024-11-01 | 2025-09-22 |  | 10d |  |  |  |  |  |
| 10 | 1.2.1 | Provide Photogrammetric Control & Initiate Surveys |  | 60d | 2024-11-01 | 2025-02-11 | 3 | 10d | 0d | 1LS1 | LS | NCDOT |  |
| 11 | 1.2.2 | Reviews & Provides Best Available Geospatial Data |  | 20d | 2024-11-01 | 2024-12-06 | 3 | 50d | 40d | 1PH1 | PH | NCDOT |  |
| 12 | 1.2.3 | Compile Aerial Photography & Mapping |  | 60d | 2024-11-01 | 2025-02-11 | 3 | 10d | 0d | 1PH2 | PH | NCDOT |  |
| 13 | 1.2.4 | Identify Railroad Impacts |  | 20d | 2024-11-01 | 2024-12-06 | 3 | 315d | 235d | 1RR1 | RR | NCDOT |  |
| 14 | 1.2.5 | **Investigate Existing ITS & Signal Communications** |  | 150d | 2024-11-01 | 2025-06-19 |  | 205d |  | 1SG1 | SG |  |  |
| 15 | 1.2.5.1 | Initiate Signal System Fiber Owners and Contacts |  | 10d | 2024-11-01 | 2024-11-15 | 3 | 315d | 0d | 1SG1 | SG | PEF |  |
| 16 | 1.2.5.2 | Conduct Preliminary Signal System Investigation |  | 10d | 2024-11-01 | 2024-11-15 | 3 | 315d | 0d | 1SG1 | SG | PEF |  |
| 17 | 1.2.5.3 | Prepare & Submit Draft ITS Risk Analysis and Report |  | 10d | 2024-11-18 | 2024-12-06 | 15, 16 | 315d | 0d | 1SG1 | SG | PEF |  |
| 18 | 1.2.5.4 | Review of Draft ITS Risk Analysis and Report |  | 10d | 2024-12-09 | 2024-12-20 | 17 | 315d | 0d | 1SG1 | SG | NCDOT |  |
| 19 | 1.2.5.5 | Revise & Submit Final ITS Risk Analysis and Report |  | 5d | 2024-12-30 | 2025-01-06 | 18 | 315d | 0d | 1SG1 | SG | PEF |  |
| 20 | 1.2.5.6 | Review of Final ITS Risk Analysis and Report |  | 5d | 2025-01-07 | 2025-01-13 | 19 | 315d | 215d | 1SG1 | SG | NCDOT |  |
| 21 | 1.2.5.7 | Final ITS Risk Analysis and Report Approved | milestone | 0d | 2025-06-19 | 2025-06-19 | 41 | 155d | 0d | 1EN1 | EN | NCDOT |  |
| 22 | 1.2.6 | **Determine Affected Coordinated Corridors** |  | 10d | 2024-11-01 | 2024-11-15 |  | 370d |  | 1SS1 | SS |  |  |
| 23 | 1.2.6.1 | Complete List of Affected Signal Systems |  | 10d | 2024-11-01 | 2024-11-15 | 3 | 370d |  | 1SS1 | SS | NCDOT |  |
| 24 | 1.2.7 | **Scope Traffic System Operations** |  | 20d | 2024-11-01 | 2024-12-06 |  | 360d |  | 1TO1 | TO |  |  |
| 25 | 1.2.7.1 | Determine Impacted Intelligent Transportation System (ITS) Devices & Coordinating Corridors |  | 20d | 2024-11-01 | 2024-12-06 | 3 | 360d |  | 1TO1 | TO | NCDOT |  |

Notes:
- 13: Tied to Stage 2 Rail Activities
- 20: Tied to Stage 2 ITS Activities
- 23: Tied to Stage 2 Field Inspection Activities
- 25: Tied to Stage 2 Field Inspection Activities

| ID | WBS | Task | Type | Duration | Start | Finish | Predecessors | Total slack | Free slack | Task Code | Discipline Code | Responsible Party |
| --- | --- | --- | --- | --- | --- | --- | --- | --- | --- | --- | --- | --- |
| 26 | 1.2.8 | **Assess Safety Planning** |  | 20d | 2024-11-01 | 2024-12-06 |  | 340d |  | 1TS1 | TS |  |
| 27 | 1.2.8.1 | Conduct Traffic Safety Review |  | 20d | 2024-11-01 | 2024-12-06 | 3 | 340d | 235d | 1TS1 | TS | NCDOT |
| 28 | 1.2.9 | **Geotechnical, Replacement & GeoEnvironmental Planning** |  | 10d | 2024-11-01 | 2024-11-15 |  | 60d |  | 1GT1 | GT |  |
| 29 | 1.2.9.1 | Develop Geotechnical Planning Report |  | 10d | 2024-11-01 | 2024-11-15 | 3 | 60d | 50d | 1GT1 | GT | NCDOT |
| 30 | 1.2.9.2 | Develop GeoEnvironmental Scoping Comments Report |  | 10d | 2024-11-01 | 2024-11-15 | 3 | 60d | 50d | 1GT1 | GT | NCDOT |
| 31 | 1.2.10 | **Structures Screening** |  | 10d | 2024-11-01 | 2024-11-15 |  | 60d |  | 1ST1 | ST |  |
| 32 | 1.2.10.1 | Structures Cost Estimate for Express Design |  | 10d | 2024-11-01 | 2024-11-15 | 3 | 60d | 50d | 1ST1 | ST | NCDOT |
| 33 | 1.2.11 | **Review Project Scoping** |  | 15d | 2025-01-14 | 2025-02-04 |  | 225d |  | 1CG1 | CG |  |
| 34 | 1.2.11.1 | Submit ETRACS Request to Initiate Communications Support |  | 5d | 2025-01-14 | 2025-01-21 | 8 | 225d | 0d | 1CG1 | CG | PEF |
| 35 | 1.2.11.2 | Review of Communications Support Needs |  | 10d | 2025-01-22 | 2025-02-04 | 34 | 225d | 200d | 1CG1 | CG | NCDOT |
| 36 | 1.2.12 | **Establish Environmental Needs** |  | 115d | 2025-01-14 | 2025-06-26 |  | 155d |  | 1EN1 | EN |  |
| 37 | 1.2.12.1 | **Data Collection and Mapping** |  | 110d | 2025-01-14 | 2025-06-19 |  | 155d |  | 1EN1 | EN |  |
| 38 | 1.2.12.1.1 | Collect & Review Existing Data |  | 5d | 2025-01-14 | 2025-01-21 | 8 | 165d | 90d | 1EN1 | EN | PEF |
| 39 | 1.2.12.1.2 | Conduct Site Visit | milestone | 0d | 2025-05-29 | 2025-05-29 | 38, 265 | 155d | 0d | 1EN1 | EN | PEF |
| 40 | 1.2.12.1.3 | Update Environmental Features Map & Study Area |  | 10d | 2025-05-30 | 2025-06-12 | 39, 11 | 155d | 0d | 1EN1 | EN | PEF |
| 41 | 1.2.12.1.4 | Review of Updated Environmental Features Map & Study Area |  | 5d | 2025-06-13 | 2025-06-19 | 40 | 155d | 0d | 1EN1 | EN | NCDOT |
| 42 | 1.2.12.1.5 | Environmental Features Map & Study Area Approved | milestone | 0d | 2025-06-19 | 2025-06-19 | 41 | 155d | 0d | 1EN1 | EN | NCDOT |
| 43 | 1.2.12.2 | **Requests for Human & Environment Studies** |  | 5d | 2025-06-20 | 2025-06-26 |  | 155d |  | 1EN1 | EN |  |
| 44 | 1.2.12.2.1 | Prepare & Submit ETRACS Request for Historic Architecture |  | 5d | 2025-06-20 | 2025-06-26 | 42, 21 | 155d | 0d | 1EN1 | EN | PEF |
| 45 | 1.2.12.2.2 | Prepare & Submit ETRACS Request for Archaeology |  | 5d | 2025-06-20 | 2025-06-26 | 42, 21 | 155d | 0d | 1EN1 | EN | PEF |
| 46 | 1.2.12.3 | **Land Owner Notification Letters** |  | 20d | 2025-01-14 | 2025-02-11 |  | 220d |  | 1EN1 | EN |  |
| 47 | 1.2.12.3.1 | Prepare & Submit Land Owner Notification Letters |  | 10d | 2025-01-14 | 2025-01-28 | 8 | 220d | 0d | 1EN1 | EN | PEF |
| 48 | 1.2.12.3.2 | Review and Approve Land Owner Notification Letters |  | 10d | 2025-01-29 | 2025-02-11 | 47 | 220d | 0d | 1EN1 | EN | NCDOT |
| 49 | 1.2.12.3.3 | Send Out Land Owner Notification Letters | milestone | 0d | 2025-02-11 | 2025-02-11 | 48 | 220d | 0d | 1EN1 | EN | PEF |

Notes:
- 27: Tied to Signal Recommendations in Stage 2
- 35: Tied to Public Meeting Maps in Stage 2
- 44: Tied to Stage 2 Screenings
- 45: Tied to Stage 2 Screenings

| ID | WBS | Task | Type | Duration | Start | Finish | Predecessors | Total slack | Free slack | Task Code | Discipline Code | Responsible Party |
| --- | --- | --- | --- | --- | --- | --- | --- | --- | --- | --- | --- | --- |
| 50 | 1.2.13 | **Initiate NEPA/SEPA Review** |  | 20d | 2025-01-14 | 2025-02-11 |  | 30d |  | 1EP1 | EP |  |
| 51 | 1.2.13.1 | **Project Initiation and Merger Process** |  | 20d | 2025-01-14 | 2025-02-11 |  | 30d |  | 1EP1 | EP |  |
| 52 | 1.2.13.1.1 | Prepare Project Initiation Form |  | 10d | 2025-01-14 | 2025-01-28 | 8 | 30d | 0d | 1EP1 | EP | PEF |
| 53 | 1.2.13.1.2 | Prepare Start of Study E-mail List |  | 10d | 2025-01-14 | 2025-01-28 | 8 | 30d | 0d | 1EP1 | EP | PEF |
| 54 | 1.2.13.1.3 | Prepare Merger Pre-Screening Form |  | 10d | 2025-01-14 | 2025-01-28 | 8 | 30d | 0d | 1EP1 | EP | PEF |
| 55 | 1.2.13.1.4 | Review of Project Initiation Items |  | 10d | 2025-01-29 | 2025-02-11 | 53, 52, 54 | 30d | 0d | 1EP1 | EP | NCDOT |
| 56 | 1.2.13.1.5 | Approve Start of Study/Project Initiation Items | milestone | 0d | 2025-02-11 | 2025-02-11 | 55 | 30d | 0d | 1EP1 | EP | NCDOT |
| 57 | 1.2.13.1.6 | Send out Start of Study E-mail Package | milestone | 0d | 2025-02-11 | 2025-02-11 | 56 | 30d | 0d | 1EP1 | EP | PEF |
| 58 | 1.2.14 | **Complete Express Design** |  | 85d | 2025-02-12 | 2025-06-12 |  | 0d |  | 1FS1 | FS |  |
| 59 | 1.2.14.1 | **Roadway Typical Sections, Design Criteria, and Corridor Details** |  | 30d | 2025-02-12 | 2025-03-25 |  | 10d |  | 1FS1 | FS |  |
| 60 | 1.2.14.1.1 | Prepare & Submit Design Criteria Package |  | 10d | 2025-02-12 | 2025-02-25 | 30, 32, 10, 12, 11, 8, 29 | 10d | 0d | 1FS1 | FS | PEF |
| 61 | 1.2.14.1.2 | Review of Design Criteria Package |  | 10d | 2025-02-26 | 2025-03-11 | 60 | 10d | 0d | 1FS1 | FS | NCDOT |
| 62 | 1.2.14.1.3 | Prepare & Resubmit Design Criteria Package |  | 5d | 2025-03-12 | 2025-03-18 | 61 | 10d | 0d | 1FS1 | FS | PEF |
| 63 | 1.2.14.1.4 | Review of Revised Design Criteria Package |  | 5d | 2025-03-19 | 2025-03-25 | 62 | 10d | 0d | 1FS1 | FS | NCDOT |
| 64 | 1.2.14.1.5 | Design Criteria Package Approved | milestone | 0d | 2025-03-25 | 2025-03-25 | 63 | 10d | 0d | 1FS1 | FS | NCDOT |
| 65 | 1.2.14.2 | **Express Design** |  | 55d | 2025-03-26 | 2025-06-12 |  | 0d |  | 1FS1 | FS |  |
| 66 | 1.2.14.2.1 | Prepare & Submit Draft Express Design |  | 20d | 2025-03-26 | 2025-04-23 | 64 | 10d | 0d | 1FS1 | FS | PEF |
| 67 | 1.2.14.2.2 | Review of Draft Express Design |  | 10d | 2025-04-24 | 2025-05-07 | 66 | 10d | 0d | 1FS1 | FS | NCDOT |
| 68 | 1.2.14.2.3 | Prepare & Submit Final Express Design |  | 10d | 2025-05-22 | 2025-06-05 | 67, 85 | 0d |  | 1FS1 | FS | PEF |
| 69 | 1.2.14.2.4 | Review of Final Express Design |  | 5d | 2025-06-06 | 2025-06-12 | 68 | 0d |  | 1FS1 | FS | NCDOT |
| 70 | 1.2.14.2.5 | Express Design Approved | milestone | 0d | 2025-06-12 | 2025-06-12 | 69 | 0d |  | 1FS1 | FS | NCDOT |
| 71 | 1.2.15 | **Complete Express Design Traffic Volume** |  | 40d | 2025-01-14 | 2025-03-11 |  | 0d |  | 1TP1 | TP |  |
| 72 | 1.2.15.1 | Prepare & Submit Interim Review Information |  | 10d | 2025-01-14 | 2025-01-28 | 8 | 0d |  | 1TP1 | TP | PEF |
| 73 | 1.2.15.2 | Prepare & Submit Draft Traffic Forecast |  | 10d | 2025-01-29 | 2025-02-11 | 72 | 0d |  | 1TP1 | TP | PEF |
| 74 | 1.2.15.3 | Review of Draft Traffic Forecast |  | 10d | 2025-02-12 | 2025-02-25 | 73 | 0d |  | 1TP1 | TP | NCDOT |
| 75 | 1.2.15.4 | Revise & Resubmit Traffic Forecast |  | 5d | 2025-02-26 | 2025-03-04 | 74 | 0d |  | 1TP1 | TP | PEF |
| 76 | 1.2.15.5 | Review of Revised Traffic Forecast |  | 5d | 2025-03-05 | 2025-03-11 | 75 | 0d |  | 1TP1 | TP | NCDOT |
| 77 | 1.2.15.6 | Traffic Forecast Approved | milestone | 0d | 2025-03-11 | 2025-03-11 | 76 | 0d |  | 1TP1 | TP | NCDOT |

Notes:
- 56: Tied to Start of CE
- 57: Tied to sending out complete streets request
- 68: Tied to the approval of the traffic analysis

| ID | WBS | Task | Type | Duration | Start | Finish | Predecessors | Total slack | Free slack | Task Code | Discipline Code | Responsible Party |
| --- | --- | --- | --- | --- | --- | --- | --- | --- | --- | --- | --- | --- |
| 78 | 1.2.16 | **Complete Express Design Traffic Analysis** |  | 50d | 2025-03-12 | 2025-05-21 |  | 0d |  | 1TM1 | TM |  |
| 79 | 1.2.16.1 | Prepare & Submit Interim Review Information |  | 10d | 2025-03-12 | 2025-03-25 | 77 | 0d |  | 1TM1 | TM | PEF |
| 80 | 1.2.16.2 | Review of Interim Information |  | 10d | 2025-03-26 | 2025-04-08 | 79 | 0d |  | 1TM1 | TM | NCDOT |
| 81 | 1.2.16.3 | Prepare & Submit Draft Traffic Operations Analysis |  | 10d | 2025-04-09 | 2025-04-23 | 80 | 0d |  | 1TM1 | TM | PEF |
| 82 | 1.2.16.4 | Review of Draft Traffic Operations Analysis |  | 10d | 2025-04-24 | 2025-05-07 | 81 | 0d |  | 1TM1 | TM | NCDOT |
| 83 | 1.2.16.5 | Revise & Resubmit Traffic Operations Analysis |  | 5d | 2025-05-08 | 2025-05-14 | 82 | 0d |  | 1TM1 | TM | PEF |
| 84 | 1.2.16.6 | Review of Revised Traffic Operations Analysis |  | 5d | 2025-05-15 | 2025-05-21 | 83 | 0d |  | 1TM1 | TM | NCDOT |
| 85 | 1.2.16.7 | Express Design Traffic Analysis Approved | milestone | 0d | 2025-05-21 | 2025-05-21 | 84 | 0d |  | 1TM1 | TM | NCDOT |
| 86 | 1.2.17 | **Initiate Complete Streets Review** |  | 50d | 2025-02-12 | 2025-04-23 |  | 30d |  | 1IM1 | IM |  |
| 87 | 1.2.17.1 | Prepare & Submit Complete Streets Project Sheet |  | 10d | 2025-02-12 | 2025-02-25 | 57 | 30d | 0d | 1IM1 | IM | PEF |
| 88 | 1.2.17.2 | Review of Complete Streets Project Sheet |  | 40d | 2025-02-26 | 2025-04-23 | 87 | 30d | 0d | 1IM1 | IM | NCDOT |
| 89 | 1.2.17.3 | Complete Streets Recommendations | milestone | 0d | 2025-04-23 | 2025-04-23 | 88 | 30d | 10d | 1IM1 | IM | NCDOT |
| 90 | 1.2.18 | **Initiate Public Engagement Tasks** |  | 30d | 2025-05-30 | 2025-07-11 |  | 20d |  | 1PI1 | PI |  |
| 91 | 1.2.18.1 | Prepare & Submit Draft Public Involvement Plan (PIP) |  | 10d | 2025-05-30 | 2025-06-12 | 265 | 20d | 0d | 1PI1 | PI | PEF |
| 92 | 1.2.18.2 | Review of Draft PIP |  | 10d | 2025-06-13 | 2025-06-26 | 91 | 20d | 0d | 1PI1 | PI | NCDOT |
| 93 | 1.2.18.3 | Revise & Submit Final PIP |  | 5d | 2025-06-27 | 2025-07-03 | 92 | 20d | 0d | 1PI1 | PI | PEF |
| 94 | 1.2.18.4 | Review of Final PIP |  | 5d | 2025-07-07 | 2025-07-11 | 93 | 20d | 0d | 1PI1 | PI | NCDOT |
| 95 | 1.2.18.5 | Final PIP Approved | milestone | 0d | 2025-07-11 | 2025-07-11 | 94 | 20d |  | 1PI1 | PI | NCDOT |
| 96 | 1.2.19 | **Prepare Conceptual Construction Cost Estimate** |  | 20d | 2025-06-13 | 2025-07-11 |  | 20d |  | 1CS1 | CS |  |
| 97 | 1.2.19.1 | Prepare Draft Quantities & Submit Estimate Request |  | 5d | 2025-06-13 | 2025-06-19 | 70 | 20d | 0d | 1CS1 | CS | PEF |
| 98 | 1.2.19.2 | Prepare Construction Cost Estimate |  | 10d | 2025-06-20 | 2025-07-03 | 97 | 20d | 0d | 1CS1 | CS | NCDOT |
| 99 | 1.2.19.3 | Request Cost Verification Letter | milestone | 0d | 2025-07-03 | 2025-07-03 | 98 | 20d | 0d | 1CS1 | CS | NCDOT |
| 100 | 1.2.19.4 | Prepare Cost Verification Letter |  | 5d | 2025-07-07 | 2025-07-11 | 99 | 20d | 0d | 1CS1 | CS | NCDOT |
| 101 | 1.2.19.5 | Issue Cost Verification Letter | milestone | 0d | 2025-07-11 | 2025-07-11 | 100 | 20d |  | 1CS1 | CS | NCDOT |
| 102 | 1.2.20 | Prepare Conceptual ROW Cost Estimate |  | 10d | 2025-06-13 | 2025-06-26 | 70 | 30d |  | 1RW1 | RW | NCDOT |
| 103 | 1.2.21 | Develop Initial Utility Relocation and Utility Construction Estimates |  | 10d | 2025-06-13 | 2025-06-26 | 70 | 0d |  | 1UT1 | UT | UTILITY PEF |

Notes:
- 85: Tie to final express design
- 95: Tied to Public Meeting Maps
- 101: Tied to Start of CE
- 102: Tied to Start of CE

| ID | WBS | Task | Type | Duration | Start | Finish | Predecessors | Total slack | Free slack | Task Code | Discipline Code | Responsible Party |
| --- | --- | --- | --- | --- | --- | --- | --- | --- | --- | --- | --- | --- |
| 104 | 1.2.22 | **Investigate Existing Utilities** |  | 30d | 2025-06-27 | 2025-08-08 |  | 0d |  | 1UT2 | UT |  |
| 105 | 1.2.22.1 | Prepare & Submit Draft Critical Utilities Strategy |  | 10d | 2025-06-27 | 2025-07-11 | 103 | 0d |  | 1UT2 | UT | UTILITY PEF |
| 106 | 1.2.22.2 | Review of Draft Critical Utilities Strategy |  | 10d | 2025-07-14 | 2025-07-25 | 105 | 0d |  | 1UT2 | UT | NCDOT |
| 107 | 1.2.22.3 | Revise & Submit Final Critical Utilities Strategy |  | 5d | 2025-07-28 | 2025-08-01 | 106 | 0d |  | 1UT2 | UT | UTILITY PEF |
| 108 | 1.2.22.4 | Review of Final Critical Utilities Strategy |  | 5d | 2025-08-04 | 2025-08-08 | 107 | 0d |  | 1UT2 | UT | NCDOT |
| 109 | 1.2.22.5 | Final Critical Utilities Strategy Approved | milestone | 0d | 2025-08-08 | 2025-08-08 | 108 | 0d |  | 1UT2 | UT | NCDOT |
| 110 | 1.2.23 | Initiate Value Management Activities |  | 10d | 2025-06-13 | 2025-06-26 | 70 | 10d | 0d | 1VM1 | VM | NCDOT |
| 111 | 1.2.24 | **Complete Project Scoping Report** |  | 70d | 2025-06-13 | 2025-09-22 |  | 0d |  | 1FS2 | FS |  |
| 112 | 1.2.24.1 | **Project Scoping Level-Of-Detail Evaluation** |  | 30d | 2025-06-13 | 2025-07-25 |  | 10d |  | 1FS2 | FS |  |
| 113 | 1.2.24.1.1 | Prepare & Submit Project Scoping Report Level-of-Detail Screening Form |  | 10d | 2025-06-13 | 2025-06-26 | 70, 110FF | 10d | 0d | 1FS2 | FS | PEF |
| 114 | 1.2.24.1.2 | Review of Project Scoping Report Level-of-Detail Screening Form |  | 10d | 2025-06-27 | 2025-07-11 | 113 | 10d | 0d | 1FS2 | FS | NCDOT |
| 115 | 1.2.24.1.3 | Revise & Resubmit Project Scoping Report Level-of-Detail Screening Form |  | 5d | 2025-07-14 | 2025-07-18 | 114 | 10d | 0d | 1FS2 | FS | PEF |
| 116 | 1.2.24.1.4 | Review of Revised Project Scoping Report Level-of-Detail Screening Form |  | 5d | 2025-07-21 | 2025-07-25 | 115 | 10d | 0d | 1FS2 | FS | NCDOT |
| 117 | 1.2.24.1.5 | Project Scoping Report Tier Determination | milestone | 0d | 2025-07-25 | 2025-07-25 | 116 | 10d |  | 1FS2 | FS | NCDOT |
| 118 | 1.2.24.2 | **Project Scoping Report** |  | 30d | 2025-08-11 | 2025-09-22 |  | 0d |  | 1FS2 | FS |  |
| 119 | 1.2.24.2.1 | Prepare & Submit Project Scoping Report |  | 10d | 2025-08-11 | 2025-08-22 | 117, 95, 101, 102, 103, 109 | 0d |  | 1FS2 | FS | PEF |
| 120 | 1.2.24.2.2 | Review of Project Scoping Report |  | 10d | 2025-08-25 | 2025-09-08 | 119 | 0d |  | 1FS2 | FS | NCDOT |
| 121 | 1.2.24.2.3 | Revise & Resubmit Project Scoping Report |  | 5d | 2025-09-09 | 2025-09-15 | 120 | 0d |  | 1FS2 | FS | PEF |
| 122 | 1.2.24.2.4 | Review of Revised Project Scoping Report |  | 5d | 2025-09-16 | 2025-09-22 | 121 | 0d |  | 1FS2 | FS | NCDOT |
| 123 | 1.2.24.2.5 | Project Scoping Report Approved | milestone | 0d | 2025-09-22 | 2025-09-22 | 122 | 0d |  | 1FS2 | FS | NCDOT |
| 124 | 1.3 | **Scoping, Fee Estimate, and Notice to Proceed (Stage 2)** |  | 40d | 2025-06-13 | 2025-08-08 |  | 0d |  | SCOPE | SCOPE |  |
| 125 | 1.3.1 | Scope Development |  | 10d | 2025-06-13 | 2025-06-26 | 70 | 0d |  | SCOPE | SCOPE | PEF |
| 126 | 1.3.2 | Review/Approve Scope |  | 10d | 2025-06-27 | 2025-07-11 | 125 | 0d |  | SCOPE | SCOPE | NCDOT |
| 127 | 1.3.3 | Fee Estimate Development |  | 10d | 2025-07-14 | 2025-07-25 | 126 | 0d |  | SCOPE | SCOPE | PEF |
| 128 | 1.3.4 | Review/Approve Fee Estimate |  | 10d | 2025-07-28 | 2025-08-08 | 127 | 0d |  | SCOPE | SCOPE | NCDOT |
| 129 | 1.3.5 | Notice To Proceed (Stage 2) | milestone | 0d | 2025-08-08 | 2025-08-08 | 128 | 0d |  | SCOPE | SCOPE |  |

| ID | WBS | Task | Type | Duration | Start | Finish | Predecessors | Total slack | Free slack | Task Code | Discipline Code | Responsible Party |
| --- | --- | --- | --- | --- | --- | --- | --- | --- | --- | --- | --- | --- |
| 130 | 1.4 | **Environmental and ROW Plans (Stage 2)** |  | 510d | 2025-01-14 | 2027-02-15 |  | 95d |  |  |  |  |
| 131 | 1.4.1 | Complete Final Surveys |  | 80d | 2025-02-12 | 2025-06-05 | 10 | 75d |  | 2LS1 | LS | NCDOT |
| 132 | 1.4.2 | Complete Traffic Analysis |  | 20d | 2025-08-11 | 2025-09-08 | 85, 129 | 10d |  | 2TM1 | TM | PEF |
| 133 | 1.4.3 | **Initiate Utility Coordination and/or Design** |  | 35d | 2025-08-11 | 2025-09-29 |  | 50d |  | 2UT1 | UT |  |
| 134 | 1.4.3.1 | Initiate Utility Owner Contacts |  | 10d | 2025-08-11 | 2025-08-22 | 129 | 50d | 0d | 2UT1 | UT | UTILITY PEF |
| 135 | 1.4.3.2 | Conduct Preliminary Utility Investigations |  | 10d | 2025-08-11 | 2025-08-22 | 129 | 50d | 0d | 2UT1 | UT | UTILITY PEF |
| 136 | 1.4.3.3 | Prepare & Submit Utility Project Outline |  | 10d | 2025-08-25 | 2025-09-08 | 129, 134, 135 | 50d | 0d | 2UT1 | UT | UTILITY PEF |
| 137 | 1.4.3.4 | Review of Utility Project Outline |  | 10d | 2025-09-09 | 2025-09-22 | 136 | 50d | 0d | 2UT1 | UT | NCDOT |
| 138 | 1.4.3.5 | Prepare & Submit Construction Request |  | 5d | 2025-09-23 | 2025-09-29 | 137 | 50d | 35d | 2UT1 | UT | UTILITY PEF |
| 139 | 1.4.4 | **Develop Preliminary Hydraulic Recommendations** |  | 30d | 2025-08-11 | 2025-09-22 |  | 40d |  | 2HY1 | HY |  |
| 140 | 1.4.4.1 | Prepare & Submit Hydraulic Planning Report (HPR) |  | 10d | 2025-08-11 | 2025-08-22 | 129 | 40d | 0d | 2HY1 | HY | PEF |
| 141 | 1.4.4.2 | Review of HPR |  | 10d | 2025-08-25 | 2025-09-08 | 140 | 40d | 0d | 2HY1 | HY | NCDOT |
| 142 | 1.4.4.3 | Revise & Resubmit HPR |  | 5d | 2025-09-09 | 2025-09-15 | 141 | 40d | 0d | 2HY1 | HY | PEF |
| 143 | 1.4.4.4 | Review of Revised HPR |  | 5d | 2025-09-16 | 2025-09-22 | 142 | 40d | 0d | 2HY1 | HY | NCDOT |
| 144 | 1.4.4.5 | Hydraulic Planning Report Approved | milestone | 0d | 2025-09-22 | 2025-09-22 | 143 | 40d |  | 2HY1 | HY | NCDOT |
| 145 | 1.4.5 | **Complete Design Recommendation Plan Set** |  | 40d | 2025-09-23 | 2025-11-18 |  | 0d |  | 2RD2 | RD |  |
| 146 | 1.4.5.1 | Prepare & Submit Design Recommendation Plan Set |  | 20d | 2025-09-23 | 2025-10-20 | 131, 129, 89, 123, 132, 272FF | 0d |  | 2RD2 | RD | PEF |
| 147 | 1.4.5.2 | Prepare Initial Design Estimates |  | 20d | 2025-09-23 | 2025-10-20 | 146FF | 0d |  | 2CS1 | CS | PEF |
| 148 | 1.4.5.3 | Review of Design Recommendation Plan Set |  | 10d | 2025-10-21 | 2025-11-03 | 146, 147 | 0d |  | 2RD2 | RD | NCDOT |
| 149 | 1.4.5.4 | Revise & Resubmit Design Recommendation Plan Set |  | 5d | 2025-11-04 | 2025-11-10 | 148 | 0d |  | 2RD2 | RD | PEF |
| 150 | 1.4.5.5 | Review of Revised Design Recommendation Plan Set |  | 5d | 2025-11-12 | 2025-11-18 | 149 | 0d |  | 2RD2 | RD | NCDOT |
| 151 | 1.4.5.6 | Design Recommendation Plan Set Approved | milestone | 0d | 2025-11-18 | 2025-11-18 | 150 | 0d |  | 2RD2 | RD | NCDOT |
| 152 | 1.4.6 | Prepare Utility Relocation and Construction Estimates |  | 10d | 2025-11-19 | 2025-12-09 | 138, 151 | 15d | 10d | 2UT2 | UT | UTILITY PEF |
| 153 | 1.4.7 | Prepare ROW Cost Estimate |  | 10d | 2026-02-06 | 2026-02-19 | 151, 342SS-140d | 770d |  | 2RW2 | RW | ROW PEF |

Notes:
- 132: Complete this before DRPS
- 147: Estimate needed 7 months prior to ROW Fund Request
- 152: Estimate needed 7 months prior to ROW Fund Request
- 153: Estimate needed 7 months prior to ROW Fund Request

| ID | WBS | Task | Type | Duration | Start | Finish | Predecessors | Total slack | Free slack | Task Code | Discipline Code | Responsible Party |
| --- | --- | --- | --- | --- | --- | --- | --- | --- | --- | --- | --- | --- |
| 154 | 1.4.8 | **Coordinate Railroad Review** |  | 45d | 2025-11-19 | 2026-02-05 |  | 80d |  | 2RR1 | RR |  |
| 155 | 1.4.8.1 | Prepare & Submit Railroad Design Line and Grade |  | 10d | 2025-11-19 | 2025-12-09 | 151, 13 | 80d | 0d | 2RR1 | RR | PEF |
| 156 | 1.4.8.2 | Review of Railroad Line and Grade |  | 10d | 2025-12-10 | 2025-12-30 | 155 | 90d | 10d | 2RR1 | RR | NCDOT |
| 157 | 1.4.8.3 | Rail Review of Railroad Line and Grade |  | 20d | 2025-12-10 | 2026-01-14 | 155 | 80d | 0d | 2RR1 | RR | RAILROAD |
| 158 | 1.4.8.4 | Revise & Resubmit Railroad Line and Grade |  | 10d | 2026-01-15 | 2026-01-29 | 157, 156 | 80d | 0d | 2RR1 | RR | PEF |
| 159 | 1.4.8.5 | Review of Revised Railroad Line and Grade |  | 5d | 2026-01-30 | 2026-02-05 | 158 | 80d | 0d | 2RR1 | RR | NCDOT |
| 160 | 1.4.8.6 | Railroad Line and Grade Approved | milestone | 0d | 2026-02-05 | 2026-02-05 | 159 | 80d |  | 2RR1 | RR | NCDOT |
| 161 | 1.4.9 | **Complete Drainage Design** |  | 110d | 2025-11-19 | 2026-05-08 |  | 0d |  | 2HY2 | HY |  |
| 162 | 1.4.9.1 | Prepare & Submit Hydraulic Designs & BSR |  | 20d | 2025-11-19 | 2025-12-30 | 151, 144 | 0d |  | 2HY2 | HY | PEF |
| 163 | 1.4.9.2 | Review of Hydraulic Designs & BSR |  | 10d | 2025-12-31 | 2026-01-14 | 162 | 0d |  | 2HY2 | HY | NCDOT |
| 164 | 1.4.9.3 | Revise & Resubmit Hydraulic Designs & BSR |  | 10d | 2026-01-15 | 2026-01-29 | 163 | 0d |  | 2HY2 | HY | PEF |
| 165 | 1.4.9.4 | Review of Revised Hydraulic Designs & BSR |  | 5d | 2026-01-30 | 2026-02-05 | 164 | 0d |  | 2HY2 | HY | NCDOT |
| 166 | 1.4.9.5 | Hydraulic Designs & BSR Approved | milestone | 0d | 2026-02-05 | 2026-02-05 | 165 | 0d |  | 2HY2 | HY | NCDOT |
| 167 | 1.4.9.6 | State Floodplain Compliance (SFC) Package |  | 5d | 2026-02-06 | 2026-02-12 | 166 | 645d | 0d | 2HY2 | HY | PEF |
| 168 | 1.4.9.7 | NC SFC Review & Approval |  | 60d | 2026-02-13 | 2026-05-08 | 167 | 645d | 605d | 2HY2 | HY | AGENCY |
| 169 | 1.4.10 | Establish Signal & ITS Locations |  | 20d | 2025-11-19 | 2025-12-30 | 151, 20 | 100d | 50d | 2SG1 | SG | PEF |
| 170 | 1.4.11 | **Advance Utility Coordination and/or Design** |  | 115d | 2025-12-31 | 2026-06-15 |  | 5d |  | 2UT3 | UT |  |
| 171 | 1.4.11.1 | Provide Plans to Utility Owners |  | 5d | 2025-12-31 | 2026-01-07 | 162, 152 | 5d | 0d | 2UT3 | UT | UTILITY PEF |
| 172 | 1.4.11.2 | Identify Major Utility Conflicts and Relocation Impacts |  | 5d | 2025-12-31 | 2026-01-07 | 162 | 5d | 0d | 2UT3 | UT | UTILITY PEF |
| 173 | 1.4.11.3 | Conduct Utility Coordination Meeting (All Utilities) | milestone | 0d | 2026-01-07 | 2026-01-07 | 172, 171 | 5d | 0d | 2UT3 | UT | UTILITY PEF |
| 174 | 1.4.11.4 | Initiate Cost Responsibility Analysis |  | 5d | 2026-01-08 | 2026-01-14 | 173 | 95d |  | 2UT3 | UT | UTILITY PEF |
| 175 | 1.4.11.5 | Utility Owners Develop Routing Plans |  | 40d | 2026-01-08 | 2026-03-05 | 173 | 50d | 0d | 2UT3 | UT | UTILITY OWNERS |
| 176 | 1.4.11.6 | Submit Routing Plan/Preliminary UBO Plans |  | 5d | 2026-03-06 | 2026-03-12 | 175, 169FF | 50d | 0d | 2UT3 | UT | UTILITY PEF |
| 177 | 1.4.11.7 | Create Relocation Schedule |  | 5d | 2026-03-13 | 2026-03-19 | 176 | 50d |  | 2UT3 | UT | UTILITY PEF |
| 178 | 1.4.11.8 | Submit Preliminary Utility Construction Routing Plans (30%) |  | 20d | 2026-01-08 | 2026-02-05 | 173 | 5d | 0d | 2UT3 | UT | UTILITY PEF |
| 179 | 1.4.11.9 | Review of 30% UC Plans |  | 10d | 2026-02-06 | 2026-02-19 | 178 | 5d | 0d | 2UT3 | UT | NCDOT |
| 180 | 1.4.11.10 | Request Subsurface Utility Engineering (SUE) Level A |  | 5d | 2026-02-20 | 2026-02-26 | 179 | 5d | 0d | 2UT3 | UT | UTILITY PEF |
| 181 | 1.4.11.11 | Complete SUE Level A |  | 40d | 2026-02-27 | 2026-04-24 | 180 | 5d | 0d | 2LS2 | LS | NCDOT |
| 182 | 1.4.11.12 | Submit Preliminary Utility Construction Plans (60%) |  | 20d | 2026-04-27 | 2026-05-22 | 179, 181 | 5d | 0d | 2UT3 | UT | UTILITY PEF |
| 183 | 1.4.11.13 | Review of 60% UC Plans |  | 10d | 2026-05-26 | 2026-06-08 | 182 | 5d | 0d | 2UT3 | UT | NCDOT |
| 184 | 1.4.11.14 | Request Geotechnical Investigation for Trenchless Construction |  | 5d | 2026-06-09 | 2026-06-15 | 183 | 40d | 30d | 2UT3 | UT | UTILITY PEF |
| 185 | 1.4.11.15 | Submit Required Utility Easements and Parcel List |  | 5d | 2026-06-09 | 2026-06-15 | 176, 183 | 40d | 30d | 2UT3 | UT | UTILITY PEF |
| 186 | 1.4.12 | Prepare Utility Relocation and Construction Estimates |  | 10d | 2026-06-09 | 2026-06-22 | 176, 183 | 5d |  | 2UT4 | UT | UTILITY PEF |

Notes:
- 169: Need initial signal location for UBO routing
- 177: Tied to FI Plans
- 184: Tied to ROW Plans
- 185: Tied to ROW Plans
- 186: Tied to Field Inspection

| ID | WBS | Task | Type | Duration | Start | Finish | Predecessors | Total slack | Free slack | Task Code | Discipline Code | Responsible Party |
| --- | --- | --- | --- | --- | --- | --- | --- | --- | --- | --- | --- | --- |
| 187 | 1.4.13 | **Begin Advanced Right of Way Tasks** |  | 100d | 2026-02-06 | 2026-06-29 |  | 0d |  | 2RW1 | RW |  |
| 188 | 1.4.13.1 | Prepare Advanced ROW Acquisition Cost Estimate |  | 10d | 2026-02-06 | 2026-02-19 | 166 | 0d |  | 2RW1 | RW | ROW PEF |
| 189 | 1.4.13.2 | Request Advanced ROW Acquisition Funds |  | 30d | 2026-02-20 | 2026-04-02 | 188 | 0d |  | 2RW1 | RW | NCDOT |
| 190 | 1.4.13.3 | Advanced ROW Acquisition Funds Released | milestone | 0d | 2026-04-02 | 2026-04-02 | 189 | 0d |  | 2RW1 | RW | NCDOT |
| 191 | 1.4.13.4 | ROW Advanced Acquisition Surveys |  | 20d | 2026-02-20 | 2026-03-19 | 188 | 10d |  | 2RW1 | RW | NCDOT |
| 192 | 1.4.13.5 | Advanced ROW Acquisition |  | 60d | 2026-04-06 | 2026-06-29 | 190, 191 | 0d |  | 2RW1 | RW | ROW PEF |
| 193 | 1.4.14 | **Develop Preliminary General Drawings** |  | 20d | 2026-02-06 | 2026-03-05 |  | 60d |  | 2ST2 | ST |  |
| 194 | 1.4.14.1 | Prepare & Submit PGDs |  | 10d | 2026-02-06 | 2026-02-19 | 166 | 60d | 0d | 2ST2 | ST | PEF |
| 195 | 1.4.14.2 | Review of PGDs |  | 10d | 2026-02-20 | 2026-03-05 | 194 | 60d | 10d | 2ST2 | ST | NCDOT |
| 196 | 1.4.15 | **Initiate Erosion and Sediment Control Plans** |  | 30d | 2026-02-06 | 2026-03-19 |  | 50d |  | 2RE1 | RE |  |
| 197 | 1.4.15.1 | Prepare & Submit E&SC Field Inspection Plans |  | 10d | 2026-02-06 | 2026-02-19 | 166 | 50d | 0d | 2RE1 | RE | PEF |
| 198 | 1.4.15.2 | Review of E&SC Field Inspection Plans |  | 10d | 2026-02-20 | 2026-03-05 | 197 | 50d | 0d | 2RE1 | RE | NCDOT |
| 199 | 1.4.15.3 | Revise & Resubmit E&SC Field Inspection Plans |  | 5d | 2026-03-06 | 2026-03-12 | 198 | 50d | 0d | 2RE1 | RE | PEF |
| 200 | 1.4.15.4 | Review of Revised E&SC Field Inspection Plans |  | 5d | 2026-03-13 | 2026-03-19 | 199 | 50d | 0d | 2RE1 | RE | NCDOT |
| 201 | 1.4.15.5 | E&SC Field Inspection Plans Approved | milestone | 0d | 2026-03-19 | 2026-03-19 | 200 | 50d | 0d | 2RE1 | RE | NCDOT |
| 202 | 1.4.16 | **Public Engagement** |  | 80d | 2025-11-19 | 2026-03-26 |  | 15d |  | 2PI1 | PI |  |
| 203 | 1.4.16.1 | **Public Meeting Map** |  | 30d | 2025-11-19 | 2026-01-14 |  | 25d |  | 2PI1 | PI |  |
| 204 | 1.4.16.1.1 | Develop Public Meeting Maps |  | 10d | 2025-11-19 | 2025-12-09 | 151, 95, 35, 272 | 25d | 0d | 2PI1 | PI | PEF |
| 205 | 1.4.16.1.2 | Review of Public Meeting Maps |  | 10d | 2025-12-10 | 2025-12-30 | 204 | 25d | 0d | 2PI1 | PI | NCDOT |
| 206 | 1.4.16.1.3 | Revise & Resubmit Public Meeting Maps |  | 5d | 2025-12-31 | 2026-01-07 | 205 | 25d | 0d | 2PI1 | PI | PEF |
| 207 | 1.4.16.1.4 | Review of Revised Public Meeting Maps |  | 5d | 2026-01-08 | 2026-01-14 | 206 | 25d | 0d | 2PI1 | PI | NCDOT |
| 208 | 1.4.16.1.5 | Public Meeting Maps Approved | milestone | 0d | 2026-01-14 | 2026-01-14 | 207 | 25d | 10d | 2PI1 | PI | NCDOT |
| 209 | 1.4.16.2 | **Postcard** |  | 50d | 2025-11-19 | 2026-02-12 |  | 745d |  | 2PI1 | PI |  |
| 210 | 1.4.16.2.1 | Develop Postcard |  | 5d | 2025-11-19 | 2025-12-02 | 151 | 800d | 0d | 2PI1 | PI | PEF |
| 211 | 1.4.16.2.2 | Review of Postcard |  | 10d | 2025-12-03 | 2025-12-16 | 210 | 800d | 0d | 2PI1 | PI | NCDOT |
| 212 | 1.4.16.2.3 | Revise & Resubmit Postcard |  | 5d | 2025-12-17 | 2025-12-30 | 211 | 800d | 0d | 2PI1 | PI | PEF |
| 213 | 1.4.16.2.4 | Review of Revised Postcard |  | 5d | 2025-12-31 | 2026-01-07 | 212 | 800d | 0d | 2PI1 | PI | NCDOT |
| 214 | 1.4.16.2.5 | Postcards Approved | milestone | 0d | 2026-01-07 | 2026-01-07 | 213 | 800d | 25d | 2PI1 | PI | NCDOT |
| 215 | 1.4.16.2.6 | Send Out Postcard | milestone | 0d | 2026-02-12 | 2026-02-12 | 214, 234SF | 745d |  | 2PI1 | PI | PEF |

Notes:
- 192: Tied to FI plans but may be able to go beyond field inspection

| ID | WBS | Task | Type | Duration | Start | Finish | Predecessors | Total slack | Free slack | Task Code | Discipline Code | Responsible Party |
| --- | --- | --- | --- | --- | --- | --- | --- | --- | --- | --- | --- | --- |
| 216 | 1.4.16.3 | **Visualization** |  | 40d | 2025-11-19 | 2026-01-29 |  | 15d |  | 2PI1 | PI |  |
| 217 | 1.4.16.3.1 | Prepare & Submit Draft VISSIM Model for Visualizations |  | 10d | 2025-11-19 | 2025-12-09 | 151 | 15d | 0d | 2PI1 | PI | PEF |
| 218 | 1.4.16.3.2 | NCDOT Review of Draft VISSIM Model for Visualizations |  | 10d | 2025-12-10 | 2025-12-30 | 217 | 15d | 0d | 2PI1 | PI | NCDOT |
| 219 | 1.4.16.3.3 | Prepare & Submit Final VISSIM Model for Visualizations |  | 5d | 2025-12-31 | 2026-01-07 | 218 | 15d | 0d | 2PI1 | PI | PEF |
| 220 | 1.4.16.3.4 | NCDOT Review of Final VISSIM Model for Visualizations |  | 5d | 2026-01-08 | 2026-01-14 | 219 | 15d | 0d | 2PI1 | PI | NCDOT |
| 221 | 1.4.16.3.5 | NCDOT Approves VISSIM Model for Visualizations | milestone | 0d | 2026-01-14 | 2026-01-14 | 220 | 15d | 0d | 2PI1 | PI | NCDOT |
| 222 | 1.4.16.3.6 | Develop Draft Visualization |  | 20d | 2025-11-19 | 2025-12-30 | 151 | 15d | 0d | 2PI1 | PI | PEF |
| 223 | 1.4.16.3.7 | Review of Draft Visualization |  | 10d | 2025-12-31 | 2026-01-14 | 222 | 15d | 0d | 2PI1 | PI | NCDOT |
| 224 | 1.4.16.3.8 | Revise & Submit Final Visualization |  | 5d | 2026-01-15 | 2026-01-22 | 223, 221 | 15d | 0d | 2PI1 | PI | PEF |
| 225 | 1.4.16.3.9 | Review of Final Visualization |  | 5d | 2026-01-23 | 2026-01-29 | 224 | 15d | 0d | 2PI1 | PI | NCDOT |
| 226 | 1.4.16.3.10 | Visualization Approved | milestone | 0d | 2026-01-29 | 2026-01-29 | 225 | 15d | 0d | 2PI1 | PI | NCDOT |
| 227 | 1.4.16.4 | **Website** |  | 50d | 2025-11-19 | 2026-02-12 |  | 15d |  | 2PI1 | PI |  |
| 228 | 1.4.16.4.1 | Develop Website Template |  | 10d | 2025-11-19 | 2025-12-09 | 151 | 25d | 0d | 2PI1 | PI | PEF |
| 229 | 1.4.16.4.2 | Review of Website Template |  | 10d | 2025-12-10 | 2025-12-30 | 228 | 25d | 0d | 2PI1 | PI | NCDOT |
| 230 | 1.4.16.4.3 | Revise & Resubmit Website Template |  | 5d | 2025-12-31 | 2026-01-07 | 229 | 25d | 0d | 2PI1 | PI | PEF |
| 231 | 1.4.16.4.4 | Review of Revised Website Template |  | 5d | 2026-01-08 | 2026-01-14 | 230 | 25d | 0d | 2PI1 | PI | NCDOT |
| 232 | 1.4.16.4.5 | Website Template Approved | milestone | 0d | 2026-01-14 | 2026-01-14 | 231 | 25d | 10d | 2PI1 | PI | NCDOT |
| 233 | 1.4.16.4.6 | Creation of Website |  | 10d | 2026-01-30 | 2026-02-12 | 232, 226, 208 | 15d | 0d | 2PI1 | PI | NCDOT |
| 234 | 1.4.16.4.7 | Website Goes Live | milestone | 0d | 2026-02-12 | 2026-02-12 | 233 | 15d | 0d | 2PI1 | PI | NCDOT |
| 235 | 1.4.16.5 | **Public Involvement Comment and Responses** |  | 30d | 2026-02-13 | 2026-03-26 |  | 15d |  | 2PI1 | PI |  |
| 236 | 1.4.16.5.1 | Gathering Public Comments |  | 20d | 2026-02-13 | 2026-03-12 | 234 | 15d | 0d | 2PI1 | PI | NCDOT |
| 237 | 1.4.16.5.2 | Response to Public Comments |  | 10d | 2026-03-13 | 2026-03-26 | 236 | 15d | 0d | 2PI1 | PI | PEF |
| 238 | 1.4.17 | Prepare GeoEnvironmental Phase I Report |  | 20d | 2025-08-11 | 2025-09-08 | 129 | 175d | 0d | 2GT1 | GT | NCDOT |
| 239 | 1.4.18 | Roadway Geotechnical & Geopavement Investigations |  | 40d | 2025-11-19 | 2026-01-29 | 151 | 85d |  | 2GT2 | GT | NCDOT |
| 240 | 1.4.19 | Geotechnical Structure Investigations |  | 40d | 2026-02-06 | 2026-04-02 | 166 | 40d | 0d | 2GT3 | GT | NCDOT |

Notes:
- 240: Includes Foundation Recs. Start after Hydro approval.

| ID | WBS | Task | Type | Duration | Start | Finish | Predecessors | Total slack | Free slack | Task Code | Discipline Code | Responsible Party |
| --- | --- | --- | --- | --- | --- | --- | --- | --- | --- | --- | --- | --- |
| 241 | 1.4.20 | **Complete Pavement Design** |  | 60d | 2025-11-19 | 2026-02-26 |  | 65d |  | 2PD1 | PD |  |
| 242 | 1.4.20.1 | Final Pavement Design Memo |  | 60d | 2025-11-19 | 2026-02-26 | 151 | 65d |  | 2PD1 | PD | NCDOT |
| 243 | 1.4.21 | **Complete Safety Analysis and Operational Review** |  | 20d | 2025-11-19 | 2025-12-30 |  | 105d |  | 2TS1 | TS |  |
| 244 | 1.4.21.1 | Traffic Signal Recommendations |  | 20d | 2025-11-19 | 2025-12-30 | 151, 27 | 105d |  | 2TS1 | TS | NCDOT |
| 245 | 1.4.22 | **Initiate Natural Resources Analysis** |  | 95d | 2025-01-14 | 2025-05-29 |  | 215d |  | 2EN1 | EN |  |
| 246 | 1.4.22.1 | **Complete NRTR and WEX File** |  | 40d | 2025-02-12 | 2025-04-08 |  | 215d |  | 2EN1 | EN |  |
| 247 | 1.4.22.1.1 | Conduct Wetland Delineations and Field Surveys |  | 10d | 2025-02-12 | 2025-02-25 | 49 | 220d | 0d | 2LS1 | LS | ENVIRONMENTAL PEF |
| 248 | 1.4.22.1.2 | Prepare & Submit Draft NRTR and PJD Package |  | 10d | 2025-02-26 | 2025-03-11 | 247 | 220d | 0d | 2EN1 | EN | ENVIRONMENTAL PEF |
| 249 | 1.4.22.1.3 | Review of Draft NRTR and PJD Package |  | 10d | 2025-03-12 | 2025-03-25 | 248 | 220d | 5d | 2EN1 | EN | NCDOT |
| 250 | 1.4.22.1.4 | Revise & Resubmit Final NRTR and PJD Package |  | 5d | 2025-04-02 | 2025-04-08 | 249, 260FF | 215d | 0d | 2EN1 | EN | ENVIRONMENTAL PEF |
| 251 | 1.4.22.2 | **Signed PJD** |  | 35d | 2025-04-09 | 2025-05-29 |  | 215d |  | 2EN1 | EN |  |
| 252 | 1.4.22.2.1 | Review PJD Package |  | 25d | 2025-04-09 | 2025-05-14 | 250 | 215d | 0d | 2EN1 | EN | AGENCY |
| 253 | 1.4.22.2.2 | Conduct Agency Field Review |  | 5d | 2025-05-15 | 2025-05-21 | 252 | 215d | 0d | 2EN1 | EN | AGENCY |
| 254 | 1.4.22.2.3 | Create WET File and Revise PJD Package (If Necessary) |  | 5d | 2025-05-22 | 2025-05-29 | 253 | 215d | 0d | 2EN1 | EN | ENVIRONMENTAL PEF |
| 255 | 1.4.22.2.4 | Sign PJD | milestone | 0d | 2025-05-29 | 2025-05-29 | 254 | 215d | 200d | 2EN1 | EN | AGENCY |
| 256 | 1.4.22.3 | **Threatened & Endangered (T&E) Species Survey** |  | 60d | 2025-01-14 | 2025-04-08 |  | 215d |  | 2EN1 | EN |  |
| 257 | 1.4.22.3.1 | T&E Survey and Submit Biological Assessment |  | 10d | 2025-01-14 | 2025-01-28 | 8 | 215d | 0d | 2EN1 | EN | ENVIRONMENTAL PEF |
| 258 | 1.4.22.3.2 | Initiate Section 7 Consultation |  | 20d | 2025-01-29 | 2025-02-25 | 257 | 215d | 0d | 2EN1 | EN | NCDOT |
| 259 | 1.4.22.3.3 | Review Biological Opinion/Commitments |  | 30d | 2025-02-26 | 2025-04-08 | 258 | 215d | 0d | 2EN1 | EN | AGENCY |
| 260 | 1.4.22.3.4 | Renders Biological Opinion/Commitments | milestone | 0d | 2025-04-08 | 2025-04-08 | 259 | 215d | 0d | 2EN1 | EN | AGENCY |
| 261 | 1.4.23 | **Initiate Human Environment Analysis** |  | 250d | 2025-05-08 | 2026-05-15 |  | 0d |  | 2EN2 | EN |  |
| 262 | 1.4.23.1 | **Complete Community Studies Report** |  | 40d | 2025-05-08 | 2025-07-03 |  | 20d |  | 2EN2 | EN |  |
| 263 | 1.4.23.1.1 | Delineate the Direct Community Impact Area (DCIA) and Demographic Study Area (DSA) Boundary |  | 5d | 2025-05-08 | 2025-05-14 | 89, 67 | 20d | 0d | 2EN2 | EN | PEF |
| 264 | 1.4.23.1.2 | Submit DCIA & DSA Boundary to Community Studies for Review & Approval |  | 5d | 2025-05-15 | 2025-05-21 | 263 | 20d | 0d | 2EN2 | EN | PEF |
| 265 | 1.4.23.1.3 | Compile Demographic information from Community Studies Demographic Tool |  | 5d | 2025-05-22 | 2025-05-29 | 264 | 20d | 0d | 2EN2 | EN | PEF |
| 266 | 1.4.23.1.4 | Community Studies Field Visit | milestone | 0d | 2025-05-29 | 2025-05-29 | 265, 38 | 75d | 0d | 2EN2 | EN | PEF |
| 267 | 1.4.23.1.5 | Prepare & Send Out Local Officials Input Forms |  | 10d | 2025-05-08 | 2025-05-21 | 89, 67 | 80d | 5d | 2EN2 | EN | PEF |
| 268 | 1.4.23.1.6 | Prepare & Submit Draft Community Impact Assessment (CIA) |  | 5d | 2025-05-30 | 2025-06-05 | 266, 267 | 75d | 0d | 2EN2 | EN | PEF |
| 269 | 1.4.23.1.7 | Review of Draft CIA |  | 10d | 2025-06-06 | 2025-06-19 | 268 | 75d | 0d | 2EN2 | EN | NCDOT |
| 270 | 1.4.23.1.8 | Revise & Submit Final CIA |  | 5d | 2025-06-20 | 2025-06-26 | 269 | 75d | 0d | 2EN2 | EN | PEF |
| 271 | 1.4.23.1.9 | Review of Final CIA |  | 5d | 2025-06-27 | 2025-07-03 | 270 | 75d | 0d | 2EN2 | EN | NCDOT |
| 272 | 1.4.23.1.10 | Approve Final CIA | milestone | 0d | 2025-07-03 | 2025-07-03 | 271 | 75d |  | 2EN2 | EN | NCDOT |

Notes:
- 255: Tied to Start of CE
- 257: Adjust Survey to the appropriate time of the year as needed
- 260: Tied to Start of CE
- 272: Complete CIA by draft DRPS Submission

| ID | WBS | Task | Type | Duration | Start | Finish | Predecessors | Total slack | Free slack | Task Code | Discipline Code | Responsible Party |
| --- | --- | --- | --- | --- | --- | --- | --- | --- | --- | --- | --- | --- |
| 273 | 1.4.23.2 | **Complete Cultural Resource Screenings** |  | 40d | 2025-06-27 | 2025-08-22 |  | 155d |  | 2EN2 | EN |  |
| 274 | 1.4.23.2.1 | Complete Historic Architecture and Landscapes No Survey Required Form |  | 40d | 2025-06-27 | 2025-08-22 | 44 | 155d | 140d | 2EN2 | EN | NCDOT |
| 275 | 1.4.23.2.2 | Complete No Archaeological Survey Required Form |  | 40d | 2025-06-27 | 2025-08-22 | 45 | 155d | 140d | 2EN2 | EN | NCDOT |
| 276 | 1.4.23.3 | **Identify Section 4(f) Resources** |  | 140d | 2025-08-11 | 2026-03-12 |  | 45d |  | 2EN2 | EN |  |
| 277 | 1.4.23.3.1 | Identify Section 4(f) Resource Ownership |  | 5d | 2025-08-11 | 2025-08-15 | 129 | 155d | 110d | 2EN2 | EN | PEF |
| 278 | 1.4.23.3.2 | Determine Impacts to Resource |  | 5d | 2026-02-06 | 2026-02-12 | 277, 166 | 45d | 0d | 2EN2 | EN | PEF |
| 279 | 1.4.23.3.3 | Sign de minimis Agreement |  | 20d | 2026-02-13 | 2026-03-12 | 278 | 45d |  | 2EN2 | EN | AGENCY |
| 280 | 1.4.23.4 | **Traffic Noise Report (TNR)** |  | 185d | 2025-08-11 | 2026-05-15 |  | 0d |  | 2EN2 | EN |  |
| 281 | 1.4.23.4.1 | Prepare & Submit Workplan |  | 20d | 2025-08-11 | 2025-09-08 | 129 | 0d |  | 2EN2 | EN | PEF |
| 282 | 1.4.23.4.2 | Review of Workplan |  | 20d | 2025-09-09 | 2025-10-06 | 281 | 0d |  | 2EN2 | EN | NCDOT |
| 283 | 1.4.23.4.3 | Revise & Resubmit Workplan |  | 10d | 2025-10-07 | 2025-10-20 | 282 | 0d |  | 2EN2 | EN | PEF |
| 284 | 1.4.23.4.4 | Review of Final Workplan |  | 10d | 2025-10-21 | 2025-11-03 | 283 | 0d |  | 2EN2 | EN | NCDOT |
| 285 | 1.4.23.4.5 | Field Data Collection & Base Modeling/Validation |  | 20d | 2025-11-04 | 2025-12-09 | 284 | 0d |  | 2EN2 | EN | PEF |
| 286 | 1.4.23.4.6 | Review of Validation |  | 10d | 2025-12-10 | 2025-12-30 | 285 | 0d |  | 2EN2 | EN | NCDOT |
| 287 | 1.4.23.4.7 | Revise & Resubmit Validation |  | 10d | 2025-12-31 | 2026-01-14 | 286 | 0d |  | 2EN2 | EN | PEF |
| 288 | 1.4.23.4.8 | Review of Final Validation |  | 10d | 2026-01-15 | 2026-01-29 | 287 | 0d |  | 2EN2 | EN | NCDOT |
| 289 | 1.4.23.4.9 | Future Year No-Build Modeling |  | 10d | 2026-01-30 | 2026-02-12 | 288 | 10d |  | 2EN2 | EN | PEF |
| 290 | 1.4.23.4.10 | Future Year Build Modeling |  | 20d | 2026-01-30 | 2026-02-26 | 151, 288 | 0d |  | 2EN2 | EN | PEF |
| 291 | 1.4.23.4.11 | Prepare & Submit Draft TNR |  | 15d | 2026-02-27 | 2026-03-19 | 290, 289 | 0d |  | 2EN2 | EN | PEF |
| 292 | 1.4.23.4.12 | Review of Draft TNR |  | 20d | 2026-03-20 | 2026-04-17 | 291 | 0d |  | 2EN2 | EN | NCDOT |
| 293 | 1.4.23.4.13 | Revise & Submit Final TNR |  | 10d | 2026-04-20 | 2026-05-01 | 292 | 0d |  | 2EN2 | EN | PEF |
| 294 | 1.4.23.4.14 | Review of Final TNR |  | 10d | 2026-05-04 | 2026-05-15 | 293 | 0d |  | 2EN2 | EN | NCDOT |
| 295 | 1.4.23.4.15 | Final TNR Approved | milestone | 0d | 2026-05-15 | 2026-05-15 | 294 | 0d |  | 2EN2 | EN | NCDOT |
| 296 | 1.4.24 | **Develop Noise Report or Addendum** |  | 90d | 2026-09-24 | 2027-02-15 |  | 350d |  | 2EN3 | EN |  |
| 297 | 1.4.24.1 | Future Year No-Build Modeling |  | 10d | 2026-09-24 | 2026-10-07 | 328 | 380d | 0d | 2EN3 | EN | PEF |
| 298 | 1.4.24.2 | Future Year Build Modeling |  | 10d | 2026-09-24 | 2026-10-07 | 328 | 380d | 0d | 2EN3 | EN | PEF |
| 299 | 1.4.24.3 | Prepare & Submit Draft DNR |  | 20d | 2026-10-08 | 2026-11-04 | 297, 298 | 380d | 0d | 2EN3 | EN | PEF |
| 300 | 1.4.24.4 | Review of Draft DNR |  | 20d | 2026-11-05 | 2026-12-10 | 299 | 380d | 0d | 2EN3 | EN | NCDOT |
| 301 | 1.4.24.5 | Revise & Resubmit Draft DNR |  | 10d | 2026-12-11 | 2026-12-31 | 300 | 380d | 0d | 2EN3 | EN | PEF |
| 302 | 1.4.24.6 | Review of Revised Draft DNR |  | 10d | 2027-01-04 | 2027-01-15 | 301 | 380d | 0d | 2EN3 | EN | NCDOT |
| 303 | 1.4.24.7 | Revise & Submit Final DNR |  | 10d | 2027-01-19 | 2027-02-01 | 302 | 380d | 0d | 2EN3 | EN | PEF |
| 304 | 1.4.24.8 | Review of Final DNR |  | 10d | 2027-02-02 | 2027-02-15 | 303 | 380d | 0d | 2EN3 | EN | NCDOT |
| 305 | 1.4.24.9 | Final DNR Approved | milestone | 0d | 2027-02-15 | 2027-02-15 | 304 | 380d | 0d | 2EN3 | EN | NCDOT |

Notes:
- 274: Tied to Request in Stage 1
- 275: Tied to Request in Stage 1
- 278: Based off of Hydro/BSR Approval

| ID | WBS | Task | Type | Duration | Start | Finish | Predecessors | Total slack | Free slack | Task Code | Discipline Code | Responsible Party |
| --- | --- | --- | --- | --- | --- | --- | --- | --- | --- | --- | --- | --- |
| 306 | 1.4.25 | **Advance NEPA/SEPA Documentation** |  | 45d | 2026-03-27 | 2026-06-01 |  | 0d |  | 2EP1 | EP |  |
| 307 | 1.4.25.1 | Prepare & Submit Draft Categorical Exclusion (CE) |  | 10d | 2026-03-27 | 2026-04-10 | 274, 275, 237, 151, 101, 102, 255, 56 | 15d | 0d | 2EP1 | EP | PEF |
| 308 | 1.4.25.2 | Review of Draft CE |  | 10d | 2026-04-13 | 2026-04-24 | 307 | 15d |  | 2EP1 | EP | NCDOT |
| 309 | 1.4.25.3 | Revise & Submit Final CE |  | 5d | 2026-05-18 | 2026-05-22 | 308, 295, 279 | 0d |  | 2EP1 | EP | PEF |
| 310 | 1.4.25.4 | Review of Final CE |  | 5d | 2026-05-26 | 2026-06-01 | 309 | 0d |  | 2EP1 | EP | NCDOT |
| 311 | 1.4.25.5 | Environmental Document Approved | milestone | 0d | 2026-06-01 | 2026-06-01 | 310 | 0d |  | 2EP1 | EP | NCDOT |
| 312 | 1.4.26 | **Initiate Transportation Management Plan** |  | 20d | 2026-05-04 | 2026-06-02 |  | 340d |  | 2TM2 | TM |  |
| 313 | 1.4.26.1 | Complete Concept Temporary Traffic Control (TTC) Plans |  | 20d | 2026-05-04 | 2026-06-02 | 319SF, 320SF, 151 | 340d | 0d | 2TM2 | TM | PEF |
| 314 | 1.4.27 | **Initiate Signing and Delineation Design** |  | 20d | 2026-05-04 | 2026-06-02 |  | 670d |  | SD | SD |  |
| 315 | 1.4.27.1 | Prepare Preliminary Signing and Delineation Strip Map |  | 20d | 2026-05-04 | 2026-06-02 | 319SF, 320SF, 151 | 670d |  | 2SD1 | SD | PEF |
| 316 | 1.4.28 | Complete Value Management Activities |  | 60d | 2025-08-11 | 2025-11-03 | 129 | 135d |  | 2VM1 | VM | NCDOT |
| 317 | 1.4.29 | Initiate Signal System Timing |  | 20d | 2026-06-02 | 2026-06-29 | 313 | 640d | 430d | 2SS1 | SS | PEF |
| 318 | 1.4.30 | **Prepare for Field Inspection** |  | 40d | 2026-06-02 | 2026-07-28 |  | 0d |  | 2RD3 | RD |  |
| 319 | 1.4.30.1 | Prepare Field Construction Estimate |  | 20d | 2026-06-02 | 2026-06-29 | 316, 195, 239, 240, 242, 166, 311, 174, 201, 238, 160, 23, 25, 177, 192FF, 244 | 0d |  | 2CS2 | CS | PEF |
| 320 | 1.4.30.2 | Prepare Field Inspection Plans Set |  | 20d | 2026-06-02 | 2026-06-29 | 195, 316, 244, 239, 240, 242, 166, 311, 192FF, 177, 201, 238, 160, 23, 25, 186FF | 0d |  | 2RD3 | RD | PEF |
| 321 | 1.4.30.3 | Review of Field Inspection Plan Set |  | 20d | 2026-06-30 | 2026-07-28 | 319, 320 | 0d |  | 2RD3 | RD | NCDOT |
| 322 | 1.4.30.4 | Field Inspection | milestone | 0d | 2026-07-28 | 2026-07-28 | 321 | 0d |  | 2RD3 | RD | NCDOT |
| 323 | 1.4.31 | **ROW Plans Completed** |  | 40d | 2026-07-29 | 2026-09-23 |  | 0d |  | 2RD4 | RD |  |
| 324 | 1.4.31.1 | Complete & Submit ROW Plan Set |  | 20d | 2026-07-29 | 2026-08-25 | 336, 322, 338FF, 339FF, 184, 185 | 10d | 0d | 2RD4 | RD | PEF |
| 325 | 1.4.31.2 | Review of ROW Plan Set |  | 10d | 2026-08-26 | 2026-09-09 | 324 | 10d | 0d | 2RD4 | RD | NCDOT |
| 326 | 1.4.31.3 | Revise & Resubmit ROW Plan Set |  | 5d | 2026-09-10 | 2026-09-16 | 325 | 10d | 0d | 2RD4 | RD | PEF |
| 327 | 1.4.31.4 | Review of Revised ROW Plan Set |  | 5d | 2026-09-17 | 2026-09-23 | 326 | 10d | 0d | 2RD4 | RD | NCDOT |
| 328 | 1.4.31.5 | ROW Plans Complete (RPC) | milestone | 0d | 2026-09-23 | 2026-09-23 | 327 | 10d | 0d | 2RD4 | RD |  |
| 329 | 1.4.31.6 | Prepare ROW Cost Estimate |  | 10d | 2026-07-29 | 2026-08-11 | 322 | 0d |  | 2RW3 | RW | ROW PEF |
| 330 | 1.4.31.7 | Review of ROW Cost Estimate |  | 10d | 2026-08-12 | 2026-08-25 | 329 | 0d |  | 2RW3 | RW | NCDOT |

Notes:
- 309: Need Final TNR and 4(f) Signed de minimis Agreement for Final CE

| ID | WBS | Task | Type | Duration | Start | Finish | Predecessors | Total slack | Free slack | Task Code | Discipline Code | Responsible Party |
| --- | --- | --- | --- | --- | --- | --- | --- | --- | --- | --- | --- | --- |
| 331 | 1.5 | **Scoping, Fee Estimate, and Notice to Proceed (Stage 3 & 4)** |  | 40d | 2026-03-20 | 2026-05-15 |  | 60d |  | SCOPE | SCOPE |  |
| 332 | 1.5.1 | Scope Development |  | 10d | 2026-03-20 | 2026-04-02 | 166, 195, 201 | 60d | 0d | SCOPE | SCOPE | PEF |
| 333 | 1.5.2 | Review/Approve Scope |  | 10d | 2026-04-06 | 2026-04-17 | 332 | 60d | 0d | SCOPE | SCOPE | NCDOT |
| 334 | 1.5.3 | Fee Estimate Development |  | 10d | 2026-04-20 | 2026-05-01 | 333 | 60d | 0d | SCOPE | SCOPE | PEF |
| 335 | 1.5.4 | Review/Approve Fee Estimate |  | 10d | 2026-05-04 | 2026-05-15 | 334 | 60d | 0d | SCOPE | SCOPE | NCDOT |
| 336 | 1.5.5 | Notice To Proceed (Stage 3 & 4) | milestone | 0d | 2026-05-15 | 2026-05-15 | 335 | 60d | 50d | SCOPE | SCOPE |  |
| 337 | 1.6 | **Final Plans (Stage 3)** |  | 745d | 2025-09-09 | 2028-09-28 |  | 100d |  |  |  |  |
| 338 | 1.6.1 | Verify and Revise Pavement Design |  | 5d | 2026-07-29 | 2026-08-04 | 322, 242, 336 | 25d | 15d | 3PD1 | PD | PEF |
| 339 | 1.6.2 | Incorporate Value Management Activities |  | 5d | 2026-07-29 | 2026-08-04 | 316, 322, 336 | 25d | 15d | 3VM1 | VM | PEF |
| 340 | 1.6.3 | **Right of Way Funding** |  | 90d | 2026-06-02 | 2026-10-07 |  | 60d |  | 3RW1 | RW |  |
| 341 | 1.6.3.1 | Complete NEPA/SEPA Documentation |  | 10d | 2026-06-02 | 2026-06-15 | 342SS-60d | 690d |  | 3EP1 | EP | PEF |
| 342 | 1.6.3.2 | Complete ROW Authorization Package |  | 30d | 2026-08-26 | 2026-10-07 | 330, 311 | 0d |  | 3RW1 | RW | NCDOT |
| 343 | 1.6.3.3 | ROW Funds Released | milestone | 0d | 2026-10-07 | 2026-10-07 | 342 | 0d |  | 3RW1 | RW | NCDOT |
| 344 | 1.6.4 | Complete Additional Surveys and ROW Acquisition Surveys |  | 20d | 2026-09-24 | 2026-10-21 | 328 | 150d |  | 3LS1 | LS | NCDOT |
| 345 | 1.6.5 | **Complete ROW Acquisitions and Relocations** |  | 480d | 2026-10-08 | 2028-09-27 |  | 0d |  | 3RW2 | RW | ROW PEF |
| 346 | 1.6.5.1 | Phase 1 - ROW Acquisitions and Relocations (Utility/Priority Parcels) |  | 160d | 2026-10-08 | 2027-06-09 | 343, 344FF, 381, 328 | 0d |  | 3RW2 | RW | ROW PEF |
| 347 | 1.6.5.2 | Phase 2 - ROW Acquisitions and Relocations (Utility/Priority Parcels) |  | 160d | 2027-06-10 | 2028-02-10 | 346 | 0d |  | 3RW2 | RW | ROW PEF |
| 348 | 1.6.5.3 | Remaining ROW Acquisitions and Relocations |  | 160d | 2028-02-11 | 2028-09-27 | 347 | 40d | 0d | 3RW2 | RW | ROW PEF |
| 349 | 1.6.5.4 | ROW Certification | milestone | 0d | 2028-09-27 | 2028-09-27 | 348 | 40d | 0d | 3RW2 | RW | NCDOT |
| 350 | 1.6.6 | **Complete Roadway Design** |  | 40d | 2028-02-11 | 2028-04-06 |  | 200d |  | 3RD1 | RD |  |
| 351 | 1.6.6.1 | Complete & Submit Final Roadway Plan Set |  | 20d | 2028-02-11 | 2028-03-09 | 336, 328, 338, 339, 347, 402 | 230d | 0d | 3RD1 | RD | PEF |
| 352 | 1.6.6.2 | Review Final Roadway Plan Set |  | 10d | 2028-03-10 | 2028-03-23 | 351 | 230d | 0d | 3RD1 | RD | NCDOT |
| 353 | 1.6.6.3 | Revise & Resubmit Final Roadway Plan Set |  | 5d | 2028-03-24 | 2028-03-30 | 352 | 230d | 0d | 3RD1 | RD | PEF |
| 354 | 1.6.6.4 | Review Revised Final Roadway Plan Set |  | 5d | 2028-03-31 | 2028-04-06 | 353 | 230d | 0d | 3RD1 | RD | NCDOT |
| 355 | 1.6.6.5 | Final Roadway Plan Set Approved | milestone | 0d | 2028-04-06 | 2028-04-06 | 354 | 230d | 0d | 3RD1 | RD | NCDOT |

Notes:
- 341: 3 months prior to ROW Fund Request Complete ROW Consult. If needed
- 342: Includes Board Authorization of Funds, Match up with Board Dates
- 344: Concurrent with Start of ROW. Adjust as needed.
- 351: Tied to ROW Acquisition Phase 2 (adjust as needed)

| ID | WBS | Task | Type | Duration | Start | Finish | Predecessors | Total slack | Free slack | Task Code | Discipline Code | Responsible Party |
| --- | --- | --- | --- | --- | --- | --- | --- | --- | --- | --- | --- | --- |
| 356 | 1.6.7 | **Complete Utility Coordination and/or Design** |  | 135d | 2026-09-24 | 2027-04-20 |  | 195d |  | 3UT1 | UT |  |
| 357 | 1.6.7.1 | Prepare & Submit Utilities By Other (UBO) Plans |  | 20d | 2026-09-24 | 2026-10-21 | 328 | 195d | 0d | 3UT1 | UT | UTILITY PEF |
| 358 | 1.6.7.2 | Review of UBO Plans |  | 10d | 2026-10-22 | 2026-11-04 | 357 | 195d | 0d | 3UT1 | UT | NCDOT |
| 359 | 1.6.7.3 | Revise & Resubmit UBO Plans |  | 5d | 2026-11-05 | 2026-11-12 | 358 | 195d | 0d | 3UT1 | UT | UTILITY PEF |
| 360 | 1.6.7.4 | Review of Revised UBO Plans |  | 5d | 2026-11-13 | 2026-11-19 | 359 | 195d | 0d | 3UT1 | UT | NCDOT |
| 361 | 1.6.7.5 | UBO Plans Approved | milestone | 0d | 2026-11-19 | 2026-11-19 | 360 | 195d | 0d | 3UT1 | UT | NCDOT |
| 362 | 1.6.7.6 | Prepare & Submit Final Utility Construction (UC) Plans to NCDOT & Utility Owners |  | 40d | 2026-09-24 | 2026-11-19 | 328 | 195d | 0d | 3UT1 | UT | UTILITY PEF |
| 363 | 1.6.7.7 | Review of Final UC Plans |  | 20d | 2026-11-20 | 2026-12-31 | 362 | 395d | 0d | 3UT1 | UT | NCDOT / UO |
| 364 | 1.6.7.8 | Revise & Resubmit Final UC Plans to Utility Owners |  | 10d | 2027-01-04 | 2027-01-15 | 363 | 395d | 0d | 3UT1 | UT | UTILITY PEF |
| 365 | 1.6.7.9 | Utility Owners Review of Revised Final UC Plans |  | 10d | 2027-01-19 | 2027-02-01 | 364 | 395d | 0d | 3UT1 | UT | UTILITY OWNERS |
| 366 | 1.6.7.10 | Final UC Plans Approved | milestone | 0d | 2027-02-01 | 2027-02-01 | 365 | 395d | 0d | 3UT1 | UT | UTILITY OWNERS |
| 367 | 1.6.7.11 | Finalize Permit Applications (Prepare/Submit/Receive Signatures) |  | 5d | 2027-02-02 | 2027-02-08 | 366 | 395d | 0d | 3UT1 | UT | UTILITY PEF |
| 368 | 1.6.7.12 | Submit Final UC Plan Package to NCDEQ Water Supply Section for Review | milestone | 0d | 2027-02-08 | 2027-02-08 | 367 | 395d | 0d | 3UT1 | UT | UTILITY PEF |
| 369 | 1.6.7.13 | Review of Final UC Plan Package |  | 40d | 2027-02-09 | 2027-04-06 | 368 | 395d | 0d | 3UT1 | UT | AGENCY |
| 370 | 1.6.7.14 | Revise & Resubmit Final UC Plan Package to Utility Owners |  | 5d | 2027-04-07 | 2027-04-13 | 369 | 395d | 0d | 3UT1 | UT | UTILITY PEF |
| 371 | 1.6.7.15 | Review of Revised Final UC Plan Package |  | 5d | 2027-04-14 | 2027-04-20 | 370 | 395d | 0d | 3UT1 | UT | AGENCY |
| 372 | 1.6.7.16 | Issue Authorization to Construct | milestone | 0d | 2027-04-20 | 2027-04-20 | 371 | 395d | 355d | 3UT1 | UT | AGENCY |
| 373 | 1.6.8 | **Initiate Utility Relocations by Others** |  | 10d | 2026-11-20 | 2026-12-10 |  | 270d |  | 3UT2 | UT |  |
| 374 | 1.6.8.1 | Update the Utilities Relocation Schedule |  | 10d | 2026-11-20 | 2026-12-10 | 361 | 250d | 0d | 3UT2 | UT | UTILITY PEF |
| 375 | 1.6.8.2 | Hold Relocation Scheduling Conference | milestone | 0d | 2026-12-10 | 2026-12-10 | 374, 377 | 280d | 120d | 3UT2 | UT | NCDOT |
| 376 | 1.6.9 | **Prepare Final Utility Relocation and Construction Estimates** |  | 40d | 2026-11-20 | 2027-02-01 |  | 270d |  | 3UT3 | UT |  |
| 377 | 1.6.9.1 | Prepare Utility Relocation and Construction Estimates |  | 10d | 2026-11-20 | 2026-12-10 | 361 | 250d | 0d | 3UT3 | UT | UTILITY PEF |
| 378 | 1.6.9.2 | Utility Relocation Funding Request |  | 30d | 2026-12-11 | 2027-02-01 | 377, 374 | 250d | 0d | 3UT3 | UT | NCDOT |
| 379 | 1.6.9.3 | Utility Relocation Funds Released | milestone | 0d | 2027-02-01 | 2027-02-01 | 378 | 250d | 90d | 3UT3 | UT | NCDOT |

| ID | WBS | Task | Type | Duration | Start | Finish | Predecessors | Total slack | Free slack | Task Code | Discipline Code | Responsible Party |
| --- | --- | --- | --- | --- | --- | --- | --- | --- | --- | --- | --- | --- |
| 380 | 1.6.10 | **GeoEnvironmental and Subsurface Investigation** |  | 145d | 2025-09-09 | 2026-04-17 |  | 225d |  | 3GT | GT |  |
| 381 | 1.6.10.1 | Prepare GeoEnvironmental Phase II Report |  | 40d | 2025-09-09 | 2025-11-03 | 238 | 225d |  | 3GT1 | GT | NCDOT |
| 382 | 1.6.10.2 | Verify Geotechnical Deliverables |  | 10d | 2026-04-06 | 2026-04-17 | 240 | 580d | 0d | 3GT2 | GT | NCDOT |
| 383 | 1.6.11 | **Complete Erosion and Sediment Control Plans** |  | 30d | 2026-11-20 | 2027-01-15 |  | 195d |  | 3RE1 | RE |  |
| 384 | 1.6.11.1 | Prepare & Submit Erosion Control Plan Package |  | 10d | 2026-11-20 | 2026-12-10 | 328, 361, 362 | 195d | 0d | 3RE1 | RE | PEF |
| 385 | 1.6.11.2 | Review of Erosion Control Package |  | 10d | 2026-12-11 | 2026-12-31 | 384 | 195d | 0d | 3RE1 | RE | NCDOT |
| 386 | 1.6.11.3 | Revise & Resubmit Erosion Control Package |  | 5d | 2027-01-04 | 2027-01-08 | 385 | 195d | 0d | 3RE1 | RE | PEF |
| 387 | 1.6.11.4 | Approve Erosion Control Package |  | 5d | 2027-01-11 | 2027-01-15 | 386 | 195d | 0d | 3RE1 | RE | NCDOT |
| 388 | 1.6.11.5 | Erosion Control Package Approved | milestone | 0d | 2027-01-15 | 2027-01-15 | 387 | 195d | 0d | 3RE1 | RE | NCDOT |
| 389 | 1.6.12 | **Complete Hydraulic Permitting Tasks and Finalize Plans** |  | 30d | 2026-11-20 | 2027-01-15 |  | 195d |  | 3HY1 | HY |  |
| 390 | 1.6.12.1 | Prepare & Submit Permit Drawing Package |  | 10d | 2026-11-20 | 2026-12-10 | 328, 361, 362 | 195d | 0d | 3HY1 | HY | PEF |
| 391 | 1.6.12.2 | Review of Permit Drawing Package |  | 10d | 2026-12-11 | 2026-12-31 | 390 | 195d | 0d | 3HY1 | HY | NCDOT |
| 392 | 1.6.12.3 | Revise & Resubmit Permit Drawing Package |  | 5d | 2027-01-04 | 2027-01-08 | 391 | 195d | 0d | 3HY1 | HY | PEF |
| 393 | 1.6.12.4 | Approve Permit Drawing Package |  | 5d | 2027-01-11 | 2027-01-15 | 392 | 195d | 0d | 3HY1 | HY | NCDOT |
| 394 | 1.6.12.5 | Permit Drawing Package Approved | milestone | 0d | 2027-01-15 | 2027-01-15 | 393 | 195d | 0d | 3HY1 | HY | NCDOT |
| 395 | 1.6.13 | **Document Noise Abatement Decision** |  | 60d | 2027-02-16 | 2027-05-11 |  | 350d |  | 3EN1 | EN |  |
| 396 | 1.6.13.1 | Prepare & Submit Draft Balloting Figures |  | 10d | 2027-02-16 | 2027-03-01 | 305 | 380d | 0d | 3EN1 | EN | PEF |
| 397 | 1.6.13.2 | Review of Draft Balloting Figures |  | 10d | 2027-03-02 | 2027-03-15 | 396 | 380d | 0d | 3EN1 | EN | NCDOT |
| 398 | 1.6.13.3 | Revise & Resubmit Final Balloting Figures |  | 10d | 2027-03-16 | 2027-03-30 | 397 | 380d | 0d | 3EN1 | EN | PEF |
| 399 | 1.6.13.4 | Review of Final Balloting Figures |  | 10d | 2027-03-31 | 2027-04-13 | 398 | 380d | 0d | 3EN1 | EN | NCDOT |
| 400 | 1.6.13.5 | Final Balloting Figures Approved | milestone | 0d | 2027-04-13 | 2027-04-13 | 399 | 380d | 0d | 3EN1 | EN | NCDOT |
| 401 | 1.6.13.6 | Public Input from Final Balloting Figures |  | 20d | 2027-04-14 | 2027-05-11 | 400 | 380d | 0d | 3EN1 | EN | NCDOT |
| 402 | 1.6.13.7 | Final Noise Wall Determination | milestone | 0d | 2027-05-11 | 2027-05-11 | 401 | 380d | 180d | 3EN1 | EN | NCDOT |
| 403 | 1.6.14 | **Complete Permit Application Package** |  | 65d | 2027-01-19 | 2027-04-20 |  | 195d |  | 3EN2 | EN |  |
| 404 | 1.6.14.1 | Prepare & Submit Permit Application Package |  | 10d | 2027-01-19 | 2027-02-01 | 388, 394 | 195d | 0d | 3EN2 | EN | PEF |
| 405 | 1.6.14.2 | Review of Permit Application Package |  | 10d | 2027-02-02 | 2027-02-15 | 404 | 195d | 0d | 3EN2 | EN | NCDOT |
| 406 | 1.6.14.3 | Revise & Submit Permit Application Package |  | 5d | 2027-02-16 | 2027-02-22 | 405 | 195d | 0d | 3EN2 | EN | PEF |
| 407 | 1.6.14.4 | Review of Permit Application Package |  | 40d | 2027-02-23 | 2027-04-20 | 406 | 195d | 0d | 3EN2 | EN | AGENCY |

Notes:
- 381: Tie to ROW Acq. For Priority Parcel Identification

| ID | WBS | Task | Type | Duration | Start | Finish | Predecessors | Total slack | Free slack | Task Code | Discipline Code | Responsible Party |
| --- | --- | --- | --- | --- | --- | --- | --- | --- | --- | --- | --- | --- |
| 408 | 1.6.15 | **Complete Structures Design** |  | 140d | 2026-04-20 | 2026-11-04 |  | 550d |  | 3ST1 | ST |  |
| 409 | 1.6.15.1 | Prepare & Submit Final (Unsealed) Structure Plans |  | 120d | 2026-04-20 | 2026-10-07 | 195, 382 | 580d | 0d | 3ST1 | ST | PEF |
| 410 | 1.6.15.2 | Review of Final (Unsealed) Structure Plans |  | 20d | 2026-10-08 | 2026-11-04 | 409 | 580d | 440d | 3ST1 | ST | NCDOT |
| 411 | 1.6.16 | **Complete Signal & ITS Design** |  | 180d | 2028-01-13 | 2028-09-28 |  | 100d |  | 3SG1 | SG |  |
| 412 | 1.6.16.1 | Prepare & Submit 1st Signal Submittal (Temporary Poles and Geometrics) |  | 40d | 2028-01-13 | 2028-03-10 | 413SF | 240d | 0d | 3SG1 | SG | PEF |
| 413 | 1.6.16.2 | Review of 1st Submittal |  | 20d | 2028-03-10 | 2028-04-07 | 414SF | 240d | 0d | 3SG1 | SG | NCDOT |
| 414 | 1.6.16.3 | Revise & Submit 2nd Signal Submittal (Include Wiring) |  | 40d | 2028-04-07 | 2028-06-06 | 415SF, 317 | 180d | 0d | 3SG1 | SG | PEF |
| 415 | 1.6.16.4 | Review of 2nd Submittal |  | 20d | 2028-06-06 | 2028-07-05 | 416SF | 190d | 0d | 3SG1 | SG | NCDOT |
| 416 | 1.6.16.5 | Revise & Submit 3rd Signal Submittal (Final Plans) |  | 40d | 2028-07-05 | 2028-08-30 | 417SF | 150d | 0d | 3SG1 | SG | PEF |
| 417 | 1.6.16.6 | Review of 3rd Submittal |  | 20d | 2028-08-30 | 2028-09-28 | 418SF | 130d | 0d | 3SG1 | SG | NCDOT |
| 418 | 1.6.16.7 | Signal Plans Approved | milestone | 0d | 2028-09-28 | 2028-09-28 | 468SF, 481SF | 130d | 0d | 3SG1 | SG | NCDOT |
| 419 | 1.6.17 | **Complete Signing and Delineation Design** |  | 180d | 2028-01-13 | 2028-09-28 |  | 100d |  | 3SD1 | SD |  |
| 420 | 1.6.17.1 | Prepare 100% Unsealed Signing and Delineation Plans |  | 40d | 2028-01-13 | 2028-03-09 | 412SS | 240d | 0d | 3SD1 | SD | PEF |
| 421 | 1.6.17.2 | Review of 100% Unsealed Submittal |  | 10d | 2028-03-10 | 2028-03-23 | 420 | 240d | 110d | 3SD1 | SD | NCDOT |
| 422 | 1.6.17.3 | Prepare 100% Sealed Signing and Delineation Plans |  | 20d | 2028-08-30 | 2028-09-28 | 421, 468SF, 481SF | 100d |  | 3SD1 | SD | PEF |
| 423 | 1.6.18 | **Finalize Railroad Design & Agreements** |  | 435d | 2025-11-19 | 2027-09-02 |  | 340d |  | 3RR1 | RR |  |
| 424 | 1.6.18.1 | Prepare PE Agreement between NCDOT and Railroad |  | 10d | 2025-11-19 | 2025-12-09 | 151 | 425d | 0d | 3RR1 | RR | NCDOT |
| 425 | 1.6.18.2 | Review of PE Agreement |  | 60d | 2025-12-10 | 2026-03-12 | 424 | 425d | 0d | 3RR1 | RR | RAIL |
| 426 | 1.6.18.3 | PE Agreement between NCDOT and Railroad Signed | milestone | 0d | 2026-03-12 | 2026-03-12 | 425 | 425d | 55d | 3RR1 | RR | NCDOT |
| 427 | 1.6.18.4 | Hold Field Diagnostics Meeting with NCDOT and Railroad |  | 10d | 2026-06-02 | 2026-06-15 | 166, 313, 426 | 370d | 0d | 3RR1 | RR | PEF |
| 428 | 1.6.18.5 | Prepare & Submit Initial Planimetric for Railroad Signal and Gates |  | 20d | 2026-06-16 | 2026-07-14 | 427 | 370d | 0d | 3RR1 | RR | PEF |
| 429 | 1.6.18.6 | Review of Initial Planimetric for Railroad Signal and Gates |  | 20d | 2026-07-15 | 2026-08-11 | 428 | 370d | 0d | 3RR1 | RR | NCDOT |
| 430 | 1.6.18.7 | Prepare & Submit Final Planimetric for Railroad Signal and Gates |  | 10d | 2026-08-12 | 2026-08-25 | 429 | 370d | 0d | 3RR1 | RR | PEF |
| 431 | 1.6.18.8 | Review of Final Planimetric for Railroad Signal and Gates |  | 10d | 2026-08-26 | 2026-09-09 | 430 | 370d | 0d | 3RR1 | RR | NCDOT |
| 432 | 1.6.18.9 | Review of Planimetric to Include Material Procurement |  | 240d | 2026-09-10 | 2027-09-02 | 431 | 370d | 0d | 3RR1 | RR | RAIL |
| 433 | 1.6.18.10 | Planimetric and Material Procurement Complete | milestone | 0d | 2027-09-02 | 2027-09-02 | 432 | 370d | 355d | 3RR1 | RR | NCDOT |

Notes:
- 424: Assume DRPS needed to begin process, may be done earlier
- 427: Assume PE Agreement with Railroad, Hydro, and WZTC are needed.
- 432: Could take up to 12 months for Rail to procure gate materials
- 433: Assume procurement of materials complete by let

| ID | WBS | Task | Type | Duration | Start | Finish | Predecessors | Total slack | Free slack | Task Code | Discipline Code | Responsible Party |
| --- | --- | --- | --- | --- | --- | --- | --- | --- | --- | --- | --- | --- |
| 434 | 1.6.19 | **Complete Railroad Coordination** |  | 80d | 2026-09-24 | 2027-02-01 |  | 440d |  | 3RR2 | RR |  |
| 435 | 1.6.19.1 | Prepare & Submit Railroad Encroachment Agreement |  | 10d | 2026-09-24 | 2026-10-07 | 328 | 470d | 0d | 3RR2 | RR | PEF |
| 436 | 1.6.19.2 | Review of Railroad Encroachment Agreement |  | 10d | 2026-10-08 | 2026-10-21 | 435 | 470d | 0d | 3RR2 | RR | NCDOT |
| 437 | 1.6.19.3 | Review of Railroad Encroachment Agreement |  | 60d | 2026-10-22 | 2027-02-01 | 436 | 470d | 0d | 3RR2 | RR | RAIL |
| 438 | 1.6.19.4 | Railroad Encroachment Agreement Signed | milestone | 0d | 2027-02-01 | 2027-02-01 | 437 | 470d | 0d | 3RR2 | RR | NCDOT |
| 439 | 1.6.19.5 | Railroad Certification | milestone | 0d | 2027-02-01 | 2027-02-01 | 438 | 490d |  | 3RR2 | RR | NCDOT |
| 440 | 1.6.20 | Complete Transportation Management Plan |  | 20d | 2028-08-30 | 2028-09-28 | 468SF, 328, 481SF | 100d |  | 3TM1 | TM | PEF |
| 441 | 1.6.21 | Prepare Construction Estimate |  | 10d | 2028-04-07 | 2028-04-21 | 475SF-260d, 328, 366, 402, 355, 487SF-260d | 210d |  | 3CS1 | CS | PEF |
| 442 | 1.6.22 | 15 Month Let Review Meeting | milestone | 0d | 2027-12-07 | 2027-12-07 | 478FS-300d, 490FS-300d | 300d |  | 3PM2 | PM | NCDOT |
| 443 | 1.6.23 | **Design Complete Review Meeting** |  | 20d | 2028-04-07 | 2028-05-05 |  | 200d |  | 3PM3 | PM |  |
| 444 | 1.6.23.1 | Finalize Design Completion Review Meeting Materials |  | 10d | 2028-04-07 | 2028-04-21 | 355, 361, 366, 388, 394 | 230d | 0d | 3PM3 | PM | PEF |
| 445 | 1.6.23.2 | Prepare for Completion Review Meeting |  | 10d | 2028-04-24 | 2028-05-05 | 444 | 230d | 0d | 3PM3 | PM | NCDOT |
| 446 | 1.6.23.3 | Conduct Design Complete Review Meeting | milestone | 0d | 2028-05-05 | 2028-05-05 | 445 | 230d | 90d | 3PM3 | PM | NCDOT |
| 447 | 1.7 | **Plans, Specifications, and Estimates (PS&E)/Letting (Stage 4)** |  | 550d | 2026-11-20 | 2029-03-05 |  | 0d |  |  |  |  |
| 448 | 1.7.1 | Secure Permits | milestone | 0d | 2027-04-20 | 2027-04-20 | 407 | 195d | 35d | 4EN1 | EN | PEF |
| 449 | 1.7.2 | Complete NEPA/SEPA Documentation | milestone | 0d | 2028-10-19 | 2028-10-19 | 475FS-60d, 487FS-60d | 85d |  | 4EP1 | EP | NCDOT |
| 450 | 1.7.3 | **Utility Relocation** |  | 530d | 2026-11-20 | 2029-02-05 |  | 20d |  | 4UT | UT |  |
| 451 | 1.7.3.1 | Finalize Utility Coordination and/or Utility Design PS&E |  | 20d | 2026-11-20 | 2026-12-31 | 361 | 270d | 110d | 4UT1 | UT | UTILITY PEF |
| 452 | 1.7.3.2 | Utility Certification | milestone | 0d | 2026-12-31 | 2026-12-31 | 451 | 480d | 470d | 4UT1 | UT | NCDOT |
| 453 | 1.7.3.3 | Complete Utility Relocation by Owner [Phase 1] |  | 240d | 2027-06-10 | 2028-06-05 | 451, 448, 379, 346, 375 | 180d | 170d | 4UT2 | UT | UTILITY OWNERS |
| 454 | 1.7.3.4 | Complete Utility Relocation by Owner [Phase 2] [Tentative Beyond Let] |  | 240d | 2028-02-11 | 2029-02-05 | 448, 347 | 0d |  | 4UT2 | UT | UTILITY OWNERS |
| 455 | 1.7.4 | **Finalize Structures Design PS&E** |  | 20d | 2028-08-30 | 2028-09-28 |  | 100d |  | 4ST1 | ST |  |
| 456 | 1.7.4.1 | Submit Final (Sealed) Structure Plans |  | 10d | 2028-08-30 | 2028-09-14 | 457SF, 410 | 110d |  | 4ST1 | ST | PEF |
| 457 | 1.7.4.2 | Review of Final (Sealed) Structure Plans |  | 10d | 2028-09-14 | 2028-09-28 | 458SF | 100d | 0d | 4ST1 | ST | NCDOT |
| 458 | 1.7.4.3 | Structure Plans Approved | milestone | 0d | 2028-09-28 | 2028-09-28 | 468SF, 481SF | 100d | 0d | 4ST1 | ST | NCDOT |
| 459 | 1.7.5 | Manage GeoEnvironmental Impacts |  | 20d | 2028-08-30 | 2028-09-28 | 468SF, 381, 481SF | 100d |  | 4GT1 | GT | NCDOT |
| 460 | 1.7.6 | Complete ROW Acquisition Surveys |  | 30d | 2028-09-28 | 2028-11-08 | 349 | 10d | 0d | 4LS1 | LS | NCDOT |
| 461 | 1.7.7 | Hydraulic Let Preparation |  | 20d | 2028-08-30 | 2028-09-28 | 468SF, 394, 481SF | 100d |  | 4HY1 | HY | PEF |
| 462 | 1.7.8 | Finalize Erosion & Sediment Control Contract Package |  | 20d | 2028-08-30 | 2028-09-28 | 468SF, 388, 481SF | 100d |  | 4RE1 | RE | PEF |
| 463 | 1.7.9 | Prepare Construction Communication Activities |  | 20d | 2028-08-30 | 2028-09-28 | 468SF, 481SF | 100d |  | 4CG1 | CG | NCDOT |
| 464 | 1.7.10 | Complete Value Management Activities |  | 20d | 2028-08-30 | 2028-09-28 | 468SF, 481SF | 100d |  | 4VM1 | VM | NCDOT |
| 465 | 1.7.11 | PS&E Review Meeting | milestone | 0d | 2028-09-14 | 2028-09-14 | 469FS-30d, 446, 482FS-30d | 110d |  | 4PM2 | PM | NCDOT |

Notes:
- 435: Tied to the ROW plans, but may be able to submit earlier
- 438: Assume complete by RPCP
- 441: Needs to be done 13 months prior to funding.
- 442: 15 Month Pre-Let Review Meeting
- 446: Tie to 4PM2, Allow time for changes to plans as needed
- 449: Construction Consultation 3 months prior to project authorization
- 454: Assume Phase 2 by let, but could go beyond as needed
- 465: 6 Weeks prior to PS&E Turn In (RPCP)

| ID | WBS | Task | Type | Duration | Start | Finish | Predecessors | Total slack | Free slack | Task Code | Discipline Code | Responsible Party | SAP MLSN |
| --- | --- | --- | --- | --- | --- | --- | --- | --- | --- | --- | --- | --- | --- |
| 466 | 1.7.12 | **Central Let Activities** |  | 100d | 2028-09-28 | 2029-03-05 |  | 0d |  |  |  |  |  |
| 467 | 1.7.12.1 | **Finalize the PS&E Package** |  | 55d | 2028-09-28 | 2028-12-21 |  | 10d |  | 4RD1 | RD |  |  |
| 468 | 1.7.12.1.1 | Submit 100% Unsealed Plans, Quantities, and Special Provisions |  | 20d | 2028-09-28 | 2028-10-25 | 448, 402, 372, 349 | 10d | 0d | 4RD1 | RD | PEF |  |
| 469 | 1.7.12.1.2 | Roadway Plans to Contracts & Proposals (RPCP) | milestone | 0d | 2028-10-25 | 2028-10-25 | 468, 168, 438 | 10d | 0d | 4RD1 | RD | PEF | MLSN |
| 470 | 1.7.12.1.3 | Review of 100% Unsealed Plans, Quantities and Special Provisions |  | 20d | 2028-10-26 | 2028-11-30 | 469 | 10d | 0d | 4RD1 | RD | NCDOT |  |
| 471 | 1.7.12.1.4 | Revise & Resubmit 100% Unsealed Plans, Quantities and Special Provisions |  | 10d | 2028-12-01 | 2028-12-14 | 460FF, 470 | 10d | 0d | 4RD1 | RD | PEF |  |
| 472 | 1.7.12.1.5 | Review of Revised 100% Unsealed Plans, Quantities and Special Provisions |  | 5d | 2028-12-15 | 2028-12-21 | 471 | 10d | 0d | 4RD1 | RD | NCDOT |  |
| 473 | 1.7.12.1.6 | Submit 100% Sealed Plans, Quantities, and Special Provisions | milestone | 0d | 2028-12-21 | 2028-12-21 | 472 | 10d | 0d | 4RD1 | RD | PEF | MLSN |
| 474 | 1.7.12.2 | **Complete PS&E Package and Advertise the Project** |  | 45d | 2028-12-22 | 2029-03-05 |  | 0d |  | 4CS1 | CS |  |  |
| 475 | 1.7.12.2.1 | Construction Funding Request and Project Authorization |  | 15d | 2028-12-22 | 2029-01-22 | 473, 349, 311, 439, 452 | 10d | 5d | 4CS1 | CS | NCDOT |  |
| 476 | 1.7.12.2.2 | Advertise Project | milestone | 0d | 2029-02-05 | 2029-02-05 | 475, 433FF, 454FF | 0d |  | 4CS1 | CS | NCDOT | MLSN |
| 477 | 1.7.12.2.3 | Project Advertisement |  | 20d | 2029-02-06 | 2029-03-05 | 476 | 0d |  | 4CS1 | CS | NCDOT |  |
| 478 | 1.7.12.3 | Central Let | milestone | 0d | 2029-03-05 | 2029-03-05 | 453FF, 477 | 0d |  | 4CS2 | CS | NCDOT | M0550 |
| 479 | 1.7.13 | **Division Let Activities** |  | 90d | 2028-09-28 | 2029-02-19 |  | 10d |  |  |  |  |  |
| 480 | 1.7.13.1 | **Finalize the PS&E Package** |  | 30d | 2028-09-28 | 2028-11-08 |  | 10d |  | 4RD1 | RD |  |  |
| 481 | 1.7.13.1.1 | Submit 100% Unsealed Plans, Quantities, and Special Provisions |  | 10d | 2028-09-28 | 2028-10-11 | 448, 402, 372, 349 | 10d | 0d | 4RD1 | RD | PEF |  |
| 482 | 1.7.13.1.2 | Review of 100% Unsealed Plans, Quantities and Special Provisions |  | 10d | 2028-10-12 | 2028-10-25 | 481 | 10d | 0d | 4RD1 | RD | NCDOT |  |
| 483 | 1.7.13.1.3 | Revise & Submit 100% Sealed Plans, Quantities and Special Provisions |  | 10d | 2028-10-26 | 2028-11-08 | 482, 460FF | 10d | 0d | 4RD1 | RD | PEF |  |
| 484 | 1.7.13.1.4 | Submit 100% Sealed Plans, Quantities, and Special Provisions | milestone | 0d | 2028-11-08 | 2028-11-08 | 483 | 10d | 0d | 4RD1 | RD | PEF |  |
| 485 | 1.7.13.2 | **Complete PS&E Package and Advertise the Project** |  | 60d | 2028-11-09 | 2029-02-19 |  | 10d |  | 4CS1 | CS |  |  |
| 486 | 1.7.13.2.1 | Update Construction Estimate Pricing |  | 10d | 2028-11-09 | 2028-11-30 | 484 | 10d | 0d | 4CS1 | CS | NCDOT |  |
| 487 | 1.7.13.2.2 | Construction Funding Request and Project Authorization |  | 35d | 2028-12-01 | 2029-01-29 | 486, 349, 311, 439, 452 | 10d | 0d | 4CS1 | CS | NCDOT |  |
| 488 | 1.7.13.2.3 | Complete PS&E Package |  | 15d | 2028-11-09 | 2028-12-07 | 168, 438, 448, 484, 311, 372 | 40d | 30d | 4CS1 | CS | NCDOT |  |
| 489 | 1.7.13.2.4 | Project Advertisement |  | 15d | 2029-01-30 | 2029-02-19 | 487, 488, 433FF, 454FF | 10d | 0d | 4CS1 | CS | NCDOT |  |
| 490 | 1.7.13.3 | Division POC Let (DPOC) | milestone | 0d | 2029-02-19 | 2029-02-19 | 489, 453FF | 10d |  | 4CS2 | CS | NCDOT |  |

Notes:
- 466: Delete if Division Let
- 477: Advertisement can be longer for larger more expensive projects
- 478: Adjust 4RD1/Critical durations to meet actual central let dates
- 479: Delete if Central Let
- 490: Adjust 4RD1/Critical durations to meet actual division let dates
